# BOOM Structure

Schedule from MS Project, 2000-12-11 to 2004-06-28, status date 2003-08-31, A marks actual dates.
Boom Structure Development Schedule
NASA GSFC
Status Date: 08/31/2003 / Baseline Date: 01/31/2003 R1

## Calendars

- Standard w/ 10 Gov't Holidays: Mon-Fri 08:00-12:00, 13:00-17:00; Sat-Sun off. Exceptions (off unless hours are given): 2000-12-25, 2001-01-01, 2001-01-15, 2001-02-19, 2001-05-28, 2001-07-04, 2001-09-03, 2001-10-08, 2001-11-12, 2001-11-22, 2001-12-25, 2002-01-01, 2002-01-14, 2002-02-18, 2002-05-27, 2002-07-04, 2002-09-02, 2002-10-07, 2002-11-11, 2002-11-28, 2002-12-25, 2003-01-01, 2003-01-13, 2003-02-17, 2003-05-26, 2003-07-04, 2003-09-01, 2003-10-06, 2003-11-10, 2003-11-27, 2003-12-25, 2004-01-01, 2004-01-12, 2004-02-16, 2004-05-31.

## Schedule

| ID | WBS | Task | Type | Duration | Start | Finish | Predecessors | Complete | Remaining | Baseline start | Baseline finish | Baseline duration | Total slack | Free slack | Constraint | Text14 | Text23 | Text13 | Text20 | Text22 |
| --- | --- | --- | --- | --- | --- | --- | --- | --- | --- | --- | --- | --- | --- | --- | --- | --- | --- | --- | --- | --- |
| 1 | 1 | **Management** |  | 418d | 2002-10-29 A | 2004-06-28 |  | 3% | 406.7d | 2002-10-29 | 2004-06-28 | 418d | 0d |  |  |  |  |  |  |  |
| 2 | 1.1 | **Milestones** |  | 418d | 2002-10-29 A | 2004-06-28 |  | 3% | 406.7d | 2002-10-29 | 2004-06-28 | 418d | 0d |  |  |  |  |  |  |  |
| 3 | 1.1.1 | Boom Review (Trigger) |  | 1d | 2002-10-29 A | 2002-10-29 A |  | 100% |  | 2002-10-29 | 2002-10-29 | 1d |  |  | start no earlier than 2002-09-30 | Boom |  |  |  |  |
| 4 | 1.1.2 | Protoflight Design Review |  | 1d | 2003-04-01 A | 2003-04-01 A | 53 | 100% |  | 2003-04-01 | 2003-04-01 | 1d |  |  | start no earlier than 2003-03-31 | Boom | Protoflight Design Reviewed |  |  |  |
| 5 | 1.1.3 | Boom Structure Protoflight Test Preparation Workshop |  | 1d | 2003-06-04 A | 2003-06-04 A | 63, 72, 77 | 100% |  | 2003-06-04 | 2003-06-04 | 1d |  |  | start no earlier than 2003-06-04 | Boom | Protoflight Test Preparation Workshop |  |  |  |
| 6 | 1.1.4 | Boom Structure Protoflight Test Results Workshop and Deployment Demo |  | 1d | 2003-08-21 A | 2003-08-21 A | 82FF | 100% |  | 2003-08-21 | 2003-08-21 | 1d |  |  |  | Boom | Protoflight Test Results Workshop and Deployment Demo |  |  |  |
| 7 | 1.1.5 | **Contingency** |  | 214d | 2003-08-21 A | 2004-06-28 |  |  | 214d | 2003-08-21 | 2004-06-28 | 214d | 0d |  |  |  |  |  |  |  |
| 8 | 1.1.5.1 | Protoflight Completion Contingency | milestone | 0d | 2003-08-21 A | 2003-08-21 A | 82 | 100% |  | 2003-08-21 | 2003-08-21 | 0d |  |  |  | Boom |  |  |  |  |
| 9 | 1.1.5.2 | Protoflight Contingency |  | 64d | 2003-09-18 | 2003-12-19 | 20, 85 |  |  | 2003-09-18 | 2003-12-19 | 64d | 7d | 0d |  | Boom |  |  |  |  |
| 10 | 1.1.5.3 | Boom Structure FM 1 Contingency |  | 40d | 2004-03-22 | 2004-05-14 | 23 |  |  | 2004-03-22 | 2004-05-14 | 40d | 27d | 0d |  | Boom |  |  |  |  |
| 11 | 1.1.5.4 | Boom Structure FM 2 Contingency |  | 40d | 2004-05-03 | 2004-06-28 | 26 |  |  | 2004-05-03 | 2004-06-28 | 40d | 0d |  |  | Boom |  |  |  |  |
| 12 | 1.1.6 | **Receiveables** |  | 43d | 2003-03-31 A | 2003-06-02 |  |  | 43d | 2003-03-31 | 2003-06-02 | 43d | 271d |  |  |  |  |  |  |  |
| 13 | 1.1.6.1 | Receive Boom Test Plan Comments From APL | milestone | 0d | 2003-03-31 A | 2003-03-31 A |  | 100% |  | 2003-03-31 | 2003-03-31 | 0d |  |  | start no earlier than 2003-03-31 | Boom |  |  |  |  |
| 14 | 1.1.6.2 | Receive Safety Plan (IMPACT Schedule) Comments From APL | milestone | 0d | 2003-05-31 | 2003-05-31 |  |  |  | 2003-05-31 | 2003-05-31 | 0d | 271d |  | start no earlier than 2003-05-31 | Boom |  |  |  |  |
| 15 | 1.1.6.3 | Receive Thermal Blanketing Schedule from APL | milestone | 0d | 2003-05-31 A | 2003-05-31 A |  | 100% |  | 2003-05-31 | 2003-05-31 | 0d |  |  | start no earlier than 2003-05-31 | Boom |  |  |  |  |
| 16 | 1.1.6.4 | Receive Testing Level Input | milestone | 0d | 2003-05-31 A | 2003-05-31 A |  | 100% |  | 2003-05-31 | 2003-05-31 | 0d |  |  | start no earlier than 2003-05-31 | Boom |  |  |  |  |
| 17 | 1.1.6.5 | Receive EM Thermal Blankets from APL | milestone | 0d | 2003-06-02 A | 2003-06-02 A |  | 100% |  | 2003-06-02 | 2003-06-02 | 0d |  |  | start no earlier than 2003-06-02 | Boom |  |  |  |  |
| 18 | 1.1.7 | **Deliverables** |  | 285d | 2003-05-09 A | 2004-06-28 |  |  | 285d | 2003-05-09 | 2004-06-28 | 285d | 0d |  |  |  |  |  |  |  |
| 19 | 1.1.7.1 | Deliver Boom Structure Blanket Mockup to APL | milestone | 0d | 2003-05-09 A | 2003-05-09 A | 149FS+5d | 100% |  | 2003-05-09 | 2003-05-09 | 0d |  |  |  | Boom | Boom Structure Blanket Mockup Delivered to APL |  |  |  |
| 20 | 1.1.7.2 | Protoflight Boom Complete | milestone | 0d | 2003-08-21 A | 2003-08-21 A | 8 | 100% |  | 2003-08-21 | 2003-08-21 | 0d |  |  |  | Boom | Protoflight Boom Complete | Boom Suite | Protoflight Boom Structure | Boom - Completion of Boom Protoflight Unit |
| 21 | 1.1.7.3 | Deliver Protoflight Boom for I & T | milestone | 0d | 2003-12-19 | 2003-12-19 | 9 |  |  | 2003-12-19 | 2003-12-19 | 0d | 7d | 0d | finish no later than 2003-12-31 | Boom | Protoflight Boom Delivered for Boom Suite I & T |  |  | Deliver Protoflight Boom for I & T |
| 22 | 1.2.5.2.4 | Receive Protoflight BOOM for FM 1 BOOM Suite I & T | milestone | 0d | 2003-12-29 | 2003-12-29 | 21FS+5d |  |  | 2003-12-29 | 2003-12-29 | 0d | 65d | 55d |  |  |  |  |  |  |
| 23 | 1.1.7.5 | FM 1 Boom Structure Avaliable | milestone | 0d | 2004-03-19 | 2004-03-19 | 120 |  |  | 2004-03-19 | 2004-03-19 | 0d | 27d | 0d |  | Boom | FM 1 Boom Structure Complete | Boom Suite |  |  |
| 24 | 1.1.7.6 | Delivery FM 1 Boom Structure | milestone | 0d | 2004-05-14 | 2004-05-14 | 10 |  |  | 2004-05-14 | 2004-05-14 | 0d | 27d | 0d |  | Boom | FM 1 Boom Structure Ready for Delivery |  | FM 1 Boom Structure | Boom - FM 1 Structure Delivered |
| 25 | 1.2.5.2.2 | Receive BOOM FM 1 For BOOM Suite I & T | milestone | 0d | 2004-05-14 | 2004-05-14 | 24 |  |  | 2004-05-14 | 2004-05-14 | 0d | 27d | 15d |  |  |  |  |  |  |
| 26 | 1.1.7.8 | FM 2 Boom Structure Available | milestone | 0d | 2004-04-30 | 2004-04-30 | 146 |  |  | 2004-04-30 | 2004-04-30 | 0d | 0d |  |  | Boom | FM 2 Boom Structure Complete | Boom Suite |  |  |
| 27 | 1.1.7.9 | Delivery FM 2 Boom Structure | milestone | 0d | 2004-06-28 | 2004-06-28 | 11 |  |  | 2004-06-28 | 2004-06-28 | 0d | 0d |  |  | Boom | FM 2 Boom Structure Ready for Delivery |  | FM 2 Boom Structure | Boom - FM 2 Structure Delivered |
| 28 | 1.2.5.3.2 | Receive BOOM FM 2 For BOOM Suite I & T | milestone | 0d | 2004-06-28 | 2004-06-28 | 27 |  |  | 2004-06-28 | 2004-06-28 | 0d | 0d |  |  |  |  |  |  |  |
| 29 | 1.1.7.11 | Deliver Updated Boom FEM to APL | milestone | 0d | 2003-09-26 | 2003-09-26 | 89FS+10d, 90FS+10d, 91FS+10d |  |  | 2003-09-26 | 2003-09-26 | 0d | 188d |  |  | Boom |  |  |  |  |

| ID | WBS | Task | Type | Duration | Start | Finish | Predecessors | Complete | Remaining | Baseline start | Baseline finish | Baseline duration | Total slack | Constraint | Text11 | Text12 | Text13 | Text14 | Text16 | Text28 | Text21 |
| --- | --- | --- | --- | --- | --- | --- | --- | --- | --- | --- | --- | --- | --- | --- | --- | --- | --- | --- | --- | --- | --- |
| 30 | 2 | **Systems Engineering** |  | 599d | 2000-12-11 A | 2003-04-30 A |  | 100% |  | 2000-12-11 | 2003-04-30 | 599d |  |  | STEREO | IMPACT | Boom Suite | Boom | Boom | UC-B |  |
| 31 | 2.1 | **Prototype Demonstration Technology** |  | 347d | 2000-12-11 A | 2002-04-29 A |  | 100% |  | 2000-12-11 | 2002-04-29 | 347d |  |  | STEREO | IMPACT | Boom Suite | Boom | Boom | UC-B |  |
| 32 | 2.1.1 | BOOM Lock Button Ring |  | 210d | 2001-04-23 A | 2002-02-22 A |  | 100% |  | 2001-04-23 | 2002-02-22 | 210d |  | start no earlier than 2001-04-22 | STEREO | IMPACT | Boom Suite | Boom | Boom | UC-B |  |
| 33 | 2.1.2 | BOOM Tubes |  | 297d | 2000-12-11 A | 2002-02-15 A |  | 100% |  | 2000-12-11 | 2002-02-15 | 297d |  | start no earlier than 2000-12-11 | STEREO | IMPACT | Boom Suite | Boom | Boom | UC-B |  |
| 34 | 2.1.3 | BOOM Stacer Spring |  | 29d | 2002-01-21 A | 2002-03-01 A |  | 100% |  | 2002-01-21 | 2002-03-01 | 29d |  | start no earlier than 2002-01-20 | STEREO | IMPACT | Boom Suite | Boom | Boom | UC-B |  |
| 35 | 2.1.4 | BOOM Characterization |  | 56d | 2001-12-03 A | 2002-02-22 A |  | 100% |  | 2001-12-03 | 2002-02-22 | 56d |  | start no earlier than 2001-12-02 | STEREO | IMPACT | Boom Suite | Boom | Boom | UC-B |  |
| 36 | 2.1.5 | BOOM Rework |  | 20d | 2002-03-11 A | 2002-04-05 A | 32, 34, 35 | 100% |  | 2002-03-11 | 2002-04-05 | 20d |  |  | STEREO | IMPACT | Boom Suite | Boom | Boom | UC-B |  |
| 37 | 2.1.6 | BOOM Retest |  | 16d | 2002-04-08 A | 2002-04-29 A | 36 | 100% |  | 2002-04-08 | 2002-04-29 | 16d |  |  | STEREO | IMPACT | Boom Suite | Boom | Boom | UC-B |  |
| 38 | 2.2 | **Studies/Analysis** |  | 24d | 2002-03-11 A | 2002-04-12 A |  | 100% |  | 2002-03-11 | 2002-04-12 | 24d |  |  | STEREO | IMPACT | Boom Suite | Boom | Boom | UC-B |  |
| 39 | 2.2.1 | BOOM Carbon Fiber Tube Analysis |  | 24d | 2002-03-11 A | 2002-04-12 A | 33 | 100% |  | 2002-03-11 | 2002-04-12 | 24d |  |  | STEREO | IMPACT | Boom Suite | Boom | Boom | UC-B |  |
| 40 | 2.3 | **STE** |  | 453.25d | 2001-06-11 A | 2003-04-02 A |  | 100% |  | 2001-06-11 | 2003-04-02 | 453.25d |  |  | STEREO | IMPACT | Boom Suite | Boom | Boom | UC-B |  |
| 41 | 2.3.1 | BOOM Thermal Analysis |  | 40d | 2001-06-11 A | 2002-10-02 A |  | 100% |  | 2001-06-11 | 2002-10-02 | 40d |  |  | STEREO | IMPACT | Boom Suite | Boom | Boom | UC-B |  |
| 42 | 2.3.2 | BOOM Mechanical Analysis |  | 25d | 2002-03-18 A | 2003-04-02 A |  | 100% |  | 2002-03-18 | 2003-04-02 | 25d |  |  | STEREO | IMPACT | Boom Suite | Boom | Boom | UC-B |  |
| 43 | 2.4 | **Deployment** |  | 162d | 2002-02-19 A | 2002-10-08 A |  | 100% |  | 2002-02-19 | 2002-10-08 | 162d |  |  | STEREO | IMPACT | Boom Suite | Boom | Boom | UC-B |  |
| 44 | 2.4.1 | BOOM Stacer Analysis |  | 34d | 2002-02-19 A | 2002-04-05 A |  | 100% |  | 2002-02-19 | 2002-04-05 | 34d |  | start no earlier than 2002-02-18 | STEREO | IMPACT | Boom Suite | Boom | Boom | UC-B |  |
| 45 | 2.4.2 | BOOM Release Analysis |  | 20d | 2002-04-15 A | 2002-08-08 A | 44 | 100% |  | 2002-04-15 | 2002-08-08 | 20d |  |  | STEREO | IMPACT | Boom Suite | Boom | Boom | UC-B |  |
| 46 | 2.4.3 | BOOM Stability Analysis |  | 45.5d | 2002-03-04 A | 2002-10-08 A | 45FS-40d | 100% |  | 2002-03-04 | 2002-10-08 | 45.5d |  |  | STEREO | IMPACT | Boom Suite | Boom | Boom | UC-B |  |
| 47 | 2.5 | BOOM SWEA Mount Analysis |  | 25d | 2002-03-11 A | 2002-04-12 A |  | 100% |  | 2002-03-11 | 2002-04-12 | 25d |  | start no earlier than 2002-03-11 | STEREO | IMPACT | Boom Suite | Boom | Boom | UC-B |  |
| 48 | 2.6 | IMPACT / SC I/F Analysis |  | 33.75d | 2002-04-08 A | 2002-09-13 A |  | 100% |  | 2002-04-08 | 2002-09-13 | 33.75d |  |  | STEREO | IMPACT | Boom Suite | Boom | Boom | UC-B |  |
| 49 | 2.7 | BOOM Analysis Complete | milestone | 0d | 2003-04-30 A | 2003-04-30 A | 41, 42, 46, 48, 50 | 100% |  | 2003-04-30 | 2003-04-30 | 0d |  | start no earlier than 2003-04-30 | STEREO | IMPACT | Boom Suite | Boom | Boom | UC-B | Analysis Cmplt. |
| 50 | 2.8 | SMA ID Analysis |  | 5d | 2002-10-01 A | 2002-10-08 A |  | 100% |  | 2002-10-01 | 2002-10-08 | 5d |  | start no earlier than 2002-09-30 | STEREO | IMPACT | Boom Suite | Boom | Boom | UC-B |  |
| 51 | 3 | **Protoflight** |  | 210d | 2002-11-25 A | 2003-09-24 |  | 95% | 10.68d | 2002-11-25 | 2003-09-24 | 210d | 190d |  |  |  |  |  |  |  |  |
| 52 | 3.1 | **Telescoping** |  | 128.75d | 2002-11-25 A | 2003-05-30 A |  | 100% |  | 2002-11-25 | 2003-05-30 | 128.75d |  |  |  |  |  |  |  |  |  |
| 53 | 3.1.1 | Rework Boom Design Based on pre-CDR Test Results |  | 55d | 2002-11-25 A | 2003-02-13 A |  | 100% |  | 2002-11-25 | 2003-02-13 | 55d |  | start no earlier than 2002-11-25 |  |  |  | Boom |  |  |  |

| ID | WBS | Task | Duration | Start | Finish | Predecessors | Complete | Baseline start | Baseline finish | Baseline duration | Constraint | Text14 | Text23 |
| --- | --- | --- | --- | --- | --- | --- | --- | --- | --- | --- | --- | --- | --- |
| 54 | 3.1.2 | **Procurments** | 70d | 2003-01-24 A | 2003-05-02 A |  | 100% | 2003-01-24 | 2003-05-02 | 70d |  |  |  |
| 55 | 3.1.2.1 | Place Stacer Order | 1d | 2003-01-29 A | 2003-01-29 A |  | 100% | 2003-01-29 | 2003-01-29 | 1d | start no earlier than 2002-12-17 | Boom | Stacer Ordered |
| 56 | 3.1.2.2 | Receive and Inspect Stacer | 2d | 2003-04-01 A | 2003-04-02 A | 55FS+41d | 100% | 2003-04-01 | 2003-04-02 | 2d | start no earlier than 2003-03-31 | Boom | Stacer Received & Inspected |
| 57 | 3.1.2.3 | Order Tubes | 1d | 2003-01-24 A | 2003-01-24 A | 53SS+15d | 100% | 2003-01-24 | 2003-01-24 | 1d |  | Boom | Protoflight Tubes Ordered |
| 58 | 3.1.2.4 | Receive and Inspect Tubes | 2d | 2003-05-01 A | 2003-05-02 A | 57FS+40d | 100% | 2003-05-01 | 2003-05-02 | 2d | start no earlier than 2003-04-30 | Boom | Protoflight Tubes Received & Inspected |
| 59 | 3.1.3 | **Fabrication** | 44.75d | 2003-03-07 A | 2003-05-08 A |  | 100% | 2003-03-07 | 2003-05-08 | 44.75d |  |  |  |
| 60 | 3.1.3.1 | Machine Tubes as necessary | 5d | 2003-04-10 A | 2003-05-08 A | 58 | 100% | 2003-04-10 | 2003-05-08 | 5d |  | Boom |  |
| 61 | 3.1.3.2 | Machine Other Protoflight Telescoping Parts | 25d | 2003-03-07 A | 2003-04-10 A | 53 | 100% | 2003-03-07 | 2003-04-10 | 25d | finish no earlier than 2003-04-10 | Boom | Other Protoflight Telescoping Parts Fabricated |
| 62 | 3.1.4 | Assemble Telescoping Boom | 10d | 2003-05-08 A | 2003-05-22 A | 60, 61 | 100% | 2003-05-08 | 2003-05-22 | 10d | start no earlier than 2003-04-30 | Boom | Protoflight Telescoping Boom Assembled |
| 63 | 3.1.5 | Test Protoflight Telescoping Boom | 5d | 2003-05-22 A | 2003-05-30 A | 62 | 100% | 2003-05-22 | 2003-05-30 | 5d |  | Boom | Protoflight Telescoping Boom Subassembly Tested |
| 64 | 3.2 | **Harness** | 87d | 2003-01-31 A | 2003-06-04 A |  | 100% | 2003-01-31 | 2003-06-04 | 87d |  |  |  |
| 65 | 3.2.1 | **Procurements** | 87d | 2003-01-31 A | 2003-06-04 A |  | 100% | 2003-01-31 | 2003-06-04 | 87d |  |  |  |
| 66 | 3.2.1.1 | Place Pin Puller Order | 1d | 2003-01-31 A | 2003-01-31 A |  | 100% | 2003-01-31 | 2003-01-31 | 1d | start no earlier than 2002-12-17 | Boom | Pin Puller Ordered |
| 67 | 3.2.1.2 | Receive Pin Puller | 2d | 2003-06-03 A | 2003-06-04 A | 66FS+60d | 100% | 2003-06-03 | 2003-06-04 | 2d | start no earlier than 2003-06-03 | Boom | Pin Puller Received & Inspected |
| 68 | 3.2.2 | **Fabrication** | 26d | 2003-03-03 A | 2003-04-07 A |  | 100% | 2003-03-03 | 2003-04-07 | 26d |  |  |  |
| 69 | 3.2.2.1 | Machine Housing Parts | 25d | 2003-03-03 A | 2003-04-07 A | 53FS+5d | 100% | 2003-03-03 | 2003-04-07 | 25d | start no earlier than 2003-03-01 | Boom | Protoflight Harness Housing Fabricated |
| 70 | 3.2.3 | **Assembly** | 10d | 2003-05-01 A | 2003-05-14 A |  | 100% | 2003-05-01 | 2003-05-14 | 10d |  |  |  |
| 71 | 3.2.3.1 | Assemble Housing subassembly | 10d | 2003-05-01 A | 2003-05-14 A | 69 | 100% | 2003-05-01 | 2003-05-14 | 10d | start no earlier than 2003-04-30 | Boom | Protoflight Harness Housing Subassembly Assembled |
| 72 | 3.2.4 | Fit Test Housing | 5d | 2003-05-15 A | 2003-05-21 A | 71 | 100% | 2003-05-15 | 2003-05-21 | 5d | start no earlier than 2003-04-30 | Boom | Protoflight Harness Housing Fit Checked |
| 73 | 3.3 | **Mounting** | 63d | 2003-03-03 A | 2003-05-29 A |  | 100% | 2003-03-03 | 2003-05-29 | 63d |  |  |  |
| 74 | 3.3.1 | Design Protoflight Mountings | 25d | 2003-03-03 A | 2003-04-04 A |  | 100% | 2003-03-03 | 2003-04-04 | 25d | start no earlier than 2003-02-28 | Boom | Protoflight Mountings Designed |
| 75 | 3.3.2 | Fabrication Protoflight Mountings | 20d | 2003-04-07 A | 2003-05-14 A | 74 | 100% | 2003-04-07 | 2003-05-14 | 20d | start no earlier than 2003-03-17 | Boom | Protoflight Mountings Fabricated |
| 76 | 3.3.3 | Assemble Protoflight Mountings | 5d | 2003-05-15 A | 2003-05-21 A | 75 | 100% | 2003-05-15 | 2003-05-21 | 5d |  | Boom | Protoflight Mountings Assembled |
| 77 | 3.3.4 | Fit Check Protoflight Mountings Test | 5d | 2003-05-22 A | 2003-05-29 A | 76 | 100% | 2003-05-22 | 2003-05-29 | 5d |  | Boom | Protoflight Mountings Fit Checked |

| ID | WBS | Task | Duration | Start | Finish | Predecessors | Complete | Remaining | Baseline start | Baseline finish | Baseline duration | Total slack | Free slack | Constraint | Text14 | Text23 |
| --- | --- | --- | --- | --- | --- | --- | --- | --- | --- | --- | --- | --- | --- | --- | --- | --- |
| 78 | 3.4 | **Integration & Test** | 81.25d | 2003-05-30 A | 2003-09-24 |  | 63% | 30.47d | 2003-05-30 | 2003-09-24 | 81.25d | 190d |  |  |  |  |
| 79 | 3.4.1 | Integrate Protoflight subassemblies | 5d | 2003-05-30 A | 2003-06-06 A | 63, 72, 77, 56 | 100% |  | 2003-05-30 | 2003-06-06 | 5d |  |  |  | Boom | Protoflight Boom Integrated |
| 80 | 3.4.2 | Protoflight Deployment Test | 5d | 2003-06-06 A | 2003-06-13 A | 79, 67, 16 | 100% |  | 2003-06-06 | 2003-06-13 | 5d |  |  |  | Boom | Protoflight Deployment Test Complete |
| 81 | 3.4.3 | Protoflight Boom Vibration Test | 2d | 2003-07-21 A | 2003-07-22 A | 80 | 100% |  | 2003-07-21 | 2003-07-22 | 2d |  |  | start no earlier than 2003-07-21 | Boom | Protoflight Boom Vibration Test Complete |
| 82 | 3.4.4 | Protoflight Boom Themal Vac Testing | 7d | 2003-08-08 A | 2003-08-18 A | 81 | 100% |  | 2003-08-08 | 2003-08-18 | 7d |  |  | start no earlier than 2003-08-08 | Boom | Protoflight Boom Themal Vac Testing Complete |
| 83 | 3.4.5 | Install EM Blankets on Protoflight Boom | 1d | 2003-08-29 A | 2003-08-29 A | 17, 82 | 100% |  | 2003-08-29 | 2003-08-29 | 1d |  |  |  | Boom |  |
| 84 | 3.4.6 | Protoflight Boom Thermal Balance Testing | 5d | 2003-09-09 | 2003-09-15 | 83 |  |  | 2003-09-09 | 2003-09-15 | 5d | 7d | 0d | start no earlier than 2003-09-09 | Boom | Protoflight Boom Thermal Balance Testing |
| 85 | 3.4.7 | Protoflight Boom Post Environmental Deployment Test | 2d | 2003-09-16 | 2003-09-17 | 84 |  |  | 2003-09-16 | 2003-09-17 | 2d | 7d | 0d |  | Boom | Protoflight Boom Post Environmental Deployment Test |
| 86 | 3.4.8 | Document Protoflight Boom Test Results | 5d | 2003-09-18 | 2003-09-24 | 85 |  |  | 2003-09-18 | 2003-09-24 | 5d | 190d |  |  | Boom |  |
| 87 | 4 | **FM 1 & FM 2** | 19d | 2003-08-18 A | 2003-09-12 |  | 50% | 9.5d | 2003-08-18 | 2003-09-12 | 19d | 15d |  |  |  |  |
| 88 | 4.1 | **Design** | 15d | 2003-08-22 A | 2003-09-12 |  | 51% | 7.29d | 2003-08-22 | 2003-09-12 | 15d | 15d |  |  |  |  |
| 89 | 4.1.1 | Rework Telescoping Design Based on Protoflight Test Results | 15d | 2003-08-22 A | 2003-09-12 | 6 | 40% | 9d | 2003-08-22 | 2003-09-12 | 15d | 0d |  |  | Boom | Telescoping Design Reworked (if necessary) |
| 90 | 4.1.2 | Rework Harness Design Based on Protoflight Test Results | 10d | 2003-08-22 A | 2003-09-05 | 6 | 60% | 4d | 2003-08-22 | 2003-09-05 | 10d | 5d | 0d |  | Boom | Harness Design Reworked (if necessary) |
| 91 | 4.1.3 | Mounting Design rework based on Protoflight Results | 10d | 2003-08-22 A | 2003-09-05 | 6 | 60% | 4d | 2003-08-22 | 2003-09-05 | 10d | 20d | 0d |  | Boom | Mounting Design Reworked (if necessary) |
| 92 | 4.2 | **Procurments** | 18d | 2003-08-18 A | 2003-09-11 |  | 33% | 12d | 2003-08-18 | 2003-09-11 | 18d | 16d |  |  |  |  |
| 93 | 4.2.1 | Trigger to Order Flight Boom Structure Tubes | 1d | 2003-08-18 A | 2003-08-18 A | 6 | 100% |  | 2003-08-18 | 2003-08-18 | 1d |  |  |  | Boom | Order Flight Tubes |
| 94 | 4.2.2 | Receive and Inspect Flight Boom Structure Tubes | 2d | 2003-09-10 | 2003-09-11 | 93FS+15d |  |  | 2003-09-10 | 2003-09-11 | 2d | 16d | 0d |  | Boom | Flight Tubes Received & Inspected |
| 95 | 5 | **FM 1** | 133d | 2003-09-08 | 2004-03-19 |  |  |  | 2003-09-08 | 2004-03-19 | 133d | 5d |  |  |  |  |
| 96 | 5.1 | **Telescoping** | 56d | 2003-09-12 | 2003-12-03 |  |  |  | 2003-09-12 | 2003-12-03 | 56d | 0d |  |  |  |  |
| 97 | 5.1.1 | **Fabrication** | 26d | 2003-09-12 | 2003-10-20 |  |  |  | 2003-09-12 | 2003-10-20 | 26d | 0d |  |  |  |  |
| 98 | 5.1.1.1 | Machine FM 1 Boom Structure Tubes as necessary | 10d | 2003-09-12 | 2003-09-25 | 94 |  |  | 2003-09-12 | 2003-09-25 | 10d | 16d |  |  | Boom |  |
| 99 | 5.1.1.2 | Machine FM 1 Boom Structure Parts | 25d | 2003-09-15 | 2003-10-20 | 89 |  |  | 2003-09-15 | 2003-10-20 | 25d | 0d |  |  | Boom | FM 1 Boom Structure Partes Fabricated |
| 100 | 5.1.2 | Assemble FM 1 Boom Structure Telescoping Assembly | 20d | 2003-10-21 | 2003-11-18 | 98, 99 |  |  | 2003-10-21 | 2003-11-18 | 20d | 0d |  |  | Boom | FM 1 Boom Structure Telescoping Assembly Assembled |
| 101 | 5.1.3 | Test FM 1 Boom Structure Telescoping Assembly | 10d | 2003-11-19 | 2003-12-03 | 100 |  |  | 2003-11-19 | 2003-12-03 | 10d | 0d |  |  | Boom | FM 1 Boom Structure Telescoping Assembly Tested |

| ID | WBS | Task | Duration | Start | Finish | Predecessors | Complete | Remaining | Baseline start | Baseline finish | Baseline duration | Total slack | Free slack | Text14 | Text23 |
| --- | --- | --- | --- | --- | --- | --- | --- | --- | --- | --- | --- | --- | --- | --- | --- |
| 102 | 5.2 | **Harness** | 55d | 2003-09-08 | 2003-11-25 |  |  |  | 2003-09-08 | 2003-11-25 | 55d | 5d |  |  |  |
| 103 | 5.2.1 | **Fabrication** | 25d | 2003-09-08 | 2003-10-13 |  |  |  | 2003-09-08 | 2003-10-13 | 25d | 5d |  |  |  |
| 104 | 5.2.1.1 | Machine FM 1 Harness Parts | 25d | 2003-09-08 | 2003-10-13 | 90 |  |  | 2003-09-08 | 2003-10-13 | 25d | 5d | 0d | Boom | FM 1 Harness Parts Fabricated |
| 105 | 5.2.2 | **Assembly** | 20d | 2003-10-14 | 2003-11-11 |  |  |  | 2003-10-14 | 2003-11-11 | 20d | 5d |  |  |  |
| 106 | 5.2.2.1 | Assemble FM 1 Harness subassembly | 20d | 2003-10-14 | 2003-11-11 | 104 |  |  | 2003-10-14 | 2003-11-11 | 20d | 5d | 0d | Boom | FM 1 Harness subassembly Assembled |
| 107 | 5.2.3 | FM1 Harness Test | 10d | 2003-11-12 | 2003-11-25 | 106 |  |  | 2003-11-12 | 2003-11-25 | 10d | 5d |  |  | FM 1 Harness Tested |
| 108 | 5.3 | **Mounting** | 40d | 2003-09-08 | 2003-11-03 |  |  |  | 2003-09-08 | 2003-11-03 | 40d | 20d |  |  |  |
| 109 | 5.3.1 | FM 1Boom Structure Mounting Fabrication | 20d | 2003-09-08 | 2003-10-03 | 91 |  |  | 2003-09-08 | 2003-10-03 | 20d | 20d | 0d | Boom | FM 1 Boom Structure Mounting Fabricated |
| 110 | 5.3.2 | FM 1Boom Structure Mounting Assembly | 10d | 2003-10-07 | 2003-10-20 | 109 |  |  | 2003-10-07 | 2003-10-20 | 10d | 20d | 0d | Boom | FM 1 Boom Structure Mounting Assemblies Assembled |
| 111 | 5.3.3 | FM 1 Boom Structure Mounting Test | 10d | 2003-10-21 | 2003-11-03 | 110 |  |  | 2003-10-21 | 2003-11-03 | 10d | 20d |  | Boom | FM 1 Boom Structure Mountings Tested |
| 112 | 5.4 | **Integration & Test** | 73d | 2003-12-04 | 2004-03-19 |  |  |  | 2003-12-04 | 2004-03-19 | 73d | 0d |  |  |  |
| 113 | 5.4.1 | Integrate FM 1 Boom Structure subassemblies | 20d | 2003-12-04 | 2004-01-02 | 101, 107, 111 |  |  | 2003-12-04 | 2004-01-02 | 20d | 0d |  | Boom | FM 1 Boom Structure subassemblies Integrated |
| 114 | 5.4.2 | FM 1 Boom Structure Deployment Test | 10d | 2004-01-05 | 2004-01-19 | 113 |  |  | 2004-01-05 | 2004-01-19 | 10d | 0d |  | Boom | FM 1 Boom Structure Deployment Testing Completed |
| 115 | 4.2.2 | Calibrate STE-U/D FM 1 | 20d | 2003-12-12 | 2004-01-13 |  |  |  | 2003-12-12 | 2004-01-13 | 20d | 4d | 0d |  |  |
| 116 | 5.4.4 | FM 1 Boom Structure Vibration Testing Completed | 4d | 2004-01-20 | 2004-01-23 | 114, 115 |  |  | 2004-01-20 | 2004-01-23 | 4d | 0d |  | Boom | FM 1 Boom Structure Vibration Test |
| 117 | 4.2.4 | STE-U FM 1 Thermal Vacuum/Balance | 14d | 2004-01-26 | 2004-02-12 | 116 |  |  | 2004-01-26 | 2004-02-12 | 14d | 0d |  |  |  |
| 118 | 5.4.6 | FM 1 Boom Structure Themal Vac Testing Completed | 30d | 2004-01-26 | 2004-03-08 | 116 |  |  | 2004-01-26 | 2004-03-08 | 30d | 0d |  | Boom | FM 1 Boom Structure Themal Vac Testing |
| 119 | 5.4.7 | FM 1 Boom Structure Post Environmental Deployment Test Completed | 4d | 2004-03-09 | 2004-03-12 | 118 |  |  | 2004-03-09 | 2004-03-12 | 4d | 27d | 0d | Boom | FM 1 Boom Structure Post Environmental Deployment Test |
| 120 | 5.4.8 | Document FM 1 Boom Structure Test Results | 5d | 2004-03-15 | 2004-03-19 | 119 |  |  | 2004-03-15 | 2004-03-19 | 5d | 27d | 0d | Boom |  |
| 121 | 6 | **FM 2** | 280d | 2003-03-24 A | 2004-04-30 |  | 11% | 248.06d | 2003-03-24 | 2004-04-30 | 280d | 0d |  |  |  |
| 122 | 6.1 | **Telescoping** | 56d | 2003-09-12 | 2003-12-03 |  |  |  | 2003-09-12 | 2003-12-03 | 56d | 4d |  |  |  |
| 123 | 6.1.1 | **Fabrication** | 26d | 2003-09-12 | 2003-10-20 |  |  |  | 2003-09-12 | 2003-10-20 | 26d | 4d |  |  |  |
| 124 | 6.1.1.1 | Machine FM 2 Boom Structure Tubes as necessary | 10d | 2003-09-12 | 2003-09-25 | 94 |  |  | 2003-09-12 | 2003-09-25 | 10d | 20d | 16d | Boom |  |
| 125 | 6.1.1.2 | Machine FM 2 Boom Structure Telescoping Parts | 25d | 2003-09-15 | 2003-10-20 | 89 |  |  | 2003-09-15 | 2003-10-20 | 25d | 4d | 0d | Boom | FM 2 Boom Structure Partes Fabricated |
| 126 | 6.1.2 | Assemble FM 2 Boom Structure Telescoping Assembly | 20d | 2003-10-21 | 2003-11-18 | 124, 125 |  |  | 2003-10-21 | 2003-11-18 | 20d | 4d | 0d | Boom | FM 2 Boom Structure Telescoping Assembly Assembled |
| 127 | 6.1.3 | Test FM 2 Boom Structure Telescoping Assembly | 10d | 2003-11-19 | 2003-12-03 | 126 |  |  | 2003-11-19 | 2003-12-03 | 10d | 4d | 0d | Boom | FM 2 Boom Structure Telescoping Assembly Tested |

| ID | WBS | Task | Duration | Start | Finish | Predecessors | Complete | Baseline start | Baseline finish | Baseline duration | Total slack | Free slack | Constraint | Text14 | Text23 |
| --- | --- | --- | --- | --- | --- | --- | --- | --- | --- | --- | --- | --- | --- | --- | --- |
| 128 | 6.2 | **Harness** | 55d | 2003-09-08 | 2003-11-25 |  |  | 2003-09-08 | 2003-11-25 | 55d | 9d |  |  |  |  |
| 129 | 6.2.1 | **Fabrication** | 25d | 2003-09-08 | 2003-10-13 |  |  | 2003-09-08 | 2003-10-13 | 25d | 9d |  |  |  |  |
| 130 | 6.2.1.1 | Machine FM 2 Harness Parts | 25d | 2003-09-08 | 2003-10-13 | 90 |  | 2003-09-08 | 2003-10-13 | 25d | 9d | 0d |  | Boom | FM 2 Harness Parts Fabricated |
| 131 | 6.2.2 | **Assembly** | 20d | 2003-10-14 | 2003-11-11 |  |  | 2003-10-14 | 2003-11-11 | 20d | 9d |  |  |  |  |
| 132 | 6.2.2.1 | Assemble FM 2 Harness subassembly | 20d | 2003-10-14 | 2003-11-11 | 130 |  | 2003-10-14 | 2003-11-11 | 20d | 9d | 0d |  | Boom | FM 2 Harness subassembly Assembled |
| 133 | 6.2.3 | FM 2 Harness Test | 10d | 2003-11-12 | 2003-11-25 | 132 |  | 2003-11-12 | 2003-11-25 | 10d | 9d | 5d |  | Boom | FM 2 Harness Tested |
| 134 | 6.3 | **Mounting** | 40d | 2003-09-08 | 2003-11-03 |  |  | 2003-09-08 | 2003-11-03 | 40d | 24d |  |  |  |  |
| 135 | 6.3.1 | FM 2 Boom Structure Mountings Fabrication | 20d | 2003-09-08 | 2003-10-03 | 91 |  | 2003-09-08 | 2003-10-03 | 20d | 24d | 0d |  | Boom | FM 2 Boom Structure Mounting Fabricated |
| 136 | 6.3.2 | FM 2 Boom Structure Mountings Assembly | 10d | 2003-10-07 | 2003-10-20 | 135 |  | 2003-10-07 | 2003-10-20 | 10d | 24d | 0d |  | Boom | FM 2 Boom Structure Mounting Assemblies Assembled |
| 137 | 6.3.3 | FM 2 Boom Structure Mountings Test | 10d | 2003-10-21 | 2003-11-03 | 136 |  | 2003-10-21 | 2003-11-03 | 10d | 24d | 20d |  | Boom | FM 2 Boom Structure Mountings Tested |
| 138 | 6.4 | **Integration & Test** | 103d | 2003-12-04 | 2004-04-30 |  |  | 2003-12-04 | 2004-04-30 | 103d | 0d |  |  |  |  |
| 139 | 6.4.1 | Integrate FM 2 Boom Structure subassemblies | 20d | 2003-12-04 | 2004-01-02 | 127, 133, 137 |  | 2003-12-04 | 2004-01-02 | 20d | 4d | 0d |  | Boom | FM 2 Boom Structure subassemblies Integrated |
| 140 | 6.4.2 | FM 2 Boom Structure Deployment Test | 10d | 2004-01-05 | 2004-01-19 | 139 |  | 2004-01-05 | 2004-01-19 | 10d | 4d | 3d |  | Boom | FM 2 Boom Structure Deployment Testing Completed |
| 141 | 4.3.2 | Calibrate STE-U/D FM 2 | 18d | 2003-12-26 | 2004-01-22 |  |  | 2003-12-26 | 2004-01-22 | 18d | 1d | 0d |  |  |  |
| 142 | 6.4.4 | FM 2 Boom Structure Vibration Test | 4d | 2004-01-23 | 2004-01-28 | 140, 141 |  | 2004-01-23 | 2004-01-28 | 4d | 1d | 0d |  | Boom | FM 2 Boom Structure Vibration Test |
| 143 | 4.3.4 | STE-U FM 2 Thermal Vacuum | 10d | 2004-01-29 | 2004-02-11 | 142 |  | 2004-01-29 | 2004-02-11 | 10d | 1d | 0d |  |  |  |
| 144 | 6.4.6 | FM 2 Boom Structure Themal Vac Testing | 30d | 2004-03-09 | 2004-04-19 | 142, 118 |  | 2004-03-09 | 2004-04-19 | 30d | 0d |  |  | Boom | FM 2 Boom Structure Themal Vac Testing |
| 145 | 6.4.7 | FM 2 Boom Structure Post Environmental Deployment Test | 4d | 2004-04-20 | 2004-04-23 | 144 |  | 2004-04-20 | 2004-04-23 | 4d | 0d |  |  | Boom | FM 2 Boom Structure Post Environmental Deployment Test |
| 146 | 6.4.8 | Document FM 2 Boom Structure Test Results | 5d | 2004-04-26 | 2004-04-30 | 145 |  | 2004-04-26 | 2004-04-30 | 5d | 0d |  |  | Boom |  |
| 147 | 6.5 | **Blanket Model** | 30d | 2003-03-24 A | 2003-05-02 A |  | 100% | 2003-03-24 | 2003-05-02 | 30d |  |  |  |  |  |
| 148 | 6.5.1 | Create Boom Structure Blanket Mockup Drawings | 5d | 2003-03-24 A | 2003-03-28 A | 15 | 100% | 2003-03-24 | 2003-03-28 | 5d |  |  | start no earlier than 2003-03-24 |  |  |
| 149 | 6.5.2 | Fabricate Boom Structure Blanket Mockup | 25d | 2003-03-31 A | 2003-05-02 A | 148 | 100% | 2003-03-31 | 2003-05-02 | 25d |  |  |  |  | Boom Structure Blanket Mockup Fabricated |
