# MAG - Magnetometer

Schedule from MS Project, 2000-09-01 to 2004-01-26, status date 2003-08-31, A marks actual dates.
MAG Instrument Development Schedule
NASA GSFC
Status Date: 08/31/2003 / Baseline Date: 05/31/2003 R1a UNDER REVIEW

## Calendars

- Standard w/ 10 Gov't Holidays: Mon-Fri 08:00-12:00, 13:00-17:00; Sat-Sun off. Exceptions (off unless hours are given): 2000-09-04, 2000-10-09, 2000-11-13, 2000-11-23, 2000-12-25, 2001-01-01, 2001-01-15, 2001-02-19, 2001-05-28, 2001-07-04, 2001-09-03, 2001-10-08, 2001-11-12, 2001-11-22, 2001-12-25, 2002-01-01, 2002-01-14, 2002-02-18, 2002-05-27, 2002-07-04, 2002-09-02, 2002-10-07, 2002-11-11, 2002-11-28, 2002-12-25, 2003-01-01, 2003-01-13, 2003-02-17, 2003-05-26, 2003-07-04, 2003-09-01, 2003-10-06, 2003-11-10, 2003-11-27, 2003-12-25, 2004-01-01, 2004-01-12.

## Schedule

| ID | WBS | Task | Type | Duration | Start | Finish | Predecessors | Complete | Remaining | Baseline start | Baseline finish | Baseline duration | Total slack | Free slack | Constraint | Text11 | Text12 | Text13 | Text14 | Text16 | Text28 | Text8 | Text21 | Text20 | Text22 | Text23 |
| --- | --- | --- | --- | --- | --- | --- | --- | --- | --- | --- | --- | --- | --- | --- | --- | --- | --- | --- | --- | --- | --- | --- | --- | --- | --- | --- |
| 1 | 1 | **Management** |  | 472.45d | 2002-03-01 A | 2004-01-19 |  | 5% | 449.95d | 2002-03-01 | 2004-01-19 | 472.45d | 0d |  |  | STEREO | IMPACT | Boom Suite | MAG | MAG | GSFC |  |  |  |  |  |
| 2 | 1.1 | **Milestones** |  | 472.45d | 2002-03-01 A | 2004-01-19 |  | 5% | 449.95d | 2002-03-01 | 2004-01-19 | 472.45d | 0d |  |  | STEREO | IMPACT | Boom Suite | MAG | MAG | GSFC |  |  |  |  |  |
| 3 | 1.1.1 | MAG ETU Internal Contingency | milestone | 0d | 2003-01-17 A | 2003-01-17 A | 61 | 100% |  | 2003-01-17 | 2003-01-17 | 0d |  |  | start no earlier than 2002-11-30 | STEREO | IMPACT | Boom Suite | MAG | MAG | GSFC |  |  |  |  |  |
| 4 | 1.1.2 | MAG FM 1 Internal Contingency |  | 10d | 2003-11-18 | 2003-12-03 | 69 |  |  | 2003-11-18 | 2003-12-03 | 10d | 30d | 0d |  | STEREO | IMPACT | Boom Suite | MAG | MAG | GSFC |  |  |  |  |  |
| 5 | 1.1.3 | MAG FM 2 Internal Contingency |  | 30d | 2003-12-03 | 2004-01-19 | 71 |  |  | 2003-12-03 | 2004-01-19 | 30d | 0d |  |  | STEREO | IMPACT | Boom Suite | MAG | MAG | GSFC |  |  |  |  |  |
| 6 | 1.1.4 | **Receivables** |  | 229d | 2002-03-01 A | 2003-01-28 A |  | 100% |  | 2002-03-01 | 2003-01-28 | 229d |  |  |  | STEREO | IMPACT | Boom Suite | MAG | MAG | GSFC |  |  |  |  |  |
| 7 | 1.1.5.3 | Deliver IDPU Simulator GSE Hardware to GSFC |  | 1d | 2002-07-03 A | 2002-07-03 A |  | 100% |  | 2002-07-03 | 2002-07-03 | 1d |  |  | start no earlier than 2002-07-01 | STEREO | IMPACT | Boom Suite | MAG | MAG | GSFC |  |  |  |  |  |
| 8 | 1.1.4.2 | Receive MAG IDPU Simulator GSE Hardware From UC-B | milestone | 0d | 2002-07-03 A | 2002-07-03 A | 7 | 100% |  | 2002-07-03 | 2002-07-03 | 0d |  |  | start no earlier than 2002-07-01 | STEREO | IMPACT | Boom Suite | MAG | MAG | GSFC |  |  |  |  |  |
| 9 | 1.1.5.5 | Deliver IDPU Simulator Software to GSFC | milestone | 0d | 2002-07-03 A | 2002-07-03 A |  | 100% |  | 2002-07-03 | 2002-07-03 | 0d |  |  |  | STEREO | IMPACT | Boom Suite | MAG | MAG | GSFC |  |  |  |  |  |
| 10 | 1.1.4.4 | Receive MAG IDPU Simulator Software From UC-B | milestone | 0d | 2002-07-03 A | 2002-07-03 A | 9 | 100% |  | 2002-07-03 | 2002-07-03 | 0d |  |  | start no earlier than 2002-05-31 | STEREO | IMPACT | Boom Suite | MAG | MAG | GSFC | IDPU Sim |  |  |  |  |
| 11 | 1.1.5.1 | Deliver MAG/DCB PWB Form Factor | milestone | 0d | 2002-03-01 A | 2002-03-01 A |  | 100% |  | 2002-03-01 | 2002-03-01 | 0d |  |  |  | STEREO | IMPACT | Boom Suite | MAG | MAG | GSFC |  |  |  |  |  |
| 12 | 1.1.4.6 | Receive MAG/DCB PWB Form Factor | milestone | 0d | 2002-03-01 A | 2002-03-01 A | 11 | 100% |  | 2002-03-01 | 2002-03-01 | 0d |  |  |  | STEREO | IMPACT | Boom Suite | MAG | MAG | GSFC | PWB FF | DCB/PWB Form Factor |  |  |  |
| 13 | 1.1.5.17 | Deliver ETU MAG/IDPU Test Results |  | 1d | 2003-01-28 A | 2003-01-28 A |  | 100% |  | 2003-01-28 | 2003-01-28 | 1d |  |  |  | STEREO | IMPACT | Boom Suite | MAG | MAG | GSFC |  |  |  |  |  |
| 14 | 1.1.4.8 | Receive ETU MAG/IDPU Test Results |  | 1d | 2003-01-28 A | 2003-01-28 A | 13 | 100% |  | 2003-01-28 | 2003-01-28 | 1d |  |  |  | STEREO | IMPACT | Boom Suite | MAG | MAG | GSFC | IDPU I/F Res |  |  |  |  |
| 15 | 1.1.5 | **Deliverables** |  | 250.45d | 2003-01-20 A | 2004-01-19 |  | 99% | 0d | 2003-01-20 | 2004-01-19 | 250.45d | 0d |  |  | STEREO | IMPACT | Boom Suite | MAG | MAG | GSFC |  |  |  |  |  |
| 16 | 1.1.5.1 | Deliver ETU MAG to UC-B For IDPU Test |  | 1d | 2003-01-20 A | 2003-01-20 A | 3 | 100% |  | 2003-01-20 | 2003-01-20 | 1d |  |  | start no earlier than 2002-07-31 | STEREO | IMPACT | Boom Suite | MAG | MAG | GSFC | ETU | ETU to UCB | MAG ETU | MAG - Deliver ETU to UC-B | Deliver ETU For IDPU I/F Testing |
| 17 | 1.1.4.8 | Receive ETU MAG From GSFC For ETU IDPU Test |  | 1d | 2003-01-20 A | 2003-01-20 A | 16 | 100% |  | 2003-01-20 | 2003-01-20 | 1d |  |  |  | STEREO | IMPACT | Boom Suite | MAG | MAG | GSFC |  |  |  |  |  |
| 18 | 1.1.5.3 | Deliver MAG FM 1 For IDPU/BOOM Suite FM 1 I & T | milestone | 0d | 2003-12-03 | 2003-12-03 | 4 |  |  | 2003-12-03 | 2003-12-03 | 0d | 30d | 0d |  | STEREO | IMPACT | Boom Suite | MAG | MAG | GSFC | FM 1 | FM1 to UCB | FM1 MAG | MAG - Deliver FM 1 to UC-B | Deliver FM 1 |
| 19 | 1.1.4.10 | Receive FM 1 MAG From GSFC For FM 1 IDPU Test | milestone | 0d | 2003-12-10 | 2003-12-10 | 18FS+5d |  |  | 2003-12-10 | 2003-12-10 | 0d | 33.55d | 16.55d |  | STEREO | IMPACT | Boom Suite | MAG | MAG | GSFC |  |  |  |  |  |
| 20 | 1.1.5.5 | Deliver MAG FM 2 For IDPU/BOOM Suite FM 2 I & T | milestone | 0d | 2004-01-19 | 2004-01-19 | 5 |  |  | 2004-01-19 | 2004-01-19 | 0d | 0d |  |  | STEREO | IMPACT | Boom Suite | MAG | MAG | GSFC | FM 2 | FM2 to UCB | FM2 MAG | MAG - Deliver FM 2 to UC-B | Deliver FM 2 |
| 21 | 1.1.4.12 | Receive FM 2 MAG From GSFC For FM 2IDPU Test | milestone | 0d | 2004-01-26 | 2004-01-26 | 20FS+5d |  |  | 2004-01-26 | 2004-01-26 | 0d | 69.55d | 26.55d |  | STEREO | IMPACT | Boom Suite | MAG | MAG | GSFC |  |  |  |  |  |
| 22 | 2 | **Systems Engineering** |  | 113d | 2000-09-01 A | 2001-02-15 A |  | 100% |  | 2000-09-01 | 2001-02-15 | 113d |  |  |  | STEREO | IMPACT | Boom Suite | MAG | MAG | GSFC |  |  |  |  |  |
| 23 | 2.1 | **Studies** |  | 113d | 2000-09-01 A | 2001-02-15 A |  | 100% |  | 2000-09-01 | 2001-02-15 | 113d |  |  |  | STEREO | IMPACT | Boom Suite | MAG | MAG | GSFC |  |  |  |  |  |
| 24 | 2.1.1 | MAG ADC Trade Study |  | 113d | 2000-09-01 A | 2001-02-15 A |  | 100% |  | 2000-09-01 | 2001-02-15 | 113d |  |  | start no earlier than 2000-09-01 | STEREO | IMPACT | Boom Suite | MAG | MAG | GSFC |  |  |  |  |  |

Notes:
- 3: Removed 02 days of duration 1/9/03
- 4: Removed 20 days of duration 1/9/03
- 5: Removed 105 days of duration 1/9/03
- 18: FNL of 6/2/03 removed 1/9/03 / FNL of 6/30/03 moved to 9/29/03 due to parts screening and I & T need no earlier than October of 2003. (Rev 1a?)
- 20: FNL of 12/1/03 removed 1/9/03 / Deliver of 12/1/03 reinstated with Rev 1

| ID | WBS | Task | Type | Duration | Start | Finish | Predecessors | Complete | Remaining | Baseline start | Baseline finish | Baseline duration | Total slack | Free slack | Constraint | Text11 | Text12 | Text13 | Text14 | Text16 | Text28 | Text23 | Text8 | Text21 | Text20 |
| --- | --- | --- | --- | --- | --- | --- | --- | --- | --- | --- | --- | --- | --- | --- | --- | --- | --- | --- | --- | --- | --- | --- | --- | --- | --- |
| 25 | 3 | **Design, Manufacture, Assembly and Test** |  | 696.45d | 2001-02-16 A | 2003-11-25 |  | 88% | 83.97d | 2001-02-16 | 2003-11-25 | 696.45d | 20d |  |  | STEREO | IMPACT | Boom Suite | MAG | MAG | GSFC |  |  |  |  |
| 26 | 3.1 | **Procurements** |  | 408.5d | 2002-01-10 A | 2003-08-25 A |  | 100% |  | 2002-01-10 | 2003-08-25 | 408.5d |  |  |  | STEREO | IMPACT | Boom Suite | MAG | MAG | GSFC |  |  |  |  |
| 27 | 3.1.1 | Procure MAG Long Lead Parts |  | 250d | 2002-01-10 A | 2003-04-09 A | 33 | 100% |  | 2002-01-10 | 2003-04-09 | 250d |  |  |  | STEREO | IMPACT | Boom Suite | MAG | MAG | GSFC | Long Lead Procurements Complete |  |  |  |
| 28 | 3.1.2 | Up-screen parts |  | 106d | 2003-03-03 A | 2003-08-25 A |  | 100% |  | 2003-03-03 | 2003-08-25 | 106d |  |  | finish no earlier than 2003-07-08 | STEREO | IMPACT | Boom Suite | MAG | MAG | GSFC |  |  |  |  |
| 29 | 3.2 | **Design** |  | 560d | 2001-02-16 A | 2003-05-09 A |  | 100% |  | 2001-02-16 | 2003-05-09 | 560d |  |  |  | STEREO | IMPACT | Boom Suite | MAG | MAG | GSFC |  |  |  |  |
| 30 | 3.2.1 | Begin MAG System Design |  | 1d | 2001-02-16 A | 2001-02-16 A | 31SS | 100% |  | 2001-02-16 | 2001-02-16 | 1d |  |  |  | STEREO | IMPACT | Boom Suite | MAG | MAG | GSFC |  | Sys | System Design |  |
| 31 | 3.2.2 | MAG System Design |  | 59d | 2001-02-16 A | 2001-05-10 A | 24 | 100% |  | 2001-02-16 | 2001-05-10 | 59d |  |  |  | STEREO | IMPACT | Boom Suite | MAG | MAG | GSFC |  |  |  |  |
| 32 | 3.2.3 | MAG FPGA Design |  | 94d | 2001-11-01 A | 2002-03-20 A | 31 | 100% |  | 2001-11-01 | 2002-03-20 | 94d |  |  |  | STEREO | IMPACT | Boom Suite | MAG | MAG | GSFC |  | FPGA |  | MAG FPGA Dsgn |
| 33 | 3.2.4 | MAG Analog Card Design |  | 46d | 2001-11-01 A | 2002-01-09 A | 31 | 100% |  | 2001-11-01 | 2002-01-09 | 46d |  |  |  | STEREO | IMPACT | Boom Suite | MAG | MAG | GSFC |  | Ana Cd |  |  |
| 34 | 3.2.5 | MAG Design Update |  | 19d | 2003-03-03 A | 2003-04-11 A | 14FS+3d | 100% |  | 2003-03-03 | 2003-04-11 | 19d |  |  | start no earlier than 2003-03-01 | STEREO | IMPACT | Boom Suite | MAG | MAG | GSFC |  | Upd |  |  |
| 35 | 3.2.6 | MAG Layout |  | 20d | 2002-03-01 A | 2002-03-28 A | 33, 12 | 100% |  | 2002-03-01 | 2002-03-28 | 20d |  |  | start no earlier than 2002-05-31 | STEREO | IMPACT | Boom Suite | MAG | MAG | GSFC |  | Layout |  |  |
| 36 | 3.2.7 | MAG Re-layout |  | 20d | 2003-04-14 A | 2003-05-09 A | 34 | 100% |  | 2003-04-14 | 2003-05-09 | 20d |  |  |  | STEREO | IMPACT | Boom Suite | MAG | MAG | GSFC |  |  |  |  |
| 37 | 3.3 | **Fabrication** |  | 387.45d | 2002-03-29 A | 2003-10-13 |  | 58% | 161.21d | 2002-03-29 | 2003-10-13 | 387.45d | 10d |  |  | STEREO | IMPACT | Boom Suite | MAG | MAG | GSFC |  |  |  |  |
| 38 | 3.3.1 | **ETU** |  | 305d | 2002-03-29 A | 2003-06-13 A |  | 100% |  | 2002-03-29 | 2003-06-13 | 305d |  |  |  | STEREO | IMPACT | Boom Suite | MAG | MAG | GSFC |  |  |  |  |
| 39 | 3.3.1.1 | ETU MAG PWB Fabrication |  | 10d | 2002-03-29 A | 2002-04-11 A | 35 | 100% |  | 2002-03-29 | 2002-04-11 | 10d |  |  | start no earlier than 2002-05-31 | STEREO | IMPACT | Boom Suite | MAG | MAG | GSFC |  | Begin |  |  |
| 40 | 3.3.1.2 | ETU #2 PWB Fabrication |  | 20d | 2003-05-12 A | 2003-06-13 A | 36 | 100% |  | 2003-05-12 | 2003-06-13 | 20d |  |  |  | STEREO | IMPACT | Boom Suite | MAG | MAG | GSFC |  |  |  |  |
| 41 | 3.3.2 | **FM 1 & FM 2** |  | 135.45d | 2003-04-01 A | 2003-10-13 |  | 50% | 68.1d | 2003-04-01 | 2003-10-13 | 135.45d | 10d |  |  | STEREO | IMPACT | Boom Suite | MAG | MAG | GSFC |  |  |  |  |
| 42 | 3.3.2.1 | **FM 1** |  | 135.45d | 2003-04-01 A | 2003-10-13 |  | 50% | 68.1d | 2003-04-01 | 2003-10-13 | 135.45d | 0d |  |  | STEREO | IMPACT | Boom Suite | MAG | MAG | GSFC |  |  |  |  |
| 43 | 1.1.13 | Instrument CDR | milestone | 3d | 2002-11-20 A | 2002-11-22 A |  | 100% |  | 2002-11-20 | 2002-11-22 | 3d |  |  | finish no earlier than 2002-11-22 | STEREO | IMPACT | Boom Suite | MAG | MAG | GSFC |  |  |  |  |
| 44 | 3.3.2.1.2 | FM 1 MAG Sensor Build |  | 35d | 2003-04-01 A | 2003-05-19 A | 43, 14FS+3d | 100% |  | 2003-04-01 | 2003-05-19 | 35d |  |  | start no earlier than 2003-03-31 | STEREO | IMPACT | Boom Suite | MAG | MAG | GSFC |  | Sensor |  |  |
| 45 | 3.3.2.1.3 | FM 1 MAG PWB Fabrication |  | 27d | 2003-04-14 A | 2003-09-26 | 34, 43, 62 | 3% | 26.2d | 2003-04-14 | 2003-09-26 | 27d | 0d |  |  | STEREO | IMPACT | Boom Suite | MAG | MAG | GSFC | FM 1 PWB Fabricated | PWB |  |  |
| 46 | 3.3.2.1.4 | Coupon Test |  | 10d | 2003-09-26 | 2003-10-13 | 45 |  |  | 2003-09-26 | 2003-10-13 | 10d | 0d |  |  | STEREO | IMPACT | Boom Suite | MAG | MAG | GSFC | FM 1 PWB Coupon Tested | Cpn Tst |  |  |
| 47 | 3.3.2.2 | **FM 2** |  | 135.45d | 2003-04-01 A | 2003-10-13 |  | 50% | 68.1d | 2003-04-01 | 2003-10-13 | 135.45d | 10d |  |  | STEREO | IMPACT | Boom Suite | MAG | MAG | GSFC |  |  |  |  |
| 48 | 3.3.2.2.1 | FM 2 MAG Sensor Build |  | 35d | 2003-04-01 A | 2003-05-19 A | 43, 14FS+3d | 100% |  | 2003-04-01 | 2003-05-19 | 35d |  |  | start no earlier than 2003-03-31 | STEREO | IMPACT | Boom Suite | MAG | MAG | GSFC |  | Sensor |  |  |
| 49 | 3.3.2.2.2 | FM 2 MAG PWB Fabrication |  | 27d | 2003-04-14 A | 2003-09-26 | 34, 43, 62 | 3% | 26.2d | 2003-04-14 | 2003-09-26 | 27d | 10d | 0d | start no earlier than 2003-03-31 | STEREO | IMPACT | Boom Suite | MAG | MAG | GSFC | FM 2 PWB Fabricated | PWB |  |  |
| 50 | 3.3.2.2.3 | Coupon Test |  | 10d | 2003-09-26 | 2003-10-13 | 49 |  |  | 2003-09-26 | 2003-10-13 | 10d | 10d |  | start no earlier than 2003-05-31 | STEREO | IMPACT | Boom Suite | MAG | MAG | GSFC | FM 2 PWB Coupon Tested | Cpn Tst |  |  |

| ID | WBS | Task | Duration | Start | Finish | Predecessors | Complete | Remaining | Baseline start | Baseline finish | Baseline duration | Total slack | Free slack | Constraint | Text11 | Text12 | Text13 | Text14 | Text16 | Text28 | Text8 | Text23 | Text21 |
| --- | --- | --- | --- | --- | --- | --- | --- | --- | --- | --- | --- | --- | --- | --- | --- | --- | --- | --- | --- | --- | --- | --- | --- |
| 51 | 3.4 | **Assembly** | 397.45d | 2002-04-12 A | 2003-11-11 |  | 50% | 198.72d | 2002-04-12 | 2003-11-11 | 397.45d | 0d |  |  | STEREO | IMPACT | Boom Suite | MAG | MAG | GSFC |  |  |  |
| 52 | 3.4.1 | **ETU** | 305d | 2002-04-12 A | 2003-06-27 A |  | 100% |  | 2002-04-12 | 2003-06-27 | 305d |  |  |  | STEREO | IMPACT | Boom Suite | MAG | MAG | GSFC |  |  |  |
| 53 | 3.4.1.1 | ETU MAG Board Load | 10d | 2002-04-12 A | 2002-04-25 A | 32, 39 | 100% |  | 2002-04-12 | 2002-04-25 | 10d |  |  | start no earlier than 2002-05-31 | STEREO | IMPACT | Boom Suite | MAG | MAG | GSFC | Assm |  |  |
| 54 | 3.4.1.2 | ETU#2 board load | 10d | 2003-06-16 A | 2003-06-27 A | 40 | 100% |  | 2003-06-16 | 2003-06-27 | 10d |  |  |  | STEREO | IMPACT | Boom Suite | MAG | MAG | GSFC |  |  |  |
| 55 | 3.4.2 | **FM 1** | 10d | 2003-10-13 | 2003-10-27 |  |  |  | 2003-10-13 | 2003-10-27 | 10d | 0d |  |  | STEREO | IMPACT | Boom Suite | MAG | MAG | GSFC |  |  |  |
| 56 | 3.4.2.1 | FM 1 MAG Analog Board Build | 10d | 2003-10-13 | 2003-10-27 | 46, 43, 27, 28 |  |  | 2003-10-13 | 2003-10-27 | 10d | 0d |  |  | STEREO | IMPACT | Boom Suite | MAG | MAG | GSFC | Assm | FM 1 Analog Board Loaded |  |
| 57 | 3.4.3 | **FM 2** | 10d | 2003-10-27 | 2003-11-11 |  |  |  | 2003-10-27 | 2003-11-11 | 10d | 0d |  |  | STEREO | IMPACT | Boom Suite | MAG | MAG | GSFC |  |  |  |
| 58 | 3.4.3.1 | FM 2 MAG Analog Board Build | 10d | 2003-10-27 | 2003-11-11 | 50, 43, 27, 56 |  |  | 2003-10-27 | 2003-11-11 | 10d | 0d |  |  | STEREO | IMPACT | Boom Suite | MAG | MAG | GSFC | Assm | FM 2 Analog Board Loaded |  |
| 59 | 3.5 | **Test** | 308.45d | 2002-09-03 A | 2003-11-25 |  | 81% | 59.78d | 2002-09-03 | 2003-11-25 | 308.45d | 20d |  |  | STEREO | IMPACT | Boom Suite | MAG | MAG | GSFC |  |  |  |
| 60 | 3.5.1 | **ETU** | 242.25d | 2002-09-03 A | 2003-08-20 A |  | 100% |  | 2002-09-03 | 2003-08-20 | 242.25d |  |  |  | STEREO | IMPACT | Boom Suite | MAG | MAG | GSFC |  |  |  |
| 61 | 3.5.1.1 | ETU MAG Test | 47.2d | 2002-09-03 A | 2003-01-17 A | 8, 10, 53FS+3d | 100% |  | 2002-09-03 | 2003-01-17 | 47.2d |  |  | start no earlier than 2002-08-31 | STEREO | IMPACT | Boom Suite | MAG | MAG | GSFC | Tst |  |  |
| 62 | 3.5.1.2 | ETU#2 MAG Test | 36d | 2003-06-30 A | 2003-08-20 A | 54 | 100% |  | 2003-06-30 | 2003-08-20 | 36d |  |  |  | STEREO | IMPACT | Boom Suite | MAG | MAG | GSFC |  |  |  |
| 63 | 3.5.2 | **FM 1** | 10d | 2003-10-27 | 2003-11-11 |  |  |  | 2003-10-27 | 2003-11-11 | 10d | 30d |  |  | STEREO | IMPACT | Boom Suite | MAG | MAG | GSFC |  |  |  |
| 64 | 3.5.2.1 | FM 1 MAG Test | 10d | 2003-10-27 | 2003-11-11 | 44, 56 |  |  | 2003-10-27 | 2003-11-11 | 10d | 30d | 0d |  | STEREO | IMPACT | Boom Suite | MAG | MAG | GSFC | Tst | FM 1 Tested |  |
| 65 | 3.5.3 | **FM 2** | 10d | 2003-11-11 | 2003-11-25 |  |  |  | 2003-11-11 | 2003-11-25 | 10d | 0d |  |  | STEREO | IMPACT | Boom Suite | MAG | MAG | GSFC |  |  |  |
| 66 | 3.5.3.1 | FM 2 MAG Test | 10d | 2003-11-11 | 2003-11-25 | 48, 58 |  |  | 2003-11-11 | 2003-11-25 | 10d | 0d |  |  | STEREO | IMPACT | Boom Suite | MAG | MAG | GSFC | Tst | FM 2 Tested |  |
| 67 | 4 | **Integration & Test** | 15d | 2003-11-11 | 2003-12-03 |  |  |  | 2003-11-11 | 2003-12-03 | 15d | 10d |  |  | STEREO | IMPACT | Boom Suite | MAG | MAG | GSFC |  |  |  |
| 68 | 4.1 | **FM 1** | 5d | 2003-11-11 | 2003-11-18 |  |  |  | 2003-11-11 | 2003-11-18 | 5d | 30d |  |  | STEREO | IMPACT | Boom Suite | MAG | MAG | GSFC |  |  |  |
| 69 | 4.1.1 | MAG FM 1 Calibrate | 5d | 2003-11-11 | 2003-11-18 | 64 |  |  | 2003-11-11 | 2003-11-18 | 5d | 30d | 0d |  | STEREO | IMPACT | Boom Suite | MAG | MAG | GSFC | Cal | FM 1 Calibrated | FM1 Cal. |
| 70 | 4.2 | **FM 2** | 5d | 2003-11-25 | 2003-12-03 |  |  |  | 2003-11-25 | 2003-12-03 | 5d | 0d |  |  | STEREO | IMPACT | Boom Suite | MAG | MAG | GSFC |  |  |  |
| 71 | 4.2.1 | MAG FM 2 Calibrate | 5d | 2003-11-25 | 2003-12-03 | 66 |  |  | 2003-11-25 | 2003-12-03 | 5d | 0d |  |  | STEREO | IMPACT | Boom Suite | MAG | MAG | GSFC | Cal | FM 2 Calibrated | FM2 Cal. |

Notes:
- 61: since we don't have input set this at 20% to get some sort of reality
