# IMPACT SEP

Schedule from MS Project, 2001-08-15 to 2004-07-07, status date 2003-08-31, A marks actual dates.
SEP Package Development With I & T
NASA GSFC
Status Date: 08/31/2003 / Baseline Date: 01/31/2003 R1

## Calendars

- Standard w/ 10 Gov't Holidays: Mon-Fri 08:00-12:00, 13:00-17:00; Sat-Sun off. Exceptions (off unless hours are given): 2001-09-03, 2001-10-08, 2001-11-12, 2001-11-22, 2001-12-25, 2002-01-01, 2002-01-14, 2002-02-18, 2002-05-27, 2002-07-04, 2002-09-02, 2002-10-07, 2002-11-11, 2002-11-28, 2002-12-25, 2003-01-01, 2003-01-13, 2003-02-17, 2003-05-26, 2003-07-04, 2003-09-01, 2003-10-06, 2003-11-10, 2003-11-27, 2003-12-25, 2004-01-01, 2004-01-12, 2004-02-16, 2004-05-31, 2004-07-05.

## Schedule

| ID | WBS | Task | Type | Duration | Start | Finish | Predecessors | Complete | Remaining | Baseline start | Baseline finish | Baseline duration | Total slack | Free slack | Constraint | Text11 | Text12 | Text13 | Text28 | Text14 | Text16 | Text22 | Text23 | Text17 | Text20 |
| --- | --- | --- | --- | --- | --- | --- | --- | --- | --- | --- | --- | --- | --- | --- | --- | --- | --- | --- | --- | --- | --- | --- | --- | --- | --- |
| 1 | 1 | **Management** |  | 575d | 2002-01-15 A | 2004-04-27 |  | 99% | 0d | 2002-01-15 | 2004-04-27 | 575d | 49d |  |  | STEREO | IMPACT | SEP Package | CIT |  |  |  |  |  |  |
| 2 | 1.1 | **Milestones** |  | 575d | 2002-01-15 A | 2004-04-27 |  | 99% | 0d | 2002-01-15 | 2004-04-27 | 575d | 49d |  |  | STEREO | IMPACT | SEP Package | CIT |  |  |  |  |  |  |
| 3 | 1.1.1 | SEP Software Design Review | milestone | 0d | 2002-05-21 A | 2002-05-21 A |  | 100% |  | 2002-05-21 | 2002-05-21 | 0d |  |  | start no earlier than 2002-07-31 | STEREO | IMPACT | SEP Package | CIT | SEP Cen | MAG |  |  |  |  |
| 4 | 1.1.2 | SEP Central EM Ready for I & T | milestone | 0d | 2003-06-09 A | 2003-06-09 A | 43, 57, 63 | 100% |  | 2003-06-09 | 2003-06-09 | 0d |  |  | start no earlier than 2003-06-30 | STEREO | IMPACT | SEP Package |  | SEP Cen |  | SEP Central - EM Ready for I & T | EM Boards Available for EM I & T |  |  |
| 5 | 1.1.3 | SEP Central FM 1 Ready for I & T | milestone | 0d | 2004-02-02 | 2004-02-02 | 34, 47, 53FS+1d, 59, 65 |  |  | 2004-01-30 | 2004-01-30 | 0d | 0d |  |  | STEREO | IMPACT | SEP Package |  | SEP Cen |  | SEP Central - FM 1 Ready for I & T | FM 1 Ready for I & T |  |  |
| 6 | 2.3.5 | Integrate/test SEP Central FM 1 |  | 5d | 2004-02-03 | 2004-02-09 | 5 |  |  |  |  |  | 0d |  |  | STEREO | IMPACT | SEP Package |  |  |  |  |  |  |  |
| 7 | 1.1.5 | SEP Central FM 2 Ready for I & T | milestone | 0d | 2004-03-26 | 2004-03-26 | 49, 55, 61, 67, 36 |  |  | 2004-03-25 | 2004-03-25 | 0d | 14d | 6d |  | STEREO | IMPACT | SEP Package |  | SEP Cen |  | SEP Central - FM 2 Ready for I & T | FM 2 Ready for I & T |  |  |
| 8 | 2.4.12 | Integrate FM 2 LVPS into SEP Central (if necessary) |  | 2d | 2004-04-06 | 2004-04-07 | 7 |  |  |  |  |  | 8d | 0d |  | STEREO | IMPACT | SEP Package |  |  |  |  |  |  |  |
| 9 | 1.1.7 | **Receivables** |  | 271d | 2003-03-31 A | 2004-04-27 |  | 99% | 0d | 2003-03-31 | 2004-04-27 | 271d | 49d |  |  | STEREO | IMPACT | SEP Package | CIT |  |  |  |  |  |  |
| 10 | 1.1.7.1 | Receive Instrument Simulator | milestone | 0d | 2003-03-31 A | 2003-03-31 A |  | 100% |  | 2003-03-31 | 2003-03-31 | 0d |  |  | start no earlier than 2003-03-31 | STEREO | IMPACT | SEP Package |  |  |  |  |  |  |  |
| 11 | 1.1.7.2 | **HET** |  | 0d | 2003-06-30 A | 2003-06-30 A |  | 100% |  | 2003-06-30 | 2003-06-30 | 0d |  |  |  | STEREO | IMPACT | SEP Package |  |  |  |  |  |  |  |
| 12 | 1.1.6.6 | Deliver HET S/W for SEP Central MISC/HET CPU24 Testing | milestone | 0d | 2003-10-08 | 2003-10-08 |  |  |  | 2003-10-08 | 2003-10-08 | 0d | 106d |  |  | STEREO | IMPACT | SEP Package |  |  |  |  |  |  |  |
| 13 | 1.1.7.2.2 | (OBSOLETE) Receive HET S/W for SEP Central I/F Testing | milestone | 0d | 2003-06-30 A | 2003-06-30 A | 12 | 100% |  | 2003-06-30 | 2003-06-30 | 0d |  |  |  | STEREO | IMPACT | SEP Package | CIT | HET | HET |  |  |  |  |
| 14 | 1.1.7.3 | **SIT** |  | 21d | 2003-05-30 A | 2003-06-30 A |  | 100% |  | 2003-05-30 | 2003-06-30 | 21d |  |  |  | STEREO | IMPACT | SEP Package |  |  |  |  |  |  |  |
| 15 | 1.1.3.12 | Delivery SIT S/W to CIT for SEP Central I/F Testing | milestone | 0d | 2003-07-23 A | 2003-07-23 A |  | 100% |  | 2003-07-23 | 2003-07-23 | 0d |  |  |  | STEREO | IMPACT | SEP Package |  |  |  |  |  |  |  |
| 16 | 1.1.7.3.2 | (OBSOLETE) Receive SIT S/W for SEP Central I/F Testing |  | 21d | 2003-05-30 A | 2003-06-30 A | 15 | 100% |  | 2003-05-30 | 2003-06-30 | 21d |  |  |  | STEREO | IMPACT | SEP Package | CIT | HET | SIT |  |  |  |  |
| 17 | 1.1.7.4 | **LVPS** |  | 116d | 2003-09-19 | 2004-03-09 |  |  |  | 2003-09-15 | 2004-03-08 | 118d | 0d |  |  | STEREO | IMPACT | SEP Package |  |  |  |  |  |  |  |
| 18 | 1.1.3.3.3 | Deliver SEP ETU LVPS to CIT | milestone | 0d | 2003-09-19 A | 2003-09-19 A |  | 100% |  | 2003-09-15 | 2003-09-15 | 0d |  |  | start no earlier than 2003-09-19 | STEREO | IMPACT | SEP Package |  |  |  |  |  |  |  |
| 19 | 1.1.7.4.2 | Receive SEP LVPS ETU From UC-B | milestone | 0d | 2003-09-19 | 2003-09-19 | 18 |  |  | 2003-09-15 | 2003-09-15 | 0d | 0d |  |  | STEREO | IMPACT | SEP Package | CIT | SEP Cen | SEP DPU |  | ETU LVPS Received | LVPS | SEP ETU LVPS |
| 20 | 1.1.3.4.4 | Deliver SEP FM 1 LVPS to CIT | milestone | 0d | 2004-01-09 | 2004-01-09 |  |  |  | 2004-01-08 | 2004-01-08 | 0d | 0d |  |  | STEREO | IMPACT | SEP Package |  |  |  |  |  |  |  |
| 21 | 1.1.7.4.4 | Receive SEP LVPS FM 1 From UC-B | milestone | 0d | 2004-01-09 | 2004-01-09 | 20 |  |  | 2004-01-08 | 2004-01-08 | 0d | 0d |  |  | STEREO | IMPACT | SEP Package | CIT | SEP Cen | SEP DPU |  | FM 1 LVPS Received | LVPS | SEP FM 1 LVPS |
| 22 | 1.1.3.5.4 | Deliver SEP FM 2 LVPS to CIT | milestone | 0d | 2004-03-09 | 2004-03-09 |  |  |  | 2004-03-08 | 2004-03-08 | 0d | 0d |  |  | STEREO | IMPACT | SEP Package |  |  |  |  |  |  |  |
| 23 | 1.1.7.4.6 | Receive SEP LVPS FM 2 From UC-B | milestone | 0d | 2004-03-09 | 2004-03-09 | 22 |  |  | 2004-03-08 | 2004-03-08 | 0d | 14d | 0d |  | STEREO | IMPACT | SEP Package | CIT | SEP Cen | SEP DPU |  | FM 2 LVPS Received | LVPS | SEP FM 2 LVPS |
| 24 | 1.1.7.5 | **LET** |  | 65d | 2003-07-31 A | 2003-11-03 |  |  | 65d | 2003-07-31 | 2003-11-03 | 65d | 78d |  |  | STEREO | IMPACT | SEP Package |  |  |  |  |  |  |  |
| 25 | 1.2.4.9 | Deliver LET S/W Build 2 | milestone | 0d | 2003-07-31 A | 2003-07-31 A |  | 100% |  | 2003-07-31 | 2003-07-31 | 0d |  |  |  | STEREO | IMPACT | SEP Package |  |  |  |  |  |  |  |
| 26 | 1.1.7.5.2 | Receive LET S/W Build 2 | milestone | 0d | 2003-07-31 A | 2003-07-31 A | 25 | 100% |  | 2003-07-31 | 2003-07-31 | 0d |  |  |  | STEREO | IMPACT | SEP Package | CIT | LET | LET |  |  |  |  |
| 27 | 1.2.4.12 | Deliver LET S/W Build 3 | milestone | 0d | 2003-11-03 | 2003-11-03 |  |  |  | 2003-11-03 | 2003-11-03 | 0d | 78d | 0d |  | STEREO | IMPACT | SEP Package |  |  |  |  |  |  |  |
| 28 | 1.1.7.5.4 | Receive LET S/W Build 3 | milestone | 0d | 2003-11-03 | 2003-11-03 | 27 |  |  | 2003-11-03 | 2003-11-03 | 0d | 78d | 17d |  | STEREO | IMPACT | SEP Package | CIT | LET | LET |  |  |  |  |

Notes:
- 13: March 03 Status Upd: CIT to produce 2nd SepCen EM Logic Board for GSFC/UMD.
- 16: March 03 Status Upd: CIT to produce 2nd SepCen EM Logic Board for GSFC/UMD.

| ID | WBS | Task | Type | Duration | Start | Finish | Predecessors | Complete | Remaining | Baseline start | Baseline finish | Baseline duration | Total slack | Free slack | Constraint | Text11 | Text12 | Text13 | Text14 | Text16 | Text28 | Text19 | Text17 | Text20 |
| --- | --- | --- | --- | --- | --- | --- | --- | --- | --- | --- | --- | --- | --- | --- | --- | --- | --- | --- | --- | --- | --- | --- | --- | --- |
| 29 | 1.1.7.6 | **IDPU** |  | 244d | 2003-05-08 A | 2004-04-27 |  |  | 244d | 2003-05-08 | 2004-04-27 | 244d | 49d |  |  | STEREO | IMPACT | SEP Package |  |  |  |  |  |  |
| 30 | 1.1.7.6.1 | Receive ETU IDPU From UC-B For SEP ETU/IDPU ETU I/F Test | milestone | 0d | 2003-05-08 A | 2003-05-08 A |  | 100% |  | 2003-05-08 | 2003-05-08 | 0d |  |  | start no earlier than 2003-03-31 | STEREO | IMPACT | SEP Package | IDPU | IDPU | CIT |  |  |  |
| 31 | 1.1.5.31 | Deliver IDPU FM 2 For SEP Package/IDPU I & T | milestone | 0d | 2004-04-27 | 2004-04-27 |  |  |  | 2004-04-27 | 2004-04-27 | 0d | 49d | 0d |  | STEREO | IMPACT | SEP Package |  |  |  |  |  |  |
| 32 | 1.1.7.6.3 | Receive IDPU FM 2 From UC-B For SEP FM 1/IDPU FM 1 Testing | milestone | 0d | 2004-04-27 | 2004-04-27 | 31 |  |  | 2004-04-27 | 2004-04-27 | 0d | 49d |  |  | STEREO | IMPACT | SEP Package | IDPU | IDPU | CIT |  |  |  |
| 33 | 1.1.8 | **Deliverables** |  | 553d | 2002-01-15 A | 2004-03-26 |  | 99% | 0d | 2002-01-15 | 2004-03-25 | 552d | 71d |  |  | STEREO | IMPACT | SEP Package |  |  | CIT |  |  |  |
| 34 | 1.1.8.1 | Deliver SEP FM 1 Common Electronics Enclosure to CIT | milestone | 0d | 2003-10-30 | 2003-10-30 | 102 |  |  | 2003-10-30 | 2003-10-30 | 0d | 62.5d | 0d |  | STEREO | IMPACT | SEP Package | SEP Cen | SEP DPU | GSFC | Sandy Shuman |  |  |
| 35 | 1.2.7.5.2.10 | Receive SEP FM 1 Common Electronics Enclosure from GSFC | milestone | 0d | 2003-10-30 | 2003-10-30 | 34 |  |  | 2003-10-30 | 2003-10-30 | 0d | 62.5d |  |  | STEREO | IMPACT | SEP Package |  |  |  |  |  |  |
| 36 | 1.1.8.3 | Deliver SEP FM 2 Common Electronics Enclosure to CIT | milestone | 0d | 2003-10-30 | 2003-10-30 | 104 |  |  | 2003-10-30 | 2003-10-30 | 0d | 62.5d | 0d |  | STEREO | IMPACT | SEP Package | SEP Cen | SEP DPU | GSFC | Sandy Shuman |  |  |
| 37 | 1.2.7.5.3.10 | Receive SEP FM 2 Common Electronics Enclosure from GSFC | milestone | 0d | 2003-10-30 | 2003-10-30 | 36 |  |  | 2003-10-30 | 2003-10-30 | 0d | 62.5d | 30.5d |  | STEREO | IMPACT | SEP Package |  |  |  |  |  |  |
| 38 | 1.1.8.5 | Deliver SEP LVPS SPEC to UC-B | milestone | 0d | 2002-07-05 A | 2002-07-05 A | 86 | 100% |  | 2002-07-05 | 2002-07-05 | 0d |  |  | start no earlier than 2002-06-30 | STEREO | IMPACT | SEP Package | PS |  | CIT |  | LVPS |  |
| 39 | 1.1.8.6 | Deliver SEP ETU LVPS Test Feedback to UC-B | milestone | 0d | 2003-09-26 | 2003-09-26 | 240 |  |  | 2003-09-23 | 2003-09-23 | 0d | 0d |  |  | STEREO | IMPACT | SEP Package | PS |  | CIT |  | LVPS |  |
| 40 | 1.1.2.6 | Receive SEP LVPS ETU/SEP Central ETU I/F Test Results | milestone | 0d | 2003-09-26 | 2003-09-26 | 39 |  |  | 2003-09-23 | 2003-09-23 | 0d | 0d |  |  | STEREO | IMPACT | SEP Package |  |  |  |  |  |  |
| 41 | 1.1.8.8 | Deliver Software Requirements Doc To LET |  | 1d | 2002-01-15 A | 2002-01-15 A | 81 | 100% |  | 2002-01-15 | 2002-01-15 | 1d |  |  |  | STEREO | IMPACT | SEP Package | LET | LET | CIT |  |  |  |
| 42 | 1.2.3.5 | Receive Software Requirements Doc |  | 1d | 2002-01-15 A | 2002-01-15 A | 41 | 100% |  | 2002-01-15 | 2002-01-15 | 1d |  |  |  | STEREO | IMPACT | SEP Package |  |  |  |  |  |  |
| 43 | 1.1.8.10 | Deliver SEP Central EM Logic Board (intial) for SEP EM/IDPU ETU I & T | milestone | 0d | 2003-05-31 A | 2003-05-31 A | 179 | 100% |  | 2003-05-31 | 2003-05-31 | 0d |  |  | start no earlier than 2003-05-31 | STEREO | IMPACT | SEP Package | SEP Cen |  |  |  |  | SEP Cen EM (Use latest date) |
| 44 | 1.1.8.11 | Deliver SEP Central EM Logic Board (final) for SEP EM I & T | milestone | 0d | 2003-06-05 A | 2003-06-05 A | 180 | 100% |  | 2003-06-05 | 2003-06-05 | 0d |  |  | start no earlier than 2003-05-31 | STEREO | IMPACT | SEP Package |  |  |  |  |  |  |
| 45 | 1.2.7.5.1.4 | Receive SEP Central EM Logic Board for SEP EM I & T |  | 1d | 2003-06-05 A | 2003-06-06 A | 44 | 100% |  | 2003-06-05 | 2003-06-06 | 1d |  |  | start no earlier than 2003-05-31 | STEREO | IMPACT | SEP Package |  |  |  |  |  |  |
| 46 | 1.2.7.5.1.2 | Receive SEP Central EM Logic Board for SEP EM /IDPU I & T |  | 1d | 2003-05-08 A | 2003-05-08 A | 43 | 100% |  | 2003-05-08 | 2003-05-08 | 1d |  |  |  | STEREO | IMPACT | SEP Package |  |  |  |  |  |  |
| 47 | 1.1.8.14 | Deliver SEP Central FM 1 Logic Board to SEP FM 1 I & T | milestone | 0d | 2003-11-07 | 2003-11-07 | 189 |  |  | 2003-11-07 | 2003-11-07 | 0d | 56d | 0d |  | STEREO | IMPACT | SEP Package | SEP Cen |  |  |  |  | SEP Cen FM 1 (Use latest date) |
| 48 | 1.2.7.5.2.2 | Receive SEP Central FM 1 Logic Board for SEP FM 1 I & T | milestone | 0d | 2003-11-07 | 2003-11-07 | 47 |  |  | 2003-11-07 | 2003-11-07 | 0d | 56d |  |  | STEREO | IMPACT | SEP Package |  |  |  |  |  |  |
| 49 | 1.1.8.16 | Deliver SEP Central FM 2 Logic Board to SEP FM 2 I & T | milestone | 0d | 2003-11-07 | 2003-11-07 | 189 |  |  | 2003-11-07 | 2003-11-07 | 0d | 56d | 0d |  | STEREO | IMPACT | SEP Package | SEP Cen |  |  |  |  | SEP Cen FM 2 (Use latest date) |
| 50 | 1.2.7.5.3.2 | Receive SEP Central FM 2 Logic Board for SEP FM 2 I & T | milestone | 0d | 2003-11-07 | 2003-11-07 | 49 |  |  | 2003-11-07 | 2003-11-07 | 0d | 56d | 24d |  | STEREO | IMPACT | SEP Package |  |  |  |  |  |  |
| 51 | 1.1.8.18 | Deliver Bench Tested SEP Cental ETU LVPS for SEP EM I & T | milestone | 0d | 2003-09-19 | 2003-09-19 | 237 |  |  | 2003-09-16 | 2003-09-16 | 0d | 43d | 0d |  | STEREO | IMPACT | SEP Package | SEP Cen |  |  |  |  | SEP Cen EM (Use latest date) |
| 52 | 1.2.7.5.1.10 | Receive SEP Central EM Bench Tested LVPS for SEP EM I & T | milestone | 0d | 2003-09-19 | 2003-09-19 | 51 |  |  | 2003-09-16 | 2003-09-16 | 0d | 43d | 0d |  | STEREO | IMPACT | SEP Package |  |  |  |  |  |  |
| 53 | 1.1.8.20 | Deliver Bench Tested SEP Central FM 1 LVPS to SEP FM 1 I & T | milestone | 0d | 2004-01-30 | 2004-01-30 | 247 |  |  | 2004-01-29 | 2004-01-29 | 0d | 0d |  |  | STEREO | IMPACT | SEP Package | SEP Cen |  |  |  |  | SEP Cen FM 1 (Use latest date) |
| 54 | 1.2.7.5.2.8 | Receive SEP Central FM 1 Bench Tested LVPS for SEP FM 1 I & T | milestone | 0d | 2004-01-30 | 2004-01-30 | 53 |  |  | 2004-01-29 | 2004-01-29 | 0d | 1d |  |  | STEREO | IMPACT | SEP Package |  |  |  |  |  |  |
| 55 | 1.1.8.22 | Deliver Bench Tested SEP Central FM 2 LVPS to SEP FM 2 I & T | milestone | 0d | 2004-03-26 | 2004-03-26 | 257 |  |  | 2004-03-25 | 2004-03-25 | 0d | 14d | 0d |  | STEREO | IMPACT | SEP Package | SEP Cen |  |  |  |  | SEP Cen FM 2 (Use latest date) |
| 56 | 1.2.7.5.3.8 | Receive SEP Central FM 2 Bench Tested LVPS for SEP FM 2 I & T | milestone | 0d | 2004-03-26 | 2004-03-26 | 55 |  |  | 2004-03-25 | 2004-03-25 | 0d | 14d | 6d |  | STEREO | IMPACT | SEP Package |  |  |  |  |  |  |
| 57 | 1.1.8.24 | Deliver Bench Tested SEP Cental EM Analog/Post-Reg Board for SEP EM I & T | milestone | 0d | 2003-05-29 A | 2003-05-29 A | 332 | 100% |  | 2003-05-29 | 2003-05-29 | 0d |  |  |  | STEREO | IMPACT | SEP Package | SEP Cen |  |  |  |  | SEP Cen EM (Use latest date) |
| 58 | 1.2.7.5.1.6 | Receive SEP Central EM Analog/Post-Reg Board for SEP EM I & T | milestone | 0d | 2003-05-29 A | 2003-05-29 A | 57 | 100% |  | 2003-05-29 | 2003-05-29 | 0d |  |  |  | STEREO | IMPACT | SEP Package |  |  |  |  |  |  |
| 59 | 1.1.8.26 | Deliver Bench Tested SEP Cental FM 1 Analog/Post-Reg Board for SEP FM 1 I & T | milestone | 0d | 2003-11-20 | 2003-11-20 | 341 |  |  | 2003-11-20 | 2003-11-20 | 0d | 48d | 1d | finish no earlier than 2003-11-20 | STEREO | IMPACT | SEP Package | SEP Cen |  |  |  |  | SEP Cen FM 1 (Use latest date) |
| 60 | 1.2.7.5.2.4 | Receive SEP Central FM 1Analog/Post-Reg Board for SEP FM 1 I & T | milestone | 0d | 2003-11-21 | 2003-11-21 | 59 |  |  | 2003-11-21 | 2003-11-21 | 0d | 47d |  | finish no earlier than 2003-11-21 | STEREO | IMPACT | SEP Package |  |  |  |  |  |  |
| 61 | 1.1.8.28 | Deliver Bench Tested SEP Cental FM 2 Analog/Post-Reg Board for SEP FM 2 I & T | milestone | 0d | 2003-11-20 | 2003-11-20 | 341 |  |  | 2003-11-20 | 2003-11-20 | 0d | 48d | 1d | finish no earlier than 2003-11-20 | STEREO | IMPACT | SEP Package | SEP Cen |  |  |  |  | SEP Cen FM 2 (Use latest date) |
| 62 | 1.2.7.5.3.4 | Receive SEP Central FM 2Analog/Post-Reg Board for SEP FM 2 I & T | milestone | 0d | 2003-11-21 | 2003-11-21 | 61 |  |  | 2003-11-21 | 2003-11-21 | 0d | 47d | 15d | finish no earlier than 2003-11-21 | STEREO | IMPACT | SEP Package |  |  |  |  |  |  |
| 63 | 1.1.8.30 | Deliver Bench Tested SEP Cental EM SSD Bias Supply for SEP EM I & T | milestone | 0d | 2003-06-25 A | 2003-07-07 A | 423 | 100% |  | 2003-06-25 | 2003-07-07 | 0d |  |  |  | STEREO | IMPACT | SEP Package | SEP Cen |  |  |  |  | SEP Cen EM (Use latest date) |
| 64 | 1.2.7.5.1.8 | Receive SEP Central EM SSD Bias Supply for SEP EM I & T | milestone | 0d | 2003-06-25 A | 2003-07-07 | 63 | 50% | 0d | 2003-06-25 | 2003-07-07 | 0d | 96.65d | 53.65d |  | STEREO | IMPACT | SEP Package |  |  |  |  |  |  |
| 65 | 1.1.8.32 | Deliver Bench Tested SEP Cental FM 1 SSD Bias Supply for SEP FM 1 I & T | milestone | 0d | 2003-12-15 | 2003-12-15 | 432 |  |  | 2003-12-15 | 2003-12-15 | 0d | 32d | 0d | finish no earlier than 2003-11-27 | STEREO | IMPACT | SEP Package | SEP Cen |  |  |  |  | SEP Cen FM 1 (Use latest date) |
| 66 | 1.2.7.5.2.6 | Receive SEP Central FM 1 SSD Bias Supply Board for SEP FM 1 I & T | milestone | 0d | 2003-12-15 | 2003-12-15 | 65 |  |  | 2003-12-15 | 2003-12-15 | 0d | 32d |  | finish no earlier than 2003-11-28 | STEREO | IMPACT | SEP Package |  |  |  |  |  |  |
| 67 | 1.1.8.34 | Deliver Bench Tested SEP Cental FM 2 SSD Bias Supply for SEP FM 2 I & T | milestone | 0d | 2003-12-15 | 2003-12-15 | 432 |  |  | 2003-12-15 | 2003-12-15 | 0d | 32d | 0d | finish no earlier than 2003-11-27 | STEREO | IMPACT | SEP Package | SEP Cen |  |  |  |  | SEP Cen FM 2 (Use latest date) |
| 68 | 1.1.8.35 | Deliver SEP Central Build 1 For SEP I & T | milestone | 0d | 2003-04-08 A | 2003-04-08 A | 458 | 100% |  | 2003-04-08 | 2003-04-08 | 0d |  |  |  | STEREO | IMPACT | SEP Package |  |  |  |  |  |  |
| 69 | 1.2.7.5.1.12 | Receive SEP Central S/W Build 1 for SEP I & T | milestone | 0d | 2003-04-08 A | 2003-04-08 A | 68 | 100% |  | 2003-04-08 | 2003-04-08 | 0d |  |  |  | STEREO | IMPACT | SEP Package |  |  |  |  |  |  |
| 70 | 1.1.8.37 | Deliver SEP Central Build 2 For SEP I & T | milestone | 0d | 2003-07-29 A | 2003-07-29 A | 459 | 100% |  | 2003-07-29 | 2003-07-29 | 0d |  |  |  | STEREO | IMPACT | SEP Package |  |  |  |  |  |  |
| 71 | 1.2.7.5.1.14 | Receive SEP Central S/W Build 2 for SEP I & T | milestone | 0d | 2003-07-29 A | 2003-07-29 A | 70 | 100% |  | 2003-07-29 | 2003-07-29 | 0d |  |  |  | STEREO | IMPACT | SEP Package |  |  |  |  |  |  |
| 72 | 1.1.8.39 | Deliver SEP Central Build 3 For SEP I & T | milestone | 0d | 2003-11-24 | 2003-11-24 | 460 |  |  | 2003-11-24 | 2003-11-24 | 0d | 155d | 0d |  | STEREO | IMPACT | SEP Package |  |  |  |  |  |  |
| 73 | 1.2.7.5.1.16 | Receive SEP Central S/W Build 3 for SEP I & T | milestone | 0d | 2003-11-24 | 2003-11-24 | 72 |  |  | 2003-11-24 | 2003-11-24 | 0d | 292d |  |  | STEREO | IMPACT | SEP Package |  |  |  |  |  |  |
| 74 | 1.2.7.5.3.6 | Receive SEP Central FM 2 SSD Bias Supply Board for SEP FM 2 I & T | milestone | 0d | 2003-12-15 | 2003-12-15 | 67 |  |  | 2003-12-15 | 2003-12-15 | 0d | 32d | 0d | finish no earlier than 2003-11-28 | STEREO | IMPACT | SEP Package |  |  |  |  |  |  |

| ID | WBS | Task | Type | Duration | Start | Finish | Predecessors | Complete | Remaining | Baseline start | Baseline finish | Baseline duration | Total slack | Free slack | Constraint | Text11 | Text12 | Text13 | Text28 | Text14 | Text16 | Text23 | Text17 | Text19 |
| --- | --- | --- | --- | --- | --- | --- | --- | --- | --- | --- | --- | --- | --- | --- | --- | --- | --- | --- | --- | --- | --- | --- | --- | --- |
| 75 | 1.2 | **Documentation** |  | 0d | 2003-04-22 A | 2003-04-22 A |  | 100% |  | 2003-04-22 | 2003-04-22 | 0d |  |  |  | STEREO | IMPACT | SEP Package | CIT |  |  |  |  |  |
| 76 | 1.2.1 | Data Transfer Protocol ICD Finished | milestone | 0d | 2003-04-22 A | 2003-04-22 A | 82 | 100% |  | 2003-04-22 | 2003-04-22 | 0d |  |  | start no earlier than 2003-03-31 | STEREO | IMPACT | SEP Package | CIT | SEP Cen |  |  |  |  |
| 77 | 2 | **Systems Engineering** |  | 608d | 2001-08-15 A | 2004-01-20 |  | 96% | 26.85d | 2001-08-15 | 2004-01-20 | 608d | 118d |  |  | STEREO | IMPACT | SEP Package | CIT |  |  |  |  |  |
| 78 | 2.1 | **Documentation** |  | 608d | 2001-08-15 A | 2004-01-20 |  | 96% | 26.85d | 2001-08-15 | 2004-01-20 | 608d | 118d |  |  | STEREO | IMPACT | SEP Package | CIT |  |  |  |  |  |
| 79 | 2.1.1 | Write preliminary software dev plan |  | 71d | 2001-08-15 A | 2001-11-27 A |  | 100% |  | 2001-08-15 | 2001-11-27 | 71d |  |  | start no earlier than 2001-08-15 | STEREO | IMPACT | SEP Package | CIT | SEP Cen | SEP DPU |  |  |  |
| 80 | 2.1.2 | Write final Software Development Plan |  | 5d | 2002-09-23 A | 2002-09-27 A | 79, 96FS-8d | 100% |  | 2002-09-23 | 2002-09-27 | 5d |  |  |  | STEREO | IMPACT | SEP Package | CIT | SEP Cen | SEP DPU |  |  |  |
| 81 | 2.1.3 | Write software requirements doc |  | 41d | 2001-11-14 A | 2002-01-15 A | 79FS-9d | 100% |  | 2001-11-14 | 2002-01-15 | 41d |  |  |  | STEREO | IMPACT | SEP Package | CIT | SEP Cen | SEP DPU |  |  |  |
| 82 | 2.1.4 | Write data transfer protocol section of SEP ICD |  | 21d | 2002-07-02 A | 2003-04-22 A | 81FS-9d | 100% |  | 2002-07-02 | 2003-04-22 | 21d |  |  | start no earlier than 2002-07-01 | STEREO | IMPACT | SEP Package | CIT | SEP Cen | SEP DPU |  |  |  |
| 83 | 2.1.5 | Software Design Review Preparation |  | 6d | 2002-05-13 A | 2002-05-20 A | 3FS-10d | 100% |  | 2002-05-13 | 2002-05-20 | 6d |  |  | start no earlier than 2002-08-31 | STEREO | IMPACT | SEP Package | CIT | SEP Cen | SEP DPU |  |  |  |
| 84 | 2.1.6 | Update Flight Software User's Manual |  | 5d | 2004-01-14 | 2004-01-20 |  |  |  | 2004-01-14 | 2004-01-20 | 5d | 118d |  | start no earlier than 2004-01-14 | STEREO | IMPACT | SEP Package | CIT | SEP Cen | SEP DPU | B3 Flight Software Available W/User Manual |  |  |
| 85 | 2.1.7 | Collect & verify SEP power requirements |  | 2d | 2001-09-11 A | 2001-09-12 A | 372 | 100% |  | 2001-09-11 | 2001-09-12 | 2d |  |  |  | STEREO | IMPACT | SEP Package | CIT | PS | SEP DPU |  | LVPS |  |
| 86 | 2.1.8 | Prepare SEP LVPS design spec & communicate to UCB |  | 5.5d | 2002-01-02 A | 2002-07-05 A | 85FS+75d | 100% |  | 2002-01-02 | 2002-07-05 | 5.5d |  |  |  | STEREO | IMPACT | SEP Package | CIT | PS | SEP DPU |  | LVPS |  |
| 87 | 2.1.9 | Collect SEP power req update |  | 1d | 2003-09-29 | 2003-09-29 | 241, 96 |  |  | 2003-09-24 | 2003-09-24 | 1d | 26d | 0d |  | STEREO | IMPACT | SEP Package | CIT | PS | SEP DPU |  | LVPS |  |
| 88 | 2.1.10 | Update SEP LVPS design spec & communicate to UC-B |  | 1d | 2003-09-30 | 2003-09-30 | 87 |  |  | 2003-09-25 | 2003-09-25 | 1d | 26d | 0d |  | STEREO | IMPACT | SEP Package | CIT | PS | SEP DPU |  | LVPS |  |
| 89 | 3 | **Structures** |  | 358.5d | 2002-05-29 A | 2003-10-30 |  | 36% | 230.46d | 2002-05-29 | 2003-10-30 | 358.5d | 62.5d |  |  | STEREO | IMPACT | SEP Package | GSFC |  |  |  |  |  |
| 90 | 3.1 | **Design, Fabrication, Assembly and Test** |  | 358.5d | 2002-05-29 A | 2003-10-30 |  | 36% | 230.46d | 2002-05-29 | 2003-10-30 | 358.5d | 62.5d |  |  | STEREO | IMPACT | SEP Package | GSFC |  |  |  |  |  |
| 91 | 3.1.1 | **Design** |  | 338.5d | 2002-05-29 A | 2003-10-01 |  | 50% | 169.25d | 2002-05-29 | 2003-10-01 | 338.5d | 62.5d |  |  | STEREO | IMPACT | SEP Package | GSFC |  |  |  |  |  |
| 92 | 3.1.1.1 | Design SEP Common Electronics Enclosure |  | 100d | 2002-05-29 A | 2003-10-01 |  | 50% | 50d | 2002-05-29 | 2003-10-01 | 100d | 62.5d | 0d | finish no earlier than 2003-05-01 | STEREO | IMPACT | SEP Package | GSFC | SEP Cen | SEP DPU |  |  | Sandy Shuman |
| 93 | 3.1.2 | **Fabrication** |  | 15d | 2003-10-01 | 2003-10-23 |  |  |  | 2003-10-01 | 2003-10-23 | 15d | 62.5d |  |  | STEREO | IMPACT | SEP Package | GSFC |  | SEP DPU |  |  |  |
| 94 | 3.1.2.1 | **FM 1 & FM 2** |  | 15d | 2003-10-01 | 2003-10-23 |  |  |  | 2003-10-01 | 2003-10-23 | 15d | 62.5d |  |  | STEREO | IMPACT | SEP Package | GSFC |  | SEP DPU |  |  |  |
| 95 | 3.1.2.1.1 | **FM 1** |  | 15d | 2003-10-01 | 2003-10-23 |  |  |  | 2003-10-01 | 2003-10-23 | 15d | 62.5d |  |  | STEREO | IMPACT | SEP Package | GSFC |  | SEP DPU |  |  |  |
| 96 | 1.1.13 | Instrument CDR | milestone | 3d | 2002-11-20 A | 2002-11-22 A |  | 100% |  | 2002-11-20 | 2002-11-22 | 3d |  |  | finish no earlier than 2002-11-22 | STEREO | IMPACT | SEP Package |  |  |  |  |  |  |
| 97 | 3.1.2.1.1.2 | Fabricate SEP FM 1 Common Electronics Enclosure |  | 15d | 2003-10-01 | 2003-10-23 | 92, 96 |  |  | 2003-10-01 | 2003-10-23 | 15d | 62.5d | 0d |  | STEREO | IMPACT | SEP Package | GSFC | SEP Cen | SEP DPU | FM 1 SEP Central Common Enclosure Fabricated |  | Sandy Shuman |
| 98 | 3.1.2.1.2 | **FM 2** |  | 15d | 2003-10-01 | 2003-10-23 |  |  |  | 2003-10-01 | 2003-10-23 | 15d | 62.5d |  |  | STEREO | IMPACT | SEP Package | GSFC |  | SEP DPU |  |  |  |
| 99 | 3.1.2.1.2.1 | Fabricate SEP FM 2 Common Electronics Enclosure |  | 15d | 2003-10-01 | 2003-10-23 | 92, 96 |  |  | 2003-10-01 | 2003-10-23 | 15d | 62.5d | 0d |  | STEREO | IMPACT | SEP Package | GSFC | SEP Cen | SEP DPU | FM 2 SEP Central Common Enclosure Fabricated |  | Sandy Shuman |

Notes:
- 92: Removed as dependency on CDR for 10/31 reporting
- 97: Added SNL date due to TYCHO CDR Schedule slip, need to adjust later
- 99: Added SNL date due to TYCHO CDR Schedule slip, need to adjust later

| ID | WBS | Task | Type | Duration | Start | Finish | Predecessors | Complete | Remaining | Baseline start | Baseline finish | Baseline duration | Total slack | Free slack | Constraint | Text11 | Text12 | Text13 | Text16 | Text28 | Text14 | Text19 | Text23 | Text15 | Text20 | Text21 |
| --- | --- | --- | --- | --- | --- | --- | --- | --- | --- | --- | --- | --- | --- | --- | --- | --- | --- | --- | --- | --- | --- | --- | --- | --- | --- | --- |
| 100 | 3.1.3 | **Assembly** |  | 5d | 2003-10-23 | 2003-10-30 |  |  |  | 2003-10-23 | 2003-10-30 | 5d | 62.5d |  |  | STEREO | IMPACT | SEP Package | SEP DPU | GSFC |  |  |  |  |  |  |
| 101 | 3.1.3.1 | **FM 1** |  | 5d | 2003-10-23 | 2003-10-30 |  |  |  | 2003-10-23 | 2003-10-30 | 5d | 62.5d |  |  | STEREO | IMPACT | SEP Package | SEP DPU | GSFC |  |  |  |  |  |  |
| 102 | 3.1.3.1.1 | Assemble SEP FM 1 Common Electronics Enclosure |  | 5d | 2003-10-23 | 2003-10-30 | 97 |  |  | 2003-10-23 | 2003-10-30 | 5d | 62.5d | 0d |  | STEREO | IMPACT | SEP Package | SEP DPU | GSFC | SEP Cen | Sandy Shuman | FM 1 SEP Central Common Electronics Enclosesure Assembled |  |  |  |
| 103 | 3.1.3.2 | **FM 2** |  | 5d | 2003-10-23 | 2003-10-30 |  |  |  | 2003-10-23 | 2003-10-30 | 5d | 62.5d |  |  | STEREO | IMPACT | SEP Package | SEP DPU | GSFC |  |  |  |  |  |  |
| 104 | 3.1.3.2.1 | Assemble SEP FM 2 Common Electronics Enclosure |  | 5d | 2003-10-23 | 2003-10-30 | 99 |  |  | 2003-10-23 | 2003-10-30 | 5d | 62.5d | 0d |  | STEREO | IMPACT | SEP Package | SEP DPU | GSFC | SEP Cen | Sandy Shuman | FM 2 SEP Central Common Electronics Encloure Assembled |  |  |  |
| 105 | 4 | **SEP Central Logic Board** |  | 391d | 2002-05-01 A | 2003-11-19 |  | 80% | 78.4d | 2002-05-01 | 2003-11-19 | 391d | 158d |  |  | STEREO | IMPACT | SEP Package | SEP DPU | CIT |  |  |  | Logic Bd |  |  |
| 106 | 4.1 | **Design, Fabrication, Assembly and Test** |  | 391d | 2002-05-01 A | 2003-11-19 |  | 80% | 78.4d | 2002-05-01 | 2003-11-19 | 391d | 158d |  |  | STEREO | IMPACT | SEP Package | SEP DPU | CIT |  |  |  | Logic Bd |  |  |
| 107 | 4.1.1 | **Procurements** |  | 338d | 2002-05-01 A | 2003-09-03 |  | 99% | 5.04d | 2002-05-01 | 2003-09-03 | 338d | 56d |  |  | STEREO | IMPACT | SEP Package | SEP DPU | CIT |  |  |  | Logic Bd |  |  |
| 108 | 4.1.1.1 | **ETU** |  | 251.5d | 2002-05-01 A | 2003-05-01 A |  | 100% |  | 2002-05-01 | 2003-05-01 | 251.5d |  |  |  | STEREO | IMPACT | SEP Package | SEP DPU | CIT |  |  |  | Logic Bd |  |  |
| 109 | 4.1.1.1.1 | Procure SEP Central Logic Actel 54SX72A FPGA - EM | milestone | 0d | 2002-05-01 A | 2003-04-30 A |  | 100% |  | 2002-05-01 | 2003-04-30 | 0d |  |  | finish no earlier than 2002-08-01 | STEREO | IMPACT | SEP Package | SEP DPU | CIT | SEP Cen |  |  |  |  |  |
| 110 | 4.1.1.1.2 | Procure SEP Central Logic SRAM 128K x 8, 3.3V - EM |  | 29d | 2002-07-01 A | 2003-01-14 A |  | 100% |  | 2002-07-01 | 2003-01-14 | 29d |  |  | finish no earlier than 2002-08-01 | STEREO | IMPACT | SEP Package | SEP DPU | CIT | SEP Cen |  |  |  |  |  |
| 111 | 4.1.1.1.3 | Procure SEP Central Logic EEPROM 128K x 8, 3.3V - EM |  | 1d | 2002-05-01 A | 2002-08-01 A |  | 100% |  | 2002-05-01 | 2002-08-01 | 1d |  |  | finish no earlier than 2002-08-01 | STEREO | IMPACT | SEP Package | SEP DPU | CIT | SEP Cen |  |  |  |  |  |
| 112 | 4.1.1.1.4 | Procure SEP Central Logic Board EM Parts |  | 10d | 2003-01-22 A | 2003-05-01 A | 128, 129 | 100% |  | 2003-01-22 | 2003-05-01 | 10d |  |  | start no earlier than 2003-01-22 | STEREO | IMPACT | SEP Package | SEP DPU | CIT | SEP Cen |  |  |  |  |  |
| 113 | 4.1.1.1.5 | Procure SEP Central Logic EM Printed Circuit Board |  | 1d | 2003-02-18 A | 2003-02-18 A | 132 | 100% |  | 2003-02-18 | 2003-02-18 | 1d |  |  | start no earlier than 2003-02-03 | STEREO | IMPACT | SEP Package | SEP DPU | CIT | SEP Cen |  |  | Logic Bd |  |  |
| 114 | 4.1.1.2 | **FM 1 & FM 2** |  | 296d | 2002-07-01 A | 2003-09-03 |  | 98% | 6.37d | 2002-07-01 | 2003-09-03 | 296d | 56d |  |  | STEREO | IMPACT | SEP Package | SEP DPU | CIT |  |  |  | Logic Bd |  |  |
| 115 | 4.1.1.2.1 | Procure SEP Central Logic Actel RTSX72S FPGA - flight |  | 22d | 2002-07-01 A | 2002-07-31 A |  | 100% |  | 2002-07-01 | 2002-07-31 | 22d |  |  | start no earlier than 2002-07-01 | STEREO | IMPACT | SEP Package | SEP DPU | CIT | SEP Cen |  |  |  |  |  |
| 116 | 4.1.1.2.2 | Procure SEP Central Logic EEPROM 128K x 8, 3.3V - flight |  | 1d | 2002-07-01 A | 2002-08-01 A |  | 100% |  | 2002-07-01 | 2002-08-01 | 1d |  |  | finish no earlier than 2002-08-01 | STEREO | IMPACT | SEP Package | SEP DPU | CIT | SEP Cen |  |  |  |  |  |
| 117 | 4.1.1.2.3 | Procure SEP Central Logic SRAM 128K x 8, 3.3V - flight |  | 29d | 2002-07-01 A | 2003-01-14 A |  | 100% |  | 2002-07-01 | 2003-01-14 | 29d |  |  | finish no earlier than 2002-08-01 | STEREO | IMPACT | SEP Package | SEP DPU | CIT | SEP Cen |  |  |  |  |  |
| 118 | 4.1.1.2.4 | Procure SEP Central Logic Clock Oscillator, 16 MHz |  | 1d | 2002-07-02 A | 2003-05-01 A |  | 100% |  | 2002-07-02 | 2003-05-01 | 1d |  |  | start no earlier than 2002-07-01 | STEREO | IMPACT | SEP Package | SEP DPU | CIT | SEP Cen |  |  |  |  |  |
| 119 | 4.1.1.2.5 | Procure SEP Central Logic Board Flight Parts |  | 38d | 2003-05-07 A | 2003-08-01 A | 179, 135 | 100% |  | 2003-05-07 | 2003-08-01 | 38d |  |  |  | STEREO | IMPACT | SEP Package | SEP DPU | CIT | SEP Cen |  |  |  |  |  |
| 120 | 4.1.1.2.6 | Procure SEP Central Logic Flight Printed Circuit Boards |  | 2d | 2003-09-02 | 2003-09-03 | 140 |  |  | 2003-09-02 | 2003-09-03 | 2d | 56d | 0d | start no earlier than 2003-09-02 | STEREO | IMPACT | SEP Package | SEP DPU | CIT | SEP Cen |  |  | Logic Bd |  |  |
| 121 | 4.1.2 | **Design** |  | 342d | 2002-07-02 A | 2003-11-11 |  | 98% | 6.12d | 2002-07-02 | 2003-11-11 | 342d | 163d |  |  | STEREO | IMPACT | SEP Package | SEP DPU | CIT |  |  |  | Logic Bd |  |  |
| 122 | 4.1.2.1 | **ETU** |  | 229.5d | 2002-07-02 A | 2003-06-02 A |  | 100% |  | 2002-07-02 | 2003-06-02 | 229.5d |  |  |  | STEREO | IMPACT | SEP Package | SEP DPU | CIT |  |  |  | Logic Bd |  |  |
| 123 | 4.1.2.1.1 | SEP Central Logic Design Complete |  | 1d | 2003-05-06 A | 2003-05-06 A | 133FF-1d | 100% |  | 2003-05-06 | 2003-05-06 | 1d |  |  |  | STEREO | IMPACT | SEP Package |  | CIT | SEP Cen |  |  |  | SEP Central Logic EM Design | SEP Cntrl. Logic EM Dsgn |
| 124 | 5.1.2.1.1 | Design and sketch LET MISC Printed Circuit Board schematics for EM |  | 40d | 2002-07-02 A | 2002-11-06 A |  | 100% |  | 2002-07-02 | 2002-11-06 | 40d |  |  | start no earlier than 2002-07-01 | STEREO | IMPACT | SEP Package |  |  |  |  |  |  |  |  |
| 125 | 4.1.2.1.3 | Design and sketch Printed Circuit Board schematics for SEP Central Logic EM |  | 56.7d | 2002-07-02 A | 2002-11-12 A | 124SS | 100% |  | 2002-07-02 | 2002-11-12 | 56.7d |  |  |  | STEREO | IMPACT | SEP Package | SEP DPU | CIT | SEP Cen |  |  | Logic Bd |  |  |
| 126 | 4.1.2.1.4 | Design Printed Circuit Board schematics for SEP Central Logic EM version |  | 5d | 2002-11-13 A | 2002-11-19 A | 125 | 100% |  | 2002-11-13 | 2002-11-19 | 5d |  |  |  | STEREO | IMPACT | SEP Package | SEP DPU | CIT | SEP Cen |  |  | Logic Bd |  |  |
| 127 | 4.1.2.1.5 | Design FPGA schem/EEPROM for SEP Central Logic EM version |  | 29d | 2002-12-02 A | 2003-01-14 A | 126 | 100% |  | 2002-12-02 | 2003-01-14 | 29d |  |  | start no earlier than 2002-11-30 | STEREO | IMPACT | SEP Package | SEP DPU | CIT | SEP Cen |  |  | Logic Bd |  |  |
| 128 | 4.1.2.1.6 | FMA/design review/risk assessment |  | 5d | 2003-01-15 A | 2003-01-21 A | 127 | 100% |  | 2003-01-15 | 2003-01-21 | 5d |  |  |  | STEREO | IMPACT | SEP Package | SEP DPU | CIT | SEP Cen |  |  | Logic Bd |  |  |
| 129 | 4.1.2.1.7 | Assess SEP Central Logic EM and Flight Parts |  | 19d | 2002-11-13 A | 2002-12-10 A | 125 | 100% |  | 2002-11-13 | 2002-12-10 | 19d |  |  |  | STEREO | IMPACT | SEP Package | SEP DPU | CIT | SEP Cen |  |  |  |  |  |
| 130 | 4.1.2.1.8 | Obtain samples & footprints, provide to Printed Circuit Board designer |  | 6d | 2002-12-11 A | 2002-12-18 A | 129 | 100% |  | 2002-12-11 | 2002-12-18 | 6d |  |  |  | STEREO | IMPACT | SEP Package | SEP DPU | CIT | SEP Cen |  |  | Logic Bd |  |  |
| 131 | 4.1.2.1.9 | Design SEP Central Logic EM Printed Circuit Board layout |  | 28d | 2002-12-19 A | 2003-02-14 A | 130 | 100% |  | 2002-12-19 | 2003-02-14 | 28d |  |  |  | STEREO | IMPACT | SEP Package | SEP DPU | CIT | SEP Cen |  |  | Logic Bd |  |  |
| 132 | 4.1.2.1.10 | Review & approve SEP Central Logic EM Printed Circuit Board layout |  | 1d | 2003-02-14 A | 2003-02-14 A | 131FS-1d | 100% |  | 2003-02-14 | 2003-02-14 | 1d |  |  |  | STEREO | IMPACT | SEP Package | SEP DPU | CIT | SEP Cen |  |  | Logic Bd |  |  |
| 133 | 4.1.2.1.11 | Doc SEP Central Logic EM board rework (traveler, ECR) |  | 1d | 2003-05-09 A | 2003-06-02 A | 166FF-1d | 100% |  | 2003-05-09 | 2003-06-02 | 1d |  |  |  | STEREO | IMPACT | SEP Package | SEP DPU | CIT | SEP Cen |  |  | Logic Bd |  |  |

Notes:
- 112: May 2003 Status Update Analysis - How could the IDPU/SEP Central I/F test occur if Cal Tech had not completed the procurement of all the EM parts? Assumed these activities were missed during the April or May status update, took 100% credit. The note field identified this action so that no misunderstanding occurs.
- 115: GSFC Now Procuring talk to Antonio re activities

| ID | WBS | Task | Duration | Start | Finish | Predecessors | Complete | Remaining | Baseline start | Baseline finish | Baseline duration | Total slack | Free slack | Constraint | Text11 | Text12 | Text13 | Text15 | Text16 | Text28 | Text14 | Text23 |
| --- | --- | --- | --- | --- | --- | --- | --- | --- | --- | --- | --- | --- | --- | --- | --- | --- | --- | --- | --- | --- | --- | --- |
| 134 | 4.1.2.2 | **FM 1 & FM 2** | 134d | 2003-05-01 A | 2003-11-11 |  | 94% | 7.44d | 2003-05-01 | 2003-11-11 | 134d | 163d |  |  | STEREO | IMPACT | SEP Package | Logic Bd | SEP DPU | CIT |  |  |
| 135 | 4.1.2.2.1 | FMA/design review/risk assessment | 5d | 2003-05-01 A | 2003-07-03 A |  | 100% |  | 2003-05-01 | 2003-07-03 | 5d |  |  | start no earlier than 2003-05-01 | STEREO | IMPACT | SEP Package |  |  |  |  |  |
| 136 | 4.1.2.2.2 | Revise/update Printed Circuit Board schematics for flight version | 10d | 2003-06-09 A | 2003-07-02 A | 181SS+6d | 100% |  | 2003-06-09 | 2003-07-02 | 10d |  |  |  | STEREO | IMPACT | SEP Package | Logic Bd | SEP DPU | CIT | SEP Cen |  |
| 137 | 4.1.2.2.3 | Revise/update FPGA schem/EEPROM for flight ver | 19d | 2003-06-03 A | 2003-07-03 A | 181 | 100% |  | 2003-06-03 | 2003-07-03 | 19d |  |  |  | STEREO | IMPACT | SEP Package | Logic Bd | SEP DPU | CIT | SEP Cen |  |
| 138 | 4.1.2.2.4 | Obtain samples & footprints, provide to Printed Circuit Board designer | 6d | 2003-06-06 A | 2003-06-16 A | 119 | 100% |  | 2003-06-06 | 2003-06-16 | 6d |  |  |  | STEREO | IMPACT | SEP Package | Logic Bd | SEP DPU | CIT | SEP Cen |  |
| 139 | 4.1.2.2.5 | Revise/update Printed Circuit Board layout for flight version | 26d | 2003-06-27 A | 2003-08-07 A | 138, 137FS-1d, 136 | 100% |  | 2003-06-27 | 2003-08-07 | 26d |  |  |  | STEREO | IMPACT | SEP Package | Logic Bd | SEP DPU | CIT | SEP Cen |  |
| 140 | 4.1.2.2.6 | Review & approve flight Printed Circuit Board layout | 2d | 2003-08-07 A | 2003-08-11 A | 139 | 100% |  | 2003-08-07 | 2003-08-11 | 2d |  |  |  | STEREO | IMPACT | SEP Package | Logic Bd | SEP DPU | CIT | SEP Cen |  |
| 141 | 4.1.2.2.7 | Doc flight board rework (traveler, ECR) for FM 1 | 1d | 2003-10-28 | 2003-10-28 | 171, 129 |  |  | 2003-10-28 | 2003-10-28 | 1d | 62d | 0d |  | STEREO | IMPACT | SEP Package | Logic Bd | SEP DPU | CIT | SEP Cen |  |
| 142 | 4.1.2.2.8 | Final update of Printed Circuit Board schematics & layout for FM 1 | 1d | 2003-10-29 | 2003-10-29 | 141 |  |  | 2003-10-29 | 2003-10-29 | 1d | 62d | 6d |  | STEREO | IMPACT | SEP Package | Logic Bd | SEP DPU | CIT | SEP Cen |  |
| 143 | 4.1.2.2.9 | Doc flight board rework (traveler, ECR) for FM 2 | 1d | 2003-11-07 | 2003-11-07 | 176 |  |  | 2003-11-07 | 2003-11-07 | 1d | 163d | 0d |  | STEREO | IMPACT | SEP Package | Logic Bd | SEP DPU | CIT | SEP Cen |  |
| 144 | 4.1.2.2.10 | Final update of Printed Circuit Board schematics & layout for FM 2 | 1d | 2003-11-11 | 2003-11-11 | 143 |  |  | 2003-11-11 | 2003-11-11 | 1d | 163d | 5d |  | STEREO | IMPACT | SEP Package | Logic Bd | SEP DPU | CIT | SEP Cen |  |
| 145 | 4.1.3 | **Fabrication** | 139d | 2003-03-19 A | 2003-10-02 |  | 40% | 83.98d | 2003-03-19 | 2003-10-02 | 139d | 60d |  |  | STEREO | IMPACT | SEP Package | Logic Bd | SEP DPU | CIT |  |  |
| 146 | 4.1.3.1 | **ETU** | 31d | 2003-03-19 A | 2003-04-30 A |  | 100% |  | 2003-03-19 | 2003-04-30 | 31d |  |  |  | STEREO | IMPACT | SEP Package | Logic Bd | SEP DPU | CIT |  |  |
| 147 | 4.1.3.1.1 | Receive/inspect/database SEP Central Logic EM parts | 4d | 2003-04-22 A | 2003-04-25 A | 109FS+4d, 110FS+39d, 111FS+39d, 112FS+10d | 100% |  | 2003-04-22 | 2003-04-25 | 4d |  |  | start no earlier than 2003-03-31 | STEREO | IMPACT | SEP Package | Logic Bd | SEP DPU | CIT | SEP Cen |  |
| 148 | 4.1.3.1.2 | Inspect SEP Central Logic EM Printed Circuit Board | 1d | 2003-03-19 A | 2003-03-19 A | 113FS+20d | 100% |  | 2003-03-19 | 2003-03-19 | 1d |  |  |  | STEREO | IMPACT | SEP Package | Logic Bd | SEP DPU | CIT | SEP Cen | EM Logic Board Fabricated |
| 149 | 4.1.3.1.3 | Generate SEP Central Logic EM kit list in database | 2d | 2003-04-28 A | 2003-04-29 A | 147 | 100% |  | 2003-04-28 | 2003-04-29 | 2d |  |  | start no earlier than 2003-03-31 | STEREO | IMPACT | SEP Package | Logic Bd | SEP DPU | CIT | SEP Cen |  |
| 150 | 4.1.3.1.4 | Burn in SEP Central Logic EM FPGA/EEPROM | 1d | 2003-04-28 A | 2003-04-28 A | 147 | 100% |  | 2003-04-28 | 2003-04-28 | 1d |  |  | start no earlier than 2003-03-31 | STEREO | IMPACT | SEP Package | Logic Bd | SEP DPU | CIT | SEP Cen |  |
| 151 | 4.1.3.1.5 | Bend leads on SEP Central Logic EM ICs | 1d | 2003-04-28 A | 2003-04-28 A | 147 | 100% |  | 2003-04-28 | 2003-04-28 | 1d |  |  | start no earlier than 2003-03-31 | STEREO | IMPACT | SEP Package | Logic Bd | SEP DPU | CIT | SEP Cen |  |
| 152 | 4.1.3.1.6 | Generate SEP Central Logic EM kit book | 2d | 2003-04-29 A | 2003-04-30 A | 149FS-1d | 100% |  | 2003-04-29 | 2003-04-30 | 2d |  |  | start no earlier than 2003-03-31 | STEREO | IMPACT | SEP Package | Logic Bd | SEP DPU | CIT | SEP Cen |  |
| 153 | 4.1.3.1.7 | Kit SEP Central Logic EM parts | 2d | 2003-03-21 A | 2003-03-24 A | 152 | 100% |  | 2003-03-21 | 2003-03-24 | 2d |  |  |  | STEREO | IMPACT | SEP Package | Logic Bd | SEP DPU | CIT | SEP Cen |  |
| 154 | 4.1.3.2 | **FM 1 & FM 2** | 43.55d | 2003-08-01 A | 2003-10-02 |  | 17% | 36.08d | 2003-08-01 | 2003-10-02 | 43.55d | 60d |  |  | STEREO | IMPACT | SEP Package | Logic Bd | SEP DPU | CIT |  |  |
| 155 | 4.1.3.2.1 | Receive/inspect/database SEP Central Logic flight parts | 6d | 2003-08-01 A | 2003-08-11 A | 119, 118, 117, 116, 115 | 100% |  | 2003-08-01 | 2003-08-11 | 6d |  |  |  | STEREO | IMPACT | SEP Package | Logic Bd | SEP DPU | CIT | SEP Cen |  |
| 156 | 4.1.3.2.2 | Inspect flight SEP Central Printed Circuit Boards (coupons & elec continuity) | 1d | 2003-09-25 | 2003-09-25 | 120FS+15d |  |  | 2003-09-25 | 2003-09-25 | 1d | 56d | 0d |  | STEREO | IMPACT | SEP Package | Logic Bd | SEP DPU | CIT | SEP Cen | Flight Logic Boards Fabricated |
| 157 | 4.1.3.2.3 | Generate SEP Central flight kit list in database | 1d | 2003-09-26 | 2003-09-26 | 155, 156 |  |  | 2003-09-26 | 2003-09-26 | 1d | 60d | 0d |  | STEREO | IMPACT | SEP Package | Logic Bd | SEP DPU | CIT | SEP Cen |  |
| 158 | 4.1.3.2.4 | Rescreen heritage flight parts for SEP Central Logic Board | 19d | 2003-09-02 | 2003-09-26 | 129 |  |  | 2003-09-02 | 2003-09-26 | 19d | 61d | 1d | start no earlier than 2003-09-02 | STEREO | IMPACT | SEP Package | Logic Bd | SEP DPU | CIT | SEP Cen |  |
| 159 | 4.1.3.2.5 | Burn-in flight FPGA/EEPROM for SEP Central Logic Board | 2d | 2003-09-25 | 2003-09-26 | 137 |  |  | 2003-09-25 | 2003-09-26 | 2d | 64d | 8d | start no earlier than 2003-09-25 | STEREO | IMPACT | SEP Package | Logic Bd | SEP DPU | CIT | SEP Cen |  |
| 160 | 4.1.3.2.6 | Bend leads on SEP Central Logic Board flight Ics | 2d | 2003-09-26 | 2003-09-29 | 140, 156 |  |  | 2003-09-26 | 2003-09-29 | 2d | 63d | 7d |  | STEREO | IMPACT | SEP Package | Logic Bd | SEP DPU | CIT | SEP Cen |  |
| 161 | 4.1.3.2.7 | Generate flight SEP Central Logic Board kit book | 1d | 2003-09-29 | 2003-09-29 | 157 |  |  | 2003-09-29 | 2003-09-29 | 1d | 60d | 0d |  | STEREO | IMPACT | SEP Package | Logic Bd | SEP DPU | CIT | SEP Cen |  |
| 162 | 4.1.3.2.8 | Kit SEP Central Logic Board flight parts | 3d | 2003-09-30 | 2003-10-02 | 158, 161 |  |  | 2003-09-30 | 2003-10-02 | 3d | 60d | 4d |  | STEREO | IMPACT | SEP Package | Logic Bd | SEP DPU | CIT | SEP Cen |  |

Notes:
- 147: How could the IDPU/SEP Central I/F test occur if Cal Tech had not completed the procurement of all the EM parts? Assumed these activities were missed during the April or May status update, took 100% credit. The note field identified this action so that no misunderstanding occurs.

| ID | WBS | Task | Duration | Start | Finish | Predecessors | Complete | Remaining | Baseline start | Baseline finish | Baseline duration | Total slack | Free slack | Constraint | Text11 | Text12 | Text13 | Text15 | Text16 | Text28 | Text14 | Text23 |
| --- | --- | --- | --- | --- | --- | --- | --- | --- | --- | --- | --- | --- | --- | --- | --- | --- | --- | --- | --- | --- | --- | --- |
| 163 | 4.1.4 | **Assembly** | 159d | 2003-03-25 A | 2003-11-06 |  | 55% | 71.81d | 2003-03-25 | 2003-11-06 | 159d | 158d |  |  | STEREO | IMPACT | SEP Package | Logic Bd | SEP DPU | CIT |  |  |
| 164 | 4.1.4.1 | **ETU** | 69.2d | 2003-03-25 A | 2003-07-01 A |  | 100% |  | 2003-03-25 | 2003-07-01 | 69.2d |  |  |  | STEREO | IMPACT | SEP Package | Logic Bd | SEP DPU | CIT |  |  |
| 165 | 4.1.4.1.1 | Assemble SEP Central Logic EM board and Preliminary Checkout | 15d | 2003-03-25 A | 2003-05-13 A | 148, 150, 151, 153 | 100% |  | 2003-03-25 | 2003-05-13 | 15d |  |  |  | STEREO | IMPACT | SEP Package | Logic Bd | SEP DPU | CIT | SEP Cen | EM Logic Board Assembled |
| 166 | 4.1.4.1.2 | Rework/Haywire/Trim SEP Central Logic EM Board | 2d | 2003-05-09 A | 2003-07-01 A | 179 | 100% |  | 2003-05-09 | 2003-07-01 | 2d |  |  |  | STEREO | IMPACT | SEP Package | Logic Bd | SEP DPU | CIT | SEP Cen |  |
| 167 | 4.1.4.2 | **FM 1** | 12d | 2003-10-10 | 2003-10-27 |  |  |  | 2003-10-10 | 2003-10-27 | 12d | 56d |  |  | STEREO | IMPACT | SEP Package | Logic Bd | SEP DPU | CIT |  |  |
| 168 | 4.1.4.2.1 | Assemble FM 1 SEP Central Logic board | 5d | 2003-10-10 | 2003-10-16 | 120, 156FS+9d, 158, 159, 160, 162 |  |  | 2003-10-10 | 2003-10-16 | 5d | 56d | 0d |  | STEREO | IMPACT | SEP Package | Logic Bd | SEP DPU | CIT | SEP Cen | Flight Logic Boards Assembled |
| 169 | 4.1.4.2.2 | Post-assembly QA inspection of FM 1 SEP Central Logic Board | 1d | 2003-10-17 | 2003-10-17 | 168 |  |  | 2003-10-17 | 2003-10-17 | 1d | 56d | 0d |  | STEREO | IMPACT | SEP Package | Logic Bd | SEP DPU | CIT | SEP Cen |  |
| 170 | 4.1.4.2.3 | Rework/haywire/trim FM 1 SEP Central Logic board | 0.5d | 2003-10-27 | 2003-10-27 | 183 |  |  | 2003-10-27 | 2003-10-27 | 0.5d | 56d | 0d |  | STEREO | IMPACT | SEP Package | Logic Bd | SEP DPU | CIT | SEP Cen |  |
| 171 | 4.1.4.2.4 | Post-rework QA inspection of FM 1 SEP Central Logic Board | 0.5d | 2003-10-27 | 2003-10-27 | 170 |  |  | 2003-10-27 | 2003-10-27 | 0.5d | 56d | 0d |  | STEREO | IMPACT | SEP Package | Logic Bd | SEP DPU | CIT | SEP Cen |  |
| 172 | 4.1.4.3 | **FM 2** | 15d | 2003-10-17 | 2003-11-06 |  |  |  | 2003-10-17 | 2003-11-06 | 15d | 152d |  |  | STEREO | IMPACT | SEP Package | Logic Bd | SEP DPU | CIT |  |  |
| 173 | 4.1.4.3.1 | Assemble FM 2 SEP Central Logic board | 5d | 2003-10-17 | 2003-10-23 | 168 |  |  | 2003-10-17 | 2003-10-23 | 5d | 152d | 0d |  | STEREO | IMPACT | SEP Package | Logic Bd | SEP DPU | CIT | SEP Cen | Flight Logic Boards Assembled |
| 174 | 4.1.4.3.2 | Post-assembly QA inspection of FM 2 SEP Central Logic Board | 1d | 2003-10-24 | 2003-10-24 | 173 |  |  | 2003-10-24 | 2003-10-24 | 1d | 158d | 0d |  | STEREO | IMPACT | SEP Package | Logic Bd | SEP DPU | CIT | SEP Cen |  |
| 175 | 4.1.4.3.3 | Rework/haywire/trim FM 2 SEP Central Logic board | 0.5d | 2003-11-06 | 2003-11-06 | 192, 193 |  |  | 2003-11-06 | 2003-11-06 | 0.5d | 158d | 0d |  | STEREO | IMPACT | SEP Package | Logic Bd | SEP DPU | CIT | SEP Cen |  |
| 176 | 4.1.4.3.4 | Post-rework QA inspection of FM 2 SEP Central Logic Boards | 0.5d | 2003-11-06 | 2003-11-06 | 175 |  |  | 2003-11-06 | 2003-11-06 | 0.5d | 158d | 0d |  | STEREO | IMPACT | SEP Package | Logic Bd | SEP DPU | CIT | SEP Cen |  |
| 177 | 4.1.5 | **Test** | 140d | 2003-05-01 A | 2003-11-19 |  | 18% | 115.16d | 2003-05-01 | 2003-11-19 | 140d | 158d |  |  | STEREO | IMPACT | SEP Package | Logic Bd | SEP DPU | CIT |  |  |
| 178 | 4.1.5.1 | **ETU** | 43.7d | 2003-05-01 A | 2003-07-02 A |  | 100% |  | 2003-05-01 | 2003-07-02 | 43.7d |  |  |  | STEREO | IMPACT | SEP Package | Logic Bd | SEP DPU | CIT |  |  |
| 179 | 4.1.5.1.1 | Test SEP Central Logic EM board (Initial) | 6d | 2003-05-01 A | 2003-05-08 A | 165, 467 | 100% |  | 2003-05-01 | 2003-05-08 | 6d |  |  |  | STEREO | IMPACT | SEP Package | Logic Bd | SEP DPU | CIT | SEP Cen | EM Logic Board Tested |
| 180 | 4.1.5.1.2 | Test SEP Central Logic EM board (Final) | 3d | 2003-06-02 A | 2003-07-02 A | 166 | 100% |  | 2003-06-02 | 2003-07-02 | 3d |  |  | start no earlier than 2003-05-31 | STEREO | IMPACT | SEP Package |  |  |  |  |  |
| 181 | 4.1.5.1.3 | Document SEP Central Logic EM Board Test Results | 2d | 2003-05-30 A | 2003-07-01 A | 179FF-1d | 100% |  | 2003-05-30 | 2003-07-01 | 2d |  |  |  | STEREO | IMPACT | SEP Package | Logic Bd | SEP DPU | CIT | SEP Cen |  |
| 182 | 4.1.5.2 | **FM 1** | 15d | 2003-10-20 | 2003-11-07 |  |  |  | 2003-10-20 | 2003-11-07 | 15d | 56d |  |  | STEREO | IMPACT | SEP Package | Logic Bd | SEP DPU | CIT |  |  |
| 183 | 4.1.5.2.1 | Test FM 1 SEP Central Logic board (initial) | 5d | 2003-10-20 | 2003-10-24 | 169, 459 |  |  | 2003-10-20 | 2003-10-24 | 5d | 56d | 0d |  | STEREO | IMPACT | SEP Package | Logic Bd | SEP DPU | CIT | SEP Cen |  |
| 184 | 4.1.5.2.2 | Doc FM 1 SEP Central Logic board test results | 3d | 2003-10-27 | 2003-10-29 | 183 |  |  | 2003-10-27 | 2003-10-29 | 3d | 172d |  |  | STEREO | IMPACT | SEP Package | Logic Bd | SEP DPU | CIT | SEP Cen |  |
| 185 | 4.1.5.2.3 | Stake/conformal coat FM 1 SEP Central Logic board | 1d | 2003-10-28 | 2003-10-28 | 171 |  |  | 2003-10-28 | 2003-10-28 | 1d | 56d | 0d |  | STEREO | IMPACT | SEP Package | Logic Bd | SEP DPU | CIT | SEP Cen |  |
| 186 | 4.1.5.2.4 | Bakeout FM 1 SEP Central Logic board | 1d | 2003-10-29 | 2003-10-29 | 185 |  |  | 2003-10-29 | 2003-10-29 | 1d | 56d | 0d |  | STEREO | IMPACT | SEP Package | Logic Bd | SEP DPU | CIT | SEP Cen |  |
| 187 | 4.1.5.2.5 | Post-conf. coat QA inspection of FM 1 SEP Central Logic Board | 1d | 2003-10-30 | 2003-10-30 | 186 |  |  | 2003-10-30 | 2003-10-30 | 1d | 56d | 0d |  | STEREO | IMPACT | SEP Package | Logic Bd | SEP DPU | CIT | SEP Cen |  |
| 188 | 4.1.5.2.6 | Test FM 1 SEP Central Logic board (final) | 5d | 2003-10-31 | 2003-11-06 | 187 |  |  | 2003-10-31 | 2003-11-06 | 5d | 56d | 0d |  | STEREO | IMPACT | SEP Package | Logic Bd | SEP DPU | CIT | SEP Cen |  |
| 189 | 4.1.5.2.7 | FM 1 SEP Central Logic Board Mass properties/photo | 1d | 2003-11-07 | 2003-11-07 | 188, 142 |  |  | 2003-11-07 | 2003-11-07 | 1d | 56d | 0d |  | STEREO | IMPACT | SEP Package | Logic Bd | SEP DPU | CIT | SEP Cen | Flight Logic Boards Tested |
| 190 | 4.1.5.2.8 | Maintain hard copy FM 1 SEP Central Logic Board docs | 9d | 2003-10-28 | 2003-11-07 | 189FF |  |  | 2003-10-28 | 2003-11-07 | 9d | 165d |  |  | STEREO | IMPACT | SEP Package | Logic Bd | SEP DPU | CIT | SEP Cen |  |

| ID | WBS | Task | Duration | Start | Finish | Predecessors | Complete | Remaining | Baseline start | Baseline finish | Baseline duration | Total slack | Free slack | Text11 | Text12 | Text13 | Text15 | Text16 | Text28 | Text14 | Text23 | Text17 |
| --- | --- | --- | --- | --- | --- | --- | --- | --- | --- | --- | --- | --- | --- | --- | --- | --- | --- | --- | --- | --- | --- | --- |
| 191 | 4.1.5.3 | **FM 2** | 17d | 2003-10-27 | 2003-11-19 |  |  |  | 2003-10-27 | 2003-11-19 | 17d | 158d |  | STEREO | IMPACT | SEP Package | Logic Bd | SEP DPU | CIT |  |  |  |
| 192 | 4.1.5.3.1 | Test FM 2 SEP Central Logic board (initial) | 5d | 2003-10-27 | 2003-10-31 | 174 |  |  | 2003-10-27 | 2003-10-31 | 5d | 158d | 0d | STEREO | IMPACT | SEP Package | Logic Bd | SEP DPU | CIT | SEP Cen |  |  |
| 193 | 4.1.5.3.2 | Doc FM 2 SEP Central Logic board test results | 3d | 2003-11-03 | 2003-11-05 | 192 |  |  | 2003-11-03 | 2003-11-05 | 3d | 158d | 0d | STEREO | IMPACT | SEP Package | Logic Bd | SEP DPU | CIT | SEP Cen |  |  |
| 194 | 4.1.5.3.3 | Stake/conformal coat FM 2 SEP Central Logic board | 1d | 2003-11-07 | 2003-11-07 | 176 |  |  | 2003-11-07 | 2003-11-07 | 1d | 158d | 0d | STEREO | IMPACT | SEP Package | Logic Bd | SEP DPU | CIT | SEP Cen |  |  |
| 195 | 4.1.5.3.4 | Bakeout FM 2 SEP Central Logic board | 1d | 2003-11-11 | 2003-11-11 | 194 |  |  | 2003-11-11 | 2003-11-11 | 1d | 158d | 0d | STEREO | IMPACT | SEP Package | Logic Bd | SEP DPU | CIT | SEP Cen |  |  |
| 196 | 4.1.5.3.5 | Post-conf. coat QA inspection of FM 2 SEP Central Logic Board | 1d | 2003-11-12 | 2003-11-12 | 195 |  |  | 2003-11-12 | 2003-11-12 | 1d | 158d | 0d | STEREO | IMPACT | SEP Package | Logic Bd | SEP DPU | CIT | SEP Cen |  |  |
| 197 | 4.1.5.3.6 | Test FM 2 SEP Central Logic board (final) | 4d | 2003-11-13 | 2003-11-18 | 196 |  |  | 2003-11-13 | 2003-11-18 | 4d | 158d | 0d | STEREO | IMPACT | SEP Package | Logic Bd | SEP DPU | CIT | SEP Cen |  |  |
| 198 | 4.1.5.3.7 | FM 2 SEP Central Logic Board Mass properties/photo | 1d | 2003-11-19 | 2003-11-19 | 197, 144 |  |  | 2003-11-19 | 2003-11-19 | 1d | 158d | 0d | STEREO | IMPACT | SEP Package | Logic Bd | SEP DPU | CIT | SEP Cen | Flight Logic Boards Tested |  |
| 199 | 4.1.5.3.8 | Maintain hard copy FM 2 SEP Central Logic Board docs | 9d | 2003-11-06 | 2003-11-19 | 198FF |  |  | 2003-11-06 | 2003-11-19 | 9d | 158d |  | STEREO | IMPACT | SEP Package | Logic Bd | SEP DPU | CIT | SEP Cen |  |  |
| 200 | 5 | **SEP Low Voltage Power Supply** | 245d | 2003-05-01 A | 2004-04-21 |  | 9% | 222.28d | 2003-05-01 | 2004-04-20 | 244d | 53d |  | STEREO | IMPACT | SEP Package | LVPS Card | SEP DPU | CIT |  |  | LVPS |
| 201 | 5.1 | **Design, Fabrication, Assembly and Test** | 245d | 2003-05-01 A | 2004-04-21 |  | 9% | 222.28d | 2003-05-01 | 2004-04-20 | 244d | 53d |  | STEREO | IMPACT | SEP Package | LVPS Card | SEP DPU | CIT |  |  | LVPS |
| 202 | 5.1.1 | **Design** | 134d | 2003-10-01 | 2004-04-14 |  |  |  | 2003-09-26 | 2004-04-13 | 136d | 26d |  | STEREO | IMPACT | SEP Package |  |  |  |  |  |  |
| 203 | 5.1.1.1 | Final Design of Flight Schematics | 5d | 2003-10-01 | 2003-10-08 | 88 |  |  | 2003-09-26 | 2003-10-02 | 5d | 26d | 0d | STEREO | IMPACT | SEP Package |  |  |  |  |  |  |
| 204 | 5.1.1.2 | Verify Flight Design Spec Implementation | 2d | 2003-10-09 | 2003-10-10 | 203 |  |  | 2003-10-03 | 2003-10-07 | 2d | 26d | 0d | STEREO | IMPACT | SEP Package |  |  |  |  |  |  |
| 205 | 5.1.1.3 | Final Design Review | 2d | 2003-10-13 | 2003-10-14 | 204 |  |  | 2003-10-08 | 2003-10-09 | 2d | 26d | 0d | STEREO | IMPACT | SEP Package |  |  |  |  |  |  |
| 206 | 5.1.1.4 | Layout Flight PCB | 9d | 2003-10-15 | 2003-10-27 | 205 |  |  | 2003-10-10 | 2003-10-22 | 9d | 26d | 0d | STEREO | IMPACT | SEP Package |  |  |  |  |  |  |
| 207 | 5.1.1.5 | Review and Approve Flight PCB layout | 2d | 2003-10-28 | 2003-10-29 | 206 |  |  | 2003-10-23 | 2003-10-24 | 2d | 26d | 0d | STEREO | IMPACT | SEP Package |  |  |  |  |  |  |
| 208 | 5.1.1.6 | Provide Feedback to UCB Designer for Flight Board 1 | 1d | 2004-02-20 | 2004-02-20 | 248 |  |  | 2004-02-19 | 2004-02-19 | 1d | 96d |  | STEREO | IMPACT | SEP Package |  |  |  |  |  |  |
| 209 | 5.1.1.7 | Document Flight Board 1 Rework (Traveler, ECR) | 1d | 2004-02-24 | 2004-02-24 | 226 |  |  | 2004-02-23 | 2004-02-23 | 1d | 92d | 0d | STEREO | IMPACT | SEP Package |  |  |  |  |  |  |
| 210 | 5.1.1.8 | Update PCB 1 Schematics & Layout (Final) | 2d | 2004-02-25 | 2004-02-26 | 209 |  |  | 2004-02-24 | 2004-02-25 | 2d | 92d |  | STEREO | IMPACT | SEP Package |  |  |  |  |  |  |
| 211 | 5.1.1.9 | Provide Feedback to UCB Designer for Flight Board 2 | 1d | 2004-04-08 | 2004-04-08 | 259 |  |  | 2004-04-07 | 2004-04-07 | 1d | 53d | 0d | STEREO | IMPACT | SEP Package |  |  |  |  |  |  |
| 212 | 5.1.1.10 | Document Flight Board 2 Rework (Traveler, ECR) | 1d | 2004-04-13 | 2004-04-13 | 231 |  |  | 2004-04-12 | 2004-04-12 | 1d | 58d | 0d | STEREO | IMPACT | SEP Package |  |  |  |  |  |  |
| 213 | 5.1.1.11 | Update PCB 2 Schematics & Layout (Final) | 1d | 2004-04-14 | 2004-04-14 | 212 |  |  | 2004-04-13 | 2004-04-13 | 1d | 58d |  | STEREO | IMPACT | SEP Package |  |  |  |  |  |  |
| 214 | 5.1.2 | **Fabrication** | 104d | 2003-08-22 A | 2004-01-23 |  | 71% | 29.71d | 2003-08-22 | 2004-01-22 | 103d | 0d |  | STEREO | IMPACT | SEP Package | LVPS Card | SEP DPU | CIT |  |  | LVPS |
| 215 | 5.1.2.1 | **ETU** | 5d | 2003-08-22 A | 2003-08-28 A |  | 100% |  | 2003-08-22 | 2003-08-28 | 5d |  |  | STEREO | IMPACT | SEP Package | LVPS Card | SEP DPU | CIT |  |  | LVPS |
| 216 | 5.1.2.1.1 | Fabricate dummy load box for EM board test | 5d | 2003-08-22 A | 2003-08-28 A | 235 | 100% |  | 2003-08-22 | 2003-08-28 | 5d |  |  | STEREO | IMPACT | SEP Package | LVPS Card | SEP DPU | CIT | PS |  | LVPS |

| ID | WBS | Task | Type | Duration | Start | Finish | Predecessors | Complete | Remaining | Baseline start | Baseline finish | Baseline duration | Total slack | Free slack | Constraint | Text11 | Text12 | Text13 | Text15 | Text16 | Text17 | Text28 | Text14 | Text23 |
| --- | --- | --- | --- | --- | --- | --- | --- | --- | --- | --- | --- | --- | --- | --- | --- | --- | --- | --- | --- | --- | --- | --- | --- | --- |
| 217 | 5.1.2.2 | **FM 1 & FM 2** |  | 42d | 2003-11-20 | 2004-01-23 |  |  |  | 2003-11-17 | 2004-01-22 | 44d | 0d |  |  | STEREO | IMPACT | SEP Package | LVPS Card | SEP DPU | LVPS | CIT |  |  |
| 218 | 5.1.2.2.1 | Modify dummy load box for flight boards test |  | 2d | 2004-01-22 | 2004-01-23 | 244 |  |  | 2004-01-21 | 2004-01-22 | 2d | 0d |  |  | STEREO | IMPACT | SEP Package | LVPS Card | SEP DPU | LVPS | CIT | PS |  |
| 219 | 5.1.2.2.2 | Flight PCB's Fabricated | milestone | 0d | 2003-11-20 | 2003-11-20 | 207FS+15d |  |  | 2003-11-17 | 2003-11-17 | 0d | 26d | 0d |  | STEREO | IMPACT | SEP Package |  |  |  |  |  |  |
| 220 | 5.1.3 | **Assembly** |  | 97d | 2003-11-21 | 2004-04-12 |  |  |  | 2003-11-18 | 2004-04-09 | 99d | 26d |  |  | STEREO | IMPACT | SEP Package |  |  |  |  |  |  |
| 221 | 5.1.3.1 | **FM 1** |  | 62d | 2003-11-21 | 2004-02-23 |  |  |  | 2003-11-18 | 2004-02-20 | 64d | 26d |  |  | STEREO | IMPACT | SEP Package |  |  |  |  |  |  |
| 222 | 1.2.2 | SEP Package EM I & T Complete | milestone | 0d | 2003-11-11 | 2003-11-11 |  |  |  |  |  |  | 33d | 7d |  | STEREO | IMPACT | SEP Package |  |  |  |  |  |  |
| 223 | 5.1.3.1.2 | Assemble Flight PCB 1 |  | 7d | 2003-11-21 | 2003-12-02 | 219, 222 |  |  | 2003-11-18 | 2003-11-26 | 7d | 26d | 0d |  | STEREO | IMPACT | SEP Package |  |  |  |  |  |  |
| 224 | 5.1.3.1.3 | Receive/QA Inspect/Document Flight Board 1 |  | 1d | 2004-01-20 | 2004-01-20 | 246 |  |  | 2004-01-19 | 2004-01-19 | 1d | 3d |  |  | STEREO | IMPACT | SEP Package |  |  |  |  |  |  |
| 225 | 5.1.3.1.4 | Rework/Haywire/Trim Flight Board 1 |  | 1d | 2004-02-20 | 2004-02-20 | 248 |  |  | 2004-02-19 | 2004-02-19 | 1d | 88d | 0d |  | STEREO | IMPACT | SEP Package |  |  |  |  |  |  |
| 226 | 5.1.3.1.5 | Post Rework QA Inspection Flight Board 1 |  | 1d | 2004-02-23 | 2004-02-23 | 225 |  |  | 2004-02-20 | 2004-02-20 | 1d | 88d | 0d |  | STEREO | IMPACT | SEP Package |  |  |  |  |  |  |
| 227 | 5.1.3.2 | **FM 2** |  | 90d | 2003-12-03 | 2004-04-12 |  |  |  | 2003-11-28 | 2004-04-09 | 92d | 53d |  |  | STEREO | IMPACT | SEP Package |  |  |  |  |  |  |
| 228 | 5.1.3.2.1 | Assemble Flight PCB 2 |  | 7d | 2003-12-03 | 2003-12-11 | 223 |  |  | 2003-11-28 | 2003-12-08 | 7d | 73d | 59d |  | STEREO | IMPACT | SEP Package |  |  |  |  |  |  |
| 229 | 5.1.3.2.2 | Receive/QA Inspect/Document Flight Board 2 |  | 1d | 2004-03-19 | 2004-03-19 | 256FS+2d |  |  | 2004-03-18 | 2004-03-18 | 1d | 14d | 0d |  | STEREO | IMPACT | SEP Package |  |  |  |  |  |  |
| 230 | 5.1.3.2.3 | Rework/Haywire/Trim Flight Board 2 |  | 1d | 2004-04-09 | 2004-04-09 | 211, 259 |  |  | 2004-04-08 | 2004-04-08 | 1d | 53d | 0d |  | STEREO | IMPACT | SEP Package |  |  |  |  |  |  |
| 231 | 5.1.3.2.4 | Post Rework QA Inspection Flight Board 2 |  | 1d | 2004-04-12 | 2004-04-12 | 230 |  |  | 2004-04-09 | 2004-04-09 | 1d | 53d | 0d |  | STEREO | IMPACT | SEP Package |  |  |  |  |  |  |
| 232 | 5.1.4 | **Test** |  | 245d | 2003-05-01 A | 2004-04-21 |  | 9% | 222.27d | 2003-05-01 | 2004-04-20 | 244d | 53d |  |  | STEREO | IMPACT | SEP Package | LVPS Card | SEP DPU | LVPS | CIT |  |  |
| 233 | 5.1.4.1 | **ETU** |  | 104d | 2003-05-01 A | 2003-09-26 |  | 28% | 74.75d | 2003-05-01 | 2003-09-23 | 101d | 26d |  |  | STEREO | IMPACT | SEP Package | LVPS Card | SEP DPU | LVPS | CIT |  |  |
| 234 | 5.1.4.1.1 | Test EM Board (UCB Pre-Delivery Test) |  | 10d | 2003-08-01 | 2003-08-14 |  |  |  | 2003-08-01 | 2003-08-14 | 10d | 19.5d | 0d | start no earlier than 2003-08-01 | STEREO | IMPACT | SEP Package |  |  |  |  |  |  |
| 235 | 5.1.4.1.2 | Prepare test spec for EM board test |  | 5d | 2003-08-15 | 2003-08-21 | 234 |  |  | 2003-08-15 | 2003-08-21 | 5d | 19.5d |  |  | STEREO | IMPACT | SEP Package | LVPS Card | SEP DPU | LVPS | CIT | SEP Cen |  |
| 236 | 5.1.4.1.3 | Receive/Inspect/document EM board |  | 0.5d | 2003-09-19 | 2003-09-19 | 19, 234 |  |  | 2003-09-16 | 2003-09-16 | 0.5d | 0d |  |  | STEREO | IMPACT | SEP Package | LVPS Card | SEP DPU | LVPS | CIT | SEP Cen |  |
| 237 | 5.1.4.1.4 | Test EM board with dummy load box |  | 0.5d | 2003-09-19 | 2003-09-19 | 216, 235, 236 |  |  | 2003-09-16 | 2003-09-16 | 0.5d | 0d |  |  | STEREO | IMPACT | SEP Package | LVPS Card | SEP DPU | LVPS | CIT | SEP Cen | ETU LVPS Tested |
| 238 | 5.1.4.1.5 | (OBSOLETE) Integrate & test EM board with SEP EM |  | 9d | 2003-05-01 A | 2003-05-13 A |  | 100% |  | 2003-05-01 | 2003-05-13 | 9d |  |  | start no earlier than 2003-04-30 | STEREO | IMPACT | SEP Package | LVPS Card | SEP DPU | LVPS | CIT | SEP Cen |  |
| 239 | 5.1.4.1.6 | Document EM boards test results |  | 3d | 2003-09-22 | 2003-09-24 | 238, 237 |  |  | 2003-09-17 | 2003-09-19 | 3d | 0d |  |  | STEREO | IMPACT | SEP Package | LVPS Card | SEP DPU | LVPS | CIT | SEP Cen |  |
| 240 | 5.1.4.1.7 | Provide feedback to UCB designer |  | 2d | 2003-09-25 | 2003-09-26 | 239 |  |  | 2003-09-22 | 2003-09-23 | 2d | 0d |  |  | STEREO | IMPACT | SEP Package | LVPS Card | SEP DPU | LVPS | CIT | SEP Cen |  |
| 241 | 5.1.4.1.8 | Rework/Haywire/Trim EM Board |  | 2d | 2003-09-25 | 2003-09-26 | 239 |  |  | 2003-09-22 | 2003-09-23 | 2d | 26d | 0d |  | STEREO | IMPACT | SEP Package | LVPS Card | SEP DPU | LVPS | CIT | SEP Cen |  |
| 242 | 2.1.5 | Integrate/Test SEP Central EM Boards |  | 5d | 2003-09-29 | 2003-10-03 | 241 |  |  | 2003-09-24 | 2003-09-30 | 5d | 33d | 0d |  | STEREO | IMPACT | SEP Package |  |  |  |  |  |  |

Notes:
- 236: Changed duration from 3 days to 1 day to reflect actual plan.
- 238: Deleted Predessor of 192, since board goes to EM I & T / May 2003 Status (RSP) - Someone marked the test of the ETU LVPS with SEP Central as obsolete. Assume the compat test in the I & T schedule is this same activity.

| ID | WBS | Task | Duration | Start | Finish | Predecessors | Complete | Remaining | Baseline start | Baseline finish | Baseline duration | Total slack | Free slack | Constraint | Text11 | Text12 | Text13 | Text15 | Text16 | Text17 | Text28 | Text14 | Text23 |
| --- | --- | --- | --- | --- | --- | --- | --- | --- | --- | --- | --- | --- | --- | --- | --- | --- | --- | --- | --- | --- | --- | --- | --- |
| 243 | 5.1.4.2 | **FM 1 & FM 2** | 71d | 2004-01-13 | 2004-04-21 |  |  |  | 2004-01-09 | 2004-04-20 | 71d | 0d |  |  | STEREO | IMPACT | SEP Package | LVPS Card | SEP DPU | LVPS | CIT |  |  |
| 244 | 5.1.4.2.1 | Prepare test spec for flight boards | 2d | 2004-01-20 | 2004-01-21 | 246 |  |  | 2004-01-19 | 2004-01-20 | 2d | 0d |  |  | STEREO | IMPACT | SEP Package | LVPS Card | SEP DPU | LVPS | CIT | SEP Cen |  |
| 245 | 5.1.4.2.2 | **FM 1** | 36d | 2004-01-13 | 2004-03-03 |  |  |  | 2004-01-09 | 2004-03-02 | 36d | 0d |  |  | STEREO | IMPACT | SEP Package | LVPS Card | SEP DPU | LVPS | CIT |  |  |
| 246 | 5.1.4.2.2.1 | Test Flight Board 1 (UCB Pre-Delivery Test) | 5d | 2004-01-13 | 2004-01-19 | 21, 223 |  |  | 2004-01-09 | 2004-01-16 | 5d | 0d |  |  | STEREO | IMPACT | SEP Package | LVPS Card | SEP DPU | LVPS | CIT | SEP Cen |  |
| 247 | 5.1.4.2.2.2 | Test Flight Board 1 with dummy load box | 5d | 2004-01-26 | 2004-01-30 | 218, 224 |  |  | 2004-01-23 | 2004-01-29 | 5d | 0d |  |  | STEREO | IMPACT | SEP Package | LVPS Card | SEP DPU | LVPS | CIT | SEP Cen | FM 1 LVPS Tested |
| 248 | 5.1.4.2.2.3 | Document Flight Board 1 Test Results | 3d | 2004-02-17 | 2004-02-19 | 247FS+10d |  |  | 2004-02-13 | 2004-02-18 | 3d | 88d | 0d |  | STEREO | IMPACT | SEP Package |  |  |  |  |  |  |
| 249 | 5.1.4.2.2.4 | Stake/Conformal Coat Flight Board 1 | 1d | 2004-02-24 | 2004-02-24 | 226 |  |  | 2004-02-23 | 2004-02-23 | 1d | 88d | 0d |  | STEREO | IMPACT | SEP Package |  |  |  |  |  |  |
| 250 | 5.1.4.2.2.5 | Bakeout Flight Board 1 | 1d | 2004-02-25 | 2004-02-25 | 249 |  |  | 2004-02-24 | 2004-02-24 | 1d | 88d | 0d |  | STEREO | IMPACT | SEP Package |  |  |  |  |  |  |
| 251 | 5.1.4.2.2.6 | Post-Conf Coat QA Inspection Flight Board 1 | 1d | 2004-02-26 | 2004-02-26 | 250 |  |  | 2004-02-25 | 2004-02-25 | 1d | 88d | 0d |  | STEREO | IMPACT | SEP Package |  |  |  |  |  |  |
| 252 | 5.1.4.2.2.7 | Test Flight Board 1 (Final) | 3d | 2004-02-27 | 2004-03-02 | 251 |  |  | 2004-02-26 | 2004-03-01 | 3d | 88d | 0d |  | STEREO | IMPACT | SEP Package |  |  |  |  |  |  |
| 253 | 5.1.4.2.2.8 | Mass Properties/Photo Flight Board 1 | 1d | 2004-03-03 | 2004-03-03 | 252 |  |  | 2004-03-02 | 2004-03-02 | 1d | 88d | 0d |  | STEREO | IMPACT | SEP Package |  |  |  |  |  |  |
| 254 | 5.1.4.2.2.9 | Maintain Hard Copy Docs FM 1 (Schematic, Parts List, Material List) | 9d | 2004-02-20 | 2004-03-03 | 253FF |  |  | 2004-02-19 | 2004-03-02 | 9d | 88d |  |  | STEREO | IMPACT | SEP Package |  |  |  |  |  |  |
| 255 | 5.1.4.2.3 | **FM 2** | 31d | 2004-03-10 | 2004-04-21 |  |  |  | 2004-03-09 | 2004-04-20 | 31d | 14d |  |  | STEREO | IMPACT | SEP Package | LVPS Card | SEP DPU | LVPS | CIT |  |  |
| 256 | 5.1.4.2.3.1 | Test Flight Board 2 (UCB Pre-Delivery Test) | 5d | 2004-03-10 | 2004-03-16 | 23, 228 |  |  | 2004-03-09 | 2004-03-15 | 5d | 14d | 0d |  | STEREO | IMPACT | SEP Package | LVPS Card | SEP DPU | LVPS | CIT | SEP Cen |  |
| 257 | 5.1.4.2.3.2 | Test Flight Board 2 with dummy load box | 5d | 2004-03-22 | 2004-03-26 | 229 |  |  | 2004-03-19 | 2004-03-25 | 5d | 14d | 0d |  | STEREO | IMPACT | SEP Package | LVPS Card | SEP DPU | LVPS | CIT | SEP Cen | FM 2 LVPS Tested |
| 258 | 5.1.4.2.3.3 | Integrate & Test Flight Board 2 with SEP | 5d | 2004-03-29 | 2004-04-02 | 257 |  |  | 2004-03-26 | 2004-04-01 | 5d | 53d | 0d |  | STEREO | IMPACT | SEP Package |  |  |  |  |  |  |
| 259 | 5.1.4.2.3.4 | Document Flight Board 2 Test Results | 3d | 2004-04-05 | 2004-04-07 | 258 |  |  | 2004-04-02 | 2004-04-06 | 3d | 53d | 0d |  | STEREO | IMPACT | SEP Package |  |  |  |  |  |  |
| 260 | 5.1.4.2.3.5 | Stake/Conformal Coat Flight Board 2 | 1d | 2004-04-13 | 2004-04-13 | 231 |  |  | 2004-04-12 | 2004-04-12 | 1d | 53d | 0d |  | STEREO | IMPACT | SEP Package |  |  |  |  |  |  |
| 261 | 5.1.4.2.3.6 | Bakeout Flight Board 2 | 1d | 2004-04-14 | 2004-04-14 | 260 |  |  | 2004-04-13 | 2004-04-13 | 1d | 53d | 0d |  | STEREO | IMPACT | SEP Package |  |  |  |  |  |  |
| 262 | 5.1.4.2.3.7 | Post-Conf Coat QA Inspection Flight Board 2 | 1d | 2004-04-15 | 2004-04-15 | 261 |  |  | 2004-04-14 | 2004-04-14 | 1d | 53d | 0d |  | STEREO | IMPACT | SEP Package |  |  |  |  |  |  |
| 263 | 5.1.4.2.3.8 | Test Flight Board 2 (Final) | 3d | 2004-04-16 | 2004-04-20 | 262 |  |  | 2004-04-15 | 2004-04-19 | 3d | 53d | 0d |  | STEREO | IMPACT | SEP Package |  |  |  |  |  |  |
| 264 | 5.1.4.2.3.9 | Mass Properties/Photo Flight Board 2 | 1d | 2004-04-21 | 2004-04-21 | 263 |  |  | 2004-04-20 | 2004-04-20 | 1d | 53d | 0d |  | STEREO | IMPACT | SEP Package |  |  |  |  |  |  |
| 265 | 5.1.4.2.3.10 | Maintain Hard Copy Docs FM 2 (Schematic, Parts List, Material List) | 9d | 2004-04-09 | 2004-04-21 | 264FF |  |  | 2004-04-08 | 2004-04-20 | 9d | 53d |  |  | STEREO | IMPACT | SEP Package |  |  |  |  |  |  |
| 266 | 6 | **SEP Analog/Post-reg Board** | 632d | 2002-01-02 A | 2004-07-07 |  | 48% | 330.54d | 2002-01-02 | 2004-07-07 | 632d | 0d |  |  | STEREO | IMPACT | SEP Package | Alog/Post-Reg Bd | SEP DPU | LVPS | CIT |  |  |
| 267 | 6.1 | **Design, Fabrication, Assembly and Test** | 632d | 2002-01-02 A | 2004-07-07 |  | 48% | 330.54d | 2002-01-02 | 2004-07-07 | 632d | 0d |  |  | STEREO | IMPACT | SEP Package | Alog/Post-Reg Bd | SEP DPU | LVPS | CIT |  |  |
| 268 | 6.1.1 | **Procurements** | 391d | 2002-12-17 A | 2004-07-07 |  | 35% | 253.14d | 2002-12-17 | 2004-07-07 | 391d | 0d |  |  | STEREO | IMPACT | SEP Package | Alog/Post-Reg Bd | SEP DPU | LVPS | CIT |  |  |
| 269 | 6.1.1.1 | **ETU** | 391d | 2002-12-17 A | 2004-07-07 |  | 34% | 259.45d | 2002-12-17 | 2004-07-07 | 391d | 0d |  |  | STEREO | IMPACT | SEP Package | Alog/Post-Reg Bd | SEP DPU | LVPS | CIT |  |  |
| 270 | 6.1.1.1.1 | Procure Analog/Post-reg Board EM parts | 21d | 2002-12-17 A | 2003-01-17 A | 280 | 100% |  | 2002-12-17 | 2003-01-17 | 21d |  |  |  | STEREO | IMPACT | SEP Package | Alog/Post-Reg Bd | SEP DPU | LVPS | CIT | SEP Cen |  |
| 271 | 6.1.1.1.2 | Procure Analog/Post-reg from SI | 298d | 2003-05-01 A | 2004-07-07 | 280 | 29% | 213d | 2003-05-01 | 2004-07-07 | 298d | 0d |  | start no earlier than 2003-04-30 | STEREO | IMPACT | SEP Package | Alog/Post-Reg Bd | SEP DPU | LVPS | CIT | SEP Cen |  |
| 272 | 6.1.1.1.3 | Procure Analog/Post-reg Board EM Printed Circuit Board | 2d | 2003-03-03 A | 2003-03-04 A | 288 | 100% |  | 2003-03-03 | 2003-03-04 | 2d |  |  |  | STEREO | IMPACT | SEP Package | Alog/Post-Reg Bd | SEP DPU | LVPS | CIT | SEP Cen |  |

Notes:
- 244: Pred is 41
- 271: Change logic so that we can take 55% credit. Really money related.

| ID | WBS | Task | Duration | Start | Finish | Predecessors | Complete | Remaining | Baseline start | Baseline finish | Baseline duration | Total slack | Free slack | Constraint | Text11 | Text12 | Text13 | Text15 | Text16 | Text17 | Text28 | Text14 |
| --- | --- | --- | --- | --- | --- | --- | --- | --- | --- | --- | --- | --- | --- | --- | --- | --- | --- | --- | --- | --- | --- | --- |
| 273 | 6.1.1.2 | **FM 1 & FM 2** | 57.5d | 2003-06-10 A | 2003-08-29 A |  | 100% |  | 2003-06-10 | 2003-08-29 | 57.5d |  |  |  | STEREO | IMPACT | SEP Package | Alog/Post-Reg Bd | SEP DPU | LVPS | CIT |  |
| 274 | 6.1.1.2.1 | Procure Analog/Post-reg Flight Boards parts | 5d | 2003-06-10 A | 2003-07-02 A | 336FS-5d | 100% |  | 2003-06-10 | 2003-07-02 | 5d |  |  |  | STEREO | IMPACT | SEP Package | Alog/Post-Reg Bd | SEP DPU | LVPS | CIT | SEP Cen |
| 275 | 6.1.1.2.2 | Procure Analog/Post-reg Flight Boards Printed Circuit Boards | 3d | 2003-08-27 A | 2003-08-29 A | 298 | 100% |  | 2003-08-27 | 2003-08-29 | 3d |  |  |  | STEREO | IMPACT | SEP Package | Alog/Post-Reg Bd | SEP DPU | LVPS | CIT | SEP Cen |
| 276 | 6.1.2 | **Design** | 477.5d | 2002-01-02 A | 2003-11-25 |  | 91% | 41.66d | 2002-01-02 | 2003-11-25 | 477.5d | 154.5d |  |  | STEREO | IMPACT | SEP Package | Alog/Post-Reg Bd | SEP DPU | LVPS | CIT |  |
| 277 | 6.1.2.1 | **ETU** | 376.4d | 2002-01-02 A | 2003-07-01 A |  | 100% |  | 2002-01-02 | 2003-07-01 | 376.4d |  |  |  | STEREO | IMPACT | SEP Package | Alog/Post-Reg Bd | SEP DPU | LVPS | CIT |  |
| 278 | 6.1.2.1.1 | Collect & verify SEP analog/post-reg requirements | 6.5d | 2002-01-02 A | 2002-12-03 A | 372FS+76d | 100% |  | 2002-01-02 | 2002-12-03 | 6.5d |  |  |  | STEREO | IMPACT | SEP Package | Alog/Post-Reg Bd | SEP DPU | LVPS | CIT | SEP Cen |
| 279 | 6.1.2.1.2 | Prepare Analog/Post-reg Board design spec & communicate to SI | 3d | 2002-04-26 A | 2002-04-30 A | 278 | 100% |  | 2002-04-26 | 2002-04-30 | 3d |  |  |  | STEREO | IMPACT | SEP Package | Alog/Post-Reg Bd | SEP DPU | LVPS | CIT | SEP Cen |
| 280 | 6.1.2.1.3 | Assess Analog/Post-reg Board EM & flight parts needs & availability | 2.4d | 2002-04-26 A | 2002-04-30 A | 279 | 100% |  | 2002-04-26 | 2002-04-30 | 2.4d |  |  |  | STEREO | IMPACT | SEP Package | Alog/Post-Reg Bd | SEP DPU | LVPS | CIT | SEP Cen |
| 281 | 6.1.2.1.4 | Obtain samples & footprint, provide to Printed Circuit Board designer | 2d | 2003-04-07 A | 2003-04-08 A | 307 | 100% |  | 2003-04-07 | 2003-04-08 | 2d |  |  | start no earlier than 2003-03-31 | STEREO | IMPACT | SEP Package | Alog/Post-Reg Bd | SEP DPU | LVPS | CIT | SEP Cen |
| 282 | 6.1.2.1.5 | Transfer Printed Circuit Board outline from GSFC to SI | 1d | 2002-05-01 A | 2002-05-01 A | 270FS-1d | 100% |  | 2002-05-01 | 2002-05-01 | 1d |  |  |  | STEREO | IMPACT | SEP Package | Alog/Post-Reg Bd | SEP DPU | LVPS | CIT | SEP Cen |
| 283 | 6.1.2.1.6 | Design Analog/Post-reg EM Board schematics | 14.8d | 2002-05-20 A | 2002-12-06 A | 282 | 100% |  | 2002-05-20 | 2002-12-06 | 14.8d |  |  |  | STEREO | IMPACT | SEP Package | Alog/Post-Reg Bd | SEP DPU | LVPS | CIT | SEP Cen |
| 284 | 6.1.2.1.7 | Verify design spec implementation - 1 | 3d | 2002-12-09 A | 2002-12-11 A | 283 | 100% |  | 2002-12-09 | 2002-12-11 | 3d |  |  | start no earlier than 2002-11-30 | STEREO | IMPACT | SEP Package | Alog/Post-Reg Bd | SEP DPU | LVPS | CIT | SEP Cen |
| 285 | 6.1.2.1.8 | FMA/design review/risk assessment | 5d | 2002-12-12 A | 2002-12-18 A | 284 | 100% |  | 2002-12-12 | 2002-12-18 | 5d |  |  |  | STEREO | IMPACT | SEP Package | Alog/Post-Reg Bd | SEP DPU | LVPS | CIT | SEP Cen |
| 286 | 6.1.2.1.9 | Provide feedback on design review to SI designer | 1d | 2002-12-19 A | 2002-12-19 A | 285 | 100% |  | 2002-12-19 | 2002-12-19 | 1d |  |  | start no earlier than 2002-11-30 | STEREO | IMPACT | SEP Package | Alog/Post-Reg Bd | SEP DPU | LVPS | CIT | SEP Cen |
| 287 | 6.1.2.1.10 | Design Analog/Post-reg EM Printed Circuit Board layout (final) | 17d | 2003-02-03 A | 2003-02-26 A | 286 | 100% |  | 2003-02-03 | 2003-02-26 | 17d |  |  | start no earlier than 2003-02-03 | STEREO | IMPACT | SEP Package | Alog/Post-Reg Bd | SEP DPU | LVPS | CIT | SEP Cen |
| 288 | 6.1.2.1.11 | Review & approve Analog/Post-reg EM Printed Circuit Board layout | 3d | 2003-02-27 A | 2003-03-03 A | 287 | 100% |  | 2003-02-27 | 2003-03-03 | 3d |  |  |  | STEREO | IMPACT | SEP Package | Alog/Post-Reg Bd | SEP DPU | LVPS | CIT | SEP Cen |
| 289 | 6.1.2.1.12 | Doc Analog/Post-reg EM board rework (traveler, ECR) | 2d | 2003-06-06 A | 2003-07-01 A | 309 | 100% |  | 2003-06-06 | 2003-07-01 | 2d |  |  |  | STEREO | IMPACT | SEP Package | Alog/Post-Reg Bd | SEP DPU | LVPS | CIT | SEP Cen |
| 290 | 6.1.2.2 | **FM 1 & FM 2** | 116d | 2003-06-10 A | 2003-11-25 |  | 74% | 29.94d | 2003-06-10 | 2003-11-25 | 116d | 154.5d |  |  | STEREO | IMPACT | SEP Package | Alog/Post-Reg Bd | SEP DPU | LVPS | CIT |  |
| 291 | 6.1.2.2.1 | Obtain samples & footprints, provide to Printed Circuit Board designer | 5d | 2003-06-10 A | 2003-06-17 A | 274SS | 100% |  | 2003-06-10 | 2003-06-17 | 5d |  |  |  | STEREO | IMPACT | SEP Package | Alog/Post-Reg Bd | SEP DPU | LVPS | CIT | SEP Cen |
| 292 | 6.1.2.2.2 | Collect SEP analog/post-reg requirements update | 1d | 2003-06-17 A | 2003-07-02 A | 274, 96 | 100% |  | 2003-06-17 | 2003-07-02 | 1d |  |  |  | STEREO | IMPACT | SEP Package | Alog/Post-Reg Bd | SEP DPU | LVPS | CIT | SEP Cen |
| 293 | 6.1.2.2.3 | Update design spec & communicate it to SI | 1d | 2003-06-18 A | 2003-07-09 A | 336, 292 | 100% |  | 2003-06-18 | 2003-07-09 | 1d |  |  |  | STEREO | IMPACT | SEP Package | Alog/Post-Reg Bd | SEP DPU | LVPS | CIT | SEP Cen |
| 294 | 6.1.2.2.4 | Verify design spec implementation - 3 | 2d | 2003-07-09 A | 2003-07-11 A | 293 | 100% |  | 2003-07-09 | 2003-07-11 | 2d |  |  | start no earlier than 2003-06-30 | STEREO | IMPACT | SEP Package | Alog/Post-Reg Bd | SEP DPU | LVPS | CIT | SEP Cen |
| 295 | 6.1.2.2.5 | Design Analog/Post-reg Flight Boards schematics (final) | 5d | 2003-08-07 A | 2003-08-13 A | 294FS+5d | 100% |  | 2003-08-07 | 2003-08-13 | 5d |  |  | start no earlier than 2003-08-07 | STEREO | IMPACT | SEP Package | Alog/Post-Reg Bd | SEP DPU | LVPS | CIT | SEP Cen |
| 296 | 6.1.2.2.6 | Final design review | 2d | 2003-08-14 A | 2003-08-15 A | 295 | 100% |  | 2003-08-14 | 2003-08-15 | 2d |  |  |  | STEREO | IMPACT | SEP Package | Alog/Post-Reg Bd | SEP DPU | LVPS | CIT | SEP Cen |
| 297 | 6.1.2.2.7 | Layout analog/post-reg Printed Circuit Board (final) | 5d | 2003-08-18 A | 2003-08-22 A | 296 | 100% |  | 2003-08-18 | 2003-08-22 | 5d |  |  |  | STEREO | IMPACT | SEP Package | Alog/Post-Reg Bd | SEP DPU | LVPS | CIT | SEP Cen |
| 298 | 6.1.2.2.8 | Review & approve Analog/Post-reg Flight Boards Printed Circuit Board layout | 2d | 2003-08-25 A | 2003-08-26 A | 297 | 100% |  | 2003-08-25 | 2003-08-26 | 2d |  |  |  | STEREO | IMPACT | SEP Package | Alog/Post-Reg Bd | SEP DPU | LVPS | CIT | SEP Cen |
| 299 | 6.1.2.2.9 | Provide feedback on test results to FM 1 SI designer | 1d | 2003-10-28 | 2003-10-28 | 343 |  |  | 2003-10-28 | 2003-10-28 | 1d | 164d | 0d |  | STEREO | IMPACT | SEP Package | Alog/Post-Reg Bd | SEP DPU | LVPS | CIT | SEP Cen |
| 300 | 6.1.2.2.10 | Doc Analog/Post-reg Flight Board 1 rework (traveler, ECR) | 1d | 2003-10-30 | 2003-10-30 | 323 |  |  | 2003-10-30 | 2003-10-30 | 1d | 164d | 0d |  | STEREO | IMPACT | SEP Package | Alog/Post-Reg Bd | SEP DPU | LVPS | CIT | SEP Cen |
| 301 | 6.1.2.2.11 | Final update of Printed Circuit Board FM 1 schematics & layout | 2d | 2003-11-07 | 2003-11-11 | 300FS+5d |  |  | 2003-11-07 | 2003-11-11 | 2d | 164d |  |  | STEREO | IMPACT | SEP Package | Alog/Post-Reg Bd | SEP DPU | LVPS | CIT | SEP Cen |
| 302 | 6.1.2.2.12 | Provide feedback on test results to FM 2 SI designer | 1d | 2003-11-18 | 2003-11-18 | 354 |  |  | 2003-11-18 | 2003-11-18 | 1d | 152d | 0d |  | STEREO | IMPACT | SEP Package | Alog/Post-Reg Bd | SEP DPU | LVPS | CIT | SEP Cen |
| 303 | 6.1.2.2.13 | Doc Analog/Post-reg Flight Board 2 rework (traveler, ECR) | 1d | 2003-11-20 | 2003-11-21 | 327 |  |  | 2003-11-20 | 2003-11-21 | 1d | 153.5d | 0d |  | STEREO | IMPACT | SEP Package | Alog/Post-Reg Bd | SEP DPU | LVPS | CIT | SEP Cen |
| 304 | 6.1.2.2.14 | Final update of Printed Circuit Board FM 2 schematics & layout | 2d | 2003-11-21 | 2003-11-25 | 303 |  |  | 2003-11-21 | 2003-11-25 | 2d | 153.5d | 1.5d |  | STEREO | IMPACT | SEP Package | Alog/Post-Reg Bd | SEP DPU | LVPS | CIT | SEP Cen |

| ID | WBS | Task | Duration | Start | Finish | Predecessors | Complete | Remaining | Baseline start | Baseline finish | Baseline duration | Total slack | Free slack | Constraint | Text11 | Text12 | Text13 | Text15 | Text16 | Text17 | Text28 | Text14 | Text23 |
| --- | --- | --- | --- | --- | --- | --- | --- | --- | --- | --- | --- | --- | --- | --- | --- | --- | --- | --- | --- | --- | --- | --- | --- |
| 305 | 6.1.3 | **Fabrication** | 129d | 2003-03-28 A | 2003-09-29 |  | 50% | 64.5d | 2003-03-28 | 2003-09-29 | 129d | 72d |  |  | STEREO | IMPACT | SEP Package | Alog/Post-Reg Bd | SEP DPU | LVPS | CIT |  |  |
| 306 | 6.1.3.1 | **ETU** | 49.5d | 2003-03-28 A | 2003-06-06 A |  | 100% |  | 2003-03-28 | 2003-06-06 | 49.5d |  |  |  | STEREO | IMPACT | SEP Package | Alog/Post-Reg Bd | SEP DPU | LVPS | CIT |  |  |
| 307 | 6.1.3.1.1 | Receive/inspect/database Analog/Post-reg EM Board parts | 4d | 2003-04-01 A | 2003-04-04 A | 270FS+27d | 100% |  | 2003-04-01 | 2003-04-04 | 4d |  |  | start no earlier than 2003-03-31 | STEREO | IMPACT | SEP Package | Alog/Post-Reg Bd | SEP DPU | LVPS | CIT | SEP Cen |  |
| 308 | 6.1.3.1.2 | Inspect Analog/Post-reg EM Printed Circuit Board | 1d | 2003-03-28 A | 2003-03-28 A | 272FS+17d | 100% |  | 2003-03-28 | 2003-03-28 | 1d |  |  |  | STEREO | IMPACT | SEP Package | Alog/Post-Reg Bd | SEP DPU | LVPS | CIT | SEP Cen | EM Analog/Post-reg Board Fabricated |
| 309 | 6.1.3.1.3 | Rework/haywire/trim Analog/Post-reg EM board | 2d | 2003-06-04 A | 2003-06-06 A | 335 | 100% |  | 2003-06-04 | 2003-06-06 | 2d |  |  |  | STEREO | IMPACT | SEP Package | Alog/Post-Reg Bd | SEP DPU | LVPS | CIT | SEP Cen |  |
| 310 | 6.1.3.2 | **FM 1 & FM 2** | 62.5d | 2003-07-01 A | 2003-09-29 |  | 29% | 44.12d | 2003-07-01 | 2003-09-29 | 62.5d | 72d |  |  | STEREO | IMPACT | SEP Package | Alog/Post-Reg Bd | SEP DPU | LVPS | CIT |  |  |
| 311 | 6.1.3.2.1 | Receive/inspect/database Analog/Post-reg Flight Boards parts | 5d | 2003-07-01 A | 2003-07-18 A | 274FS+10d | 100% |  | 2003-07-01 | 2003-07-18 | 5d |  |  |  | STEREO | IMPACT | SEP Package | Alog/Post-Reg Bd | SEP DPU | LVPS | CIT | SEP Cen |  |
| 312 | 6.1.3.2.2 | Inspect Analog/Post-reg Flight Boards Printed Circuit Boards (coupon & elec. cont.) | 4d | 2003-09-12 | 2003-09-17 | 275FS+8d |  |  | 2003-09-12 | 2003-09-17 | 4d | 71d | 0d |  | STEREO | IMPACT | SEP Package | Alog/Post-Reg Bd | SEP DPU | LVPS | CIT | SEP Cen | Flight Analog/Post-reg Boards Fabricated |
| 313 | 6.1.3.2.3 | Generate Flight Kit List in Database | 1d | 2003-09-18 | 2003-09-18 | 312 |  |  | 2003-09-18 | 2003-09-18 | 1d | 72d | 0d |  | STEREO | IMPACT | SEP Package |  |  |  |  |  |  |
| 314 | 6.1.3.2.4 | Bend Leads on Flight IC's | 2d | 2003-09-19 | 2003-09-22 | 313 |  |  | 2003-09-19 | 2003-09-22 | 2d | 72d | 0d |  | STEREO | IMPACT | SEP Package |  |  |  |  |  |  |
| 315 | 6.1.3.2.5 | Generate Flight Kit Book | 2d | 2003-09-23 | 2003-09-24 | 314 |  |  | 2003-09-23 | 2003-09-24 | 2d | 72d | 0d |  | STEREO | IMPACT | SEP Package |  |  |  |  |  |  |
| 316 | 6.1.3.2.6 | Kit Flight Parts (2 Boards) | 3d | 2003-09-25 | 2003-09-29 | 315 |  |  | 2003-09-25 | 2003-09-29 | 3d | 72d | 1d |  | STEREO | IMPACT | SEP Package |  |  |  |  |  |  |
| 317 | 6.1.4 | **Assembly** | 162.5d | 2003-04-01 A | 2003-11-20 |  | 44% | 90.28d | 2003-04-01 | 2003-11-20 | 162.5d | 152d |  |  | STEREO | IMPACT | SEP Package | Alog/Post-Reg Bd | SEP DPU | LVPS | CIT |  |  |
| 318 | 6.1.4.1 | **ETU** | 10d | 2003-04-01 A | 2003-04-14 A |  | 100% |  | 2003-04-01 | 2003-04-14 | 10d |  |  |  | STEREO | IMPACT | SEP Package | Alog/Post-Reg Bd | SEP DPU | LVPS | CIT |  |  |
| 319 | 6.1.4.1.1 | Assemble Analog/Post-reg EM Printed Circuit Board | 10d | 2003-04-01 A | 2003-04-14 A | 308 | 100% |  | 2003-04-01 | 2003-04-14 | 10d |  |  | start no earlier than 2003-03-31 | STEREO | IMPACT | SEP Package | Alog/Post-Reg Bd | SEP DPU | LVPS | CIT | SEP Cen | EM Analog/Post-reg Board Assembled |
| 320 | 6.1.4.2 | **FM 1** | 20d | 2003-10-01 | 2003-10-29 |  |  |  | 2003-10-01 | 2003-10-29 | 20d | 71d |  |  | STEREO | IMPACT | SEP Package | Alog/Post-Reg Bd | SEP DPU | LVPS | CIT |  |  |
| 321 | 6.1.4.2.1 | Assemble Analog/Post-reg Flight Printed Circuit Board 1 | 5d | 2003-10-01 | 2003-10-08 | 312FS+9d, 316 |  |  | 2003-10-01 | 2003-10-08 | 5d | 71d | 0d |  | STEREO | IMPACT | SEP Package | Alog/Post-Reg Bd | SEP DPU | LVPS | CIT | SEP Cen | Flight Analog/Post-reg Board Assembled |
| 322 | 6.1.4.2.2 | Rework/haywire/trim Analog/Post-reg Flight Board 1 | 0.5d | 2003-10-29 | 2003-10-29 | 299 |  |  | 2003-10-29 | 2003-10-29 | 0.5d | 164d | 0d |  | STEREO | IMPACT | SEP Package | Alog/Post-Reg Bd | SEP DPU | LVPS | CIT | SEP Cen |  |
| 323 | 6.1.4.2.3 | Post rework QA inspection Flight Board 1 | 0.5d | 2003-10-29 | 2003-10-29 | 322 |  |  | 2003-10-29 | 2003-10-29 | 0.5d | 164d | 0d |  | STEREO | IMPACT | SEP Package | Alog/Post-Reg Bd | SEP DPU | LVPS | CIT | SEP Cen |  |
| 324 | 6.1.4.3 | **FM 2** | 18.5d | 2003-10-24 | 2003-11-20 |  |  |  | 2003-10-24 | 2003-11-20 | 18.5d | 152d |  |  | STEREO | IMPACT | SEP Package | Alog/Post-Reg Bd | SEP DPU | LVPS | CIT |  |  |
| 325 | 6.1.4.3.1 | Assemble Analog/Post-reg Flight Printed Circuit Board 2 | 5d | 2003-10-24 | 2003-10-30 | 173, 321 |  |  | 2003-10-24 | 2003-10-30 | 5d | 152d | 0d |  | STEREO | IMPACT | SEP Package | Alog/Post-Reg Bd | SEP DPU | LVPS | CIT | SEP Cen | Flight Analog/Post-reg Board Assembled |
| 326 | 6.1.4.3.2 | Rework/haywire/trim Analog/Post-reg Flight Board 2 | 1d | 2003-11-19 | 2003-11-19 | 302 |  |  | 2003-11-19 | 2003-11-19 | 1d | 152d | 0d |  | STEREO | IMPACT | SEP Package | Alog/Post-Reg Bd | SEP DPU | LVPS | CIT | SEP Cen |  |
| 327 | 6.1.4.3.3 | Post rework QA inspection Flight Board 2 | 0.5d | 2003-11-20 | 2003-11-20 | 326 |  |  | 2003-11-20 | 2003-11-20 | 0.5d | 152d | 0d |  | STEREO | IMPACT | SEP Package | Alog/Post-Reg Bd | SEP DPU | LVPS | CIT | SEP Cen |  |
| 328 | 6.1.5 | **Test** | 168d | 2003-04-01 A | 2003-11-28 |  | 49% | 86.01d | 2003-04-01 | 2003-11-28 | 168d | 152d |  |  | STEREO | IMPACT | SEP Package | Alog/Post-Reg Bd | SEP DPU | LVPS | CIT |  |  |
| 329 | 6.1.5.1 | **ETU** | 69.4d | 2003-04-01 A | 2003-07-09 A |  | 100% |  | 2003-04-01 | 2003-07-09 | 69.4d |  |  |  | STEREO | IMPACT | SEP Package | Alog/Post-Reg Bd | SEP DPU | LVPS | CIT |  |  |
| 330 | 6.1.5.1.1 | Prepare test spec for Analog/Post-reg EM board | 2d | 2003-04-01 A | 2003-04-02 A | 272 | 100% |  | 2003-04-01 | 2003-04-02 | 2d |  |  | start no earlier than 2003-03-31 | STEREO | IMPACT | SEP Package | Alog/Post-Reg Bd | SEP DPU | LVPS | CIT | SEP Cen |  |
| 331 | 6.1.5.1.2 | Test Analog/Post-reg Board EM board | 30d | 2003-04-15 A | 2003-07-02 A | 330, 319 | 100% |  | 2003-04-15 | 2003-07-02 | 30d |  |  |  | STEREO | IMPACT | SEP Package | Alog/Post-Reg Bd | SEP DPU | LVPS | CIT | SEP Cen |  |
| 332 | 6.1.5.1.3 | Receive/inspect/doc Analog/Post-reg EM board | 2d | 2003-05-28 A | 2003-07-02 A | 331 | 100% |  | 2003-05-28 | 2003-07-02 | 2d |  |  |  | STEREO | IMPACT | SEP Package | Alog/Post-Reg Bd | SEP DPU | LVPS | CIT | SEP Cen | EM Analog/Post-reg Board Tested |
| 333 | 6.1.5.1.4 | Integrate & test Analog/Post-regxEM board with SEP EM | 5d | 2003-05-19 A | 2003-05-23 A | 332 | 100% |  | 2003-05-19 | 2003-05-23 | 5d |  |  | start no earlier than 2003-06-17 | STEREO | IMPACT | SEP Package | Alog/Post-Reg Bd | SEP DPU | LVPS | CIT | SEP Cen |  |
| 334 | 6.1.5.1.5 | Doc Analog/Post-reg EM board test results | 5d | 2003-05-23 A | 2003-07-01 A | 333 | 100% |  | 2003-05-23 | 2003-07-01 | 5d |  |  |  | STEREO | IMPACT | SEP Package | Alog/Post-Reg Bd | SEP DPU | LVPS | CIT | SEP Cen |  |
| 335 | 6.1.5.1.6 | Provide feedback on Analog/Post-Reg EM Board test results to SI designer | 2d | 2003-06-02 A | 2003-07-01 A | 334 | 100% |  | 2003-06-02 | 2003-07-01 | 2d |  |  |  | STEREO | IMPACT | SEP Package | Alog/Post-Reg Bd | SEP DPU | LVPS | CIT | SEP Cen |  |
| 336 | 6.1.5.1.7 | Test Analog/Post-reg Board EM board with SEP EM (final) | 5d | 2003-07-01 A | 2003-07-09 A | 289 | 100% |  | 2003-07-01 | 2003-07-09 | 5d |  |  | start no earlier than 2003-06-30 | STEREO | IMPACT | SEP Package | Alog/Post-Reg Bd | SEP DPU | LVPS | CIT | SEP Cen |  |

| ID | WBS | Task | Duration | Start | Finish | Predecessors | Baseline start | Baseline finish | Baseline duration | Total slack | Free slack | Text11 | Text12 | Text13 | Text15 | Text16 | Text17 | Text28 | Text14 | Text23 |
| --- | --- | --- | --- | --- | --- | --- | --- | --- | --- | --- | --- | --- | --- | --- | --- | --- | --- | --- | --- | --- |
| 337 | 6.1.5.2 | **FM 1 & FM 2** | 35d | 2003-10-09 | 2003-11-28 |  | 2003-10-09 | 2003-11-28 | 35d | 71d |  | STEREO | IMPACT | SEP Package | Alog/Post-Reg Bd | SEP DPU | LVPS | CIT |  |  |
| 338 | 6.1.5.2.1 | Prepare test spec for Analog/Post-reg Flight Boards | 1d | 2003-10-09 | 2003-10-09 | 321 | 2003-10-09 | 2003-10-09 | 1d | 71d | 0d | STEREO | IMPACT | SEP Package | Alog/Post-Reg Bd | SEP DPU | LVPS | CIT | SEP Cen |  |
| 339 | 6.1.5.2.2 | **FM 1** | 20d | 2003-10-10 | 2003-11-06 |  | 2003-10-10 | 2003-11-06 | 20d | 71d |  | STEREO | IMPACT | SEP Package |  |  |  |  |  |  |
| 340 | 6.1.5.2.2.1 | Test Flight Board 1 Pre-Delivery | 5d | 2003-10-10 | 2003-10-16 | 338 | 2003-10-10 | 2003-10-16 | 5d | 71d | 0d | STEREO | IMPACT | SEP Package | Alog/Post-Reg Bd | SEP DPU | LVPS | CIT | SEP Cen |  |
| 341 | 6.1.5.2.2.2 | Receive/QA inspect/document Flight Board 1 | 1d | 2003-10-17 | 2003-10-17 | 340 | 2003-10-17 | 2003-10-17 | 1d | 71d | 0d | STEREO | IMPACT | SEP Package | Alog/Post-Reg Bd | SEP DPU | LVPS | CIT | SEP Cen |  |
| 342 | 6.1.5.2.2.3 | Test Flight Board 1 Post Delivery | 3d | 2003-10-20 | 2003-10-22 | 341 | 2003-10-20 | 2003-10-22 | 3d | 164d | 0d | STEREO | IMPACT | SEP Package | Alog/Post-Reg Bd | SEP DPU | LVPS | CIT | SEP Cen |  |
| 343 | 6.1.5.2.2.4 | Doc Flight Board 1 test results | 3d | 2003-10-23 | 2003-10-27 | 342 | 2003-10-23 | 2003-10-27 | 3d | 164d | 0d | STEREO | IMPACT | SEP Package | Alog/Post-Reg Bd | SEP DPU | LVPS | CIT | SEP Cen |  |
| 344 | 6.1.5.2.2.5 | Stake/conformal coat Analog/Post-reg Flight Board 1 | 1d | 2003-10-30 | 2003-10-30 | 323 | 2003-10-30 | 2003-10-30 | 1d | 166d | 0d | STEREO | IMPACT | SEP Package | Alog/Post-Reg Bd | SEP DPU | LVPS | CIT | SEP Cen |  |
| 345 | 6.1.5.2.2.6 | Bakeout Analog/Post-reg Flight Board 1 | 1d | 2003-10-31 | 2003-10-31 | 344 | 2003-10-31 | 2003-10-31 | 1d | 166d | 0d | STEREO | IMPACT | SEP Package | Alog/Post-Reg Bd | SEP DPU | LVPS | CIT | SEP Cen |  |
| 346 | 6.1.5.2.2.7 | Post-conf coat QA inspection Flight Board 1 | 1d | 2003-11-03 | 2003-11-03 | 345 | 2003-11-03 | 2003-11-03 | 1d | 166d | 0d | STEREO | IMPACT | SEP Package | Alog/Post-Reg Bd | SEP DPU | LVPS | CIT | SEP Cen |  |
| 347 | 6.1.5.2.2.8 | Test Analog/Post-reg Flight Board 1 (final) | 2d | 2003-11-04 | 2003-11-05 | 346 | 2003-11-04 | 2003-11-05 | 2d | 166d | 0d | STEREO | IMPACT | SEP Package | Alog/Post-Reg Bd | SEP DPU | LVPS | CIT | SEP Cen | Flight Analog/Post-reg Boards Tested |
| 348 | 6.1.5.2.2.9 | Analog/Post-reg Flight Board 1 Mass properties/photo | 1d | 2003-11-06 | 2003-11-06 | 347 | 2003-11-06 | 2003-11-06 | 1d | 166d | 0d | STEREO | IMPACT | SEP Package | Alog/Post-Reg Bd | SEP DPU | LVPS | CIT | SEP Cen |  |
| 349 | 6.1.5.2.2.10 | Maintain Analog/Post-reg Board 1 hard copy docs (sch, parts, material list) | 9d | 2003-10-27 | 2003-11-06 | 348FF | 2003-10-27 | 2003-11-06 | 9d | 166d |  | STEREO | IMPACT | SEP Package | Alog/Post-Reg Bd | SEP DPU | LVPS | CIT | SEP Cen |  |
| 350 | 6.1.5.2.3 | **FM 2** | 19d | 2003-10-31 | 2003-11-28 |  | 2003-10-31 | 2003-11-28 | 19d | 152d |  | STEREO | IMPACT | SEP Package |  |  |  |  |  |  |
| 351 | 6.1.5.2.3.1 | Test Flight Board 2 Pre-Delivery | 5d | 2003-10-31 | 2003-11-06 | 325 | 2003-10-31 | 2003-11-06 | 5d | 152d | 0d | STEREO | IMPACT | SEP Package | Alog/Post-Reg Bd | SEP DPU | LVPS | CIT | SEP Cen |  |
| 352 | 6.1.5.2.3.2 | Receive/QA inspect/document Flight Board 2 | 1d | 2003-11-07 | 2003-11-07 | 351 | 2003-11-07 | 2003-11-07 | 1d | 152d | 0d | STEREO | IMPACT | SEP Package | Alog/Post-Reg Bd | SEP DPU | LVPS | CIT | SEP Cen |  |
| 353 | 6.1.5.2.3.3 | Test Flight Board 2 Post Delivery | 2d | 2003-11-11 | 2003-11-12 | 352 | 2003-11-11 | 2003-11-12 | 2d | 152d | 0d | STEREO | IMPACT | SEP Package | Alog/Post-Reg Bd | SEP DPU | LVPS | CIT | SEP Cen |  |
| 354 | 6.1.5.2.3.4 | Doc Flight Board 2 test results | 3d | 2003-11-13 | 2003-11-17 | 353 | 2003-11-13 | 2003-11-17 | 3d | 152d | 0d | STEREO | IMPACT | SEP Package | Alog/Post-Reg Bd | SEP DPU | LVPS | CIT | SEP Cen |  |
| 355 | 6.1.5.2.3.5 | Stake/conformal coat Analog/Post-reg Flight Board 2 | 1d | 2003-11-20 | 2003-11-21 | 327 | 2003-11-20 | 2003-11-21 | 1d | 152d | 0d | STEREO | IMPACT | SEP Package | Alog/Post-Reg Bd | SEP DPU | LVPS | CIT | SEP Cen |  |
| 356 | 6.1.5.2.3.6 | Bakeout Analog/Post-reg Flight Board 2 | 1d | 2003-11-21 | 2003-11-24 | 355 | 2003-11-21 | 2003-11-24 | 1d | 152d | 0d | STEREO | IMPACT | SEP Package | Alog/Post-Reg Bd | SEP DPU | LVPS | CIT | SEP Cen |  |
| 357 | 6.1.5.2.3.7 | Post-conf coat QA inspection Flight Board 2 | 0.5d | 2003-11-24 | 2003-11-24 | 356 | 2003-11-24 | 2003-11-24 | 0.5d | 152d | 0d | STEREO | IMPACT | SEP Package | Alog/Post-Reg Bd | SEP DPU | LVPS | CIT | SEP Cen |  |
| 358 | 6.1.5.2.3.8 | Test Analog/Post-reg Flight Board 2 (final) | 2d | 2003-11-25 | 2003-11-26 | 357 | 2003-11-25 | 2003-11-26 | 2d | 152d | 0d | STEREO | IMPACT | SEP Package | Alog/Post-Reg Bd | SEP DPU | LVPS | CIT | SEP Cen | Flight Analog/Post-reg Boards Tested |
| 359 | 6.1.5.2.3.9 | Analog/Post-reg Flight Board 2 Mass properties/photo | 1d | 2003-11-28 | 2003-11-28 | 358, 304 | 2003-11-28 | 2003-11-28 | 1d | 152d | 0d | STEREO | IMPACT | SEP Package | Alog/Post-Reg Bd | SEP DPU | LVPS | CIT | SEP Cen |  |
| 360 | 6.1.5.2.3.10 | Maintain Analog/Post-reg Board 2 hard copy docs (sch, parts, material list) | 9d | 2003-11-17 | 2003-11-28 | 359FF | 2003-11-17 | 2003-11-28 | 9d | 152d |  | STEREO | IMPACT | SEP Package | Alog/Post-Reg Bd | SEP DPU | LVPS | CIT | SEP Cen |  |

| ID | WBS | Task | Type | Duration | Start | Finish | Predecessors | Complete | Remaining | Baseline start | Baseline finish | Baseline duration | Total slack | Free slack | Constraint | Text11 | Text12 | Text13 | Text15 | Text16 | Text17 | Text28 | Text14 |
| --- | --- | --- | --- | --- | --- | --- | --- | --- | --- | --- | --- | --- | --- | --- | --- | --- | --- | --- | --- | --- | --- | --- | --- |
| 361 | 7 | **SEP Solid State Detector Bias Supply** |  | 590d | 2001-11-06 A | 2004-03-16 |  | 58% | 249d | 2001-11-06 | 2004-03-16 | 590d | 79d |  |  | STEREO | IMPACT | SEP Package | SSD Bias Card | SEP DPU | LVPS | CIT |  |
| 362 | 7.1 | **Design, Fabrication, Assembly and Test** |  | 590d | 2001-11-06 A | 2004-03-16 |  | 58% | 249d | 2001-11-06 | 2004-03-16 | 590d | 79d |  |  | STEREO | IMPACT | SEP Package | SSD Bias Card | SEP DPU | LVPS | CIT |  |
| 363 | 7.1.1 | **Procurements** |  | 342d | 2002-11-01 A | 2004-03-16 |  | 56% | 149.05d | 2002-11-01 | 2004-03-16 | 342d | 79d |  |  | STEREO | IMPACT | SEP Package | SSD Bias Card | SEP DPU | LVPS | CIT |  |
| 364 | 7.1.1.1 | **ETU** |  | 342d | 2002-11-01 A | 2004-03-16 |  | 57% | 147.43d | 2002-11-01 | 2004-03-16 | 342d | 79d |  |  | STEREO | IMPACT | SEP Package | SSD Bias Card | SEP DPU | LVPS | CIT |  |
| 365 | 7.1.1.1.1 | Procure Solid State Detector Bias Supply EM parts |  | 14d | 2003-04-01 A | 2003-04-18 A | 375 | 100% |  | 2003-04-01 | 2003-04-18 | 14d |  |  | start no earlier than 2003-03-31 | STEREO | IMPACT | SEP Package | SSD Bias Card | SEP DPU | LVPS | CIT | SEP Cen |
| 366 | 7.1.1.1.2 | Solid State Detector Bias Supply from SI |  | 342d | 2002-11-01 A | 2004-03-16 | 375FS-14d | 55% | 153.9d | 2002-11-01 | 2004-03-16 | 342d | 79d |  | start no earlier than 2002-10-31 | STEREO | IMPACT | SEP Package | SSD Bias Card | SEP DPU | LVPS | CIT | SEP Cen |
| 367 | 7.1.1.1.3 | Procure Solid State Detector EM Printed Circuit Board |  | 1d | 2003-03-18 A | 2003-03-18 A | 383 | 100% |  | 2003-03-18 | 2003-03-18 | 1d |  |  |  | STEREO | IMPACT | SEP Package | SSD Bias Card | SEP DPU | LVPS | CIT | SEP Cen |
| 368 | 7.1.1.2 | **FM 1 & FM 2** |  | 3d | 2003-09-26 | 2003-09-30 |  |  |  | 2003-09-26 | 2003-09-30 | 3d | 32d |  |  | STEREO | IMPACT | SEP Package | SSD Bias Card | SEP DPU | LVPS | CIT |  |
| 369 | 7.1.1.2.1 | Procure Solid State Detector flight Printed Circuit Boards |  | 3d | 2003-09-26 | 2003-09-30 | 389 |  |  | 2003-09-26 | 2003-09-30 | 3d | 32d | 0d |  | STEREO | IMPACT | SEP Package | SSD Bias Card | SEP DPU | LVPS | CIT | SEP Cen |
| 370 | 7.1.2 | **Design** |  | 556d | 2001-11-06 A | 2004-01-27 |  | 82% | 102.21d | 2001-11-06 | 2004-01-27 | 556d | 113d |  |  | STEREO | IMPACT | SEP Package | SSD Bias Card | SEP DPU | LVPS | CIT |  |
| 371 | 7.1.2.1 | **ETU** |  | 447d | 2001-11-06 A | 2003-08-18 A |  | 100% |  | 2001-11-06 | 2003-08-18 | 447d |  |  |  | STEREO | IMPACT | SEP Package | SSD Bias Card | SEP DPU | LVPS | CIT |  |
| 372 | 1.1.5 | Instrument PDR | milestone | 1d | 2001-09-11 A | 2001-09-11 A |  | 100% |  | 2001-09-11 | 2001-09-11 | 1d |  |  | start no earlier than 2001-09-11 | STEREO | IMPACT | SEP Package |  |  |  |  |  |
| 373 | 7.1.2.1.2 | Collect & verify SEP Solid State Detector bias requirements |  | 2d | 2001-11-06 A | 2001-11-07 A | 372FS+39d | 100% |  | 2001-11-06 | 2001-11-07 | 2d |  |  |  | STEREO | IMPACT | SEP Package | SSD Bias Card | SEP DPU | LVPS | CIT | SEP Cen |
| 374 | 7.1.2.1.3 | Prepare design spec & communicateSolid State Detector Bias Supply to SI |  | 22.5d | 2002-04-24 A | 2002-06-28 A | 373FS+113d | 100% |  | 2002-04-24 | 2002-06-28 | 22.5d |  |  |  | STEREO | IMPACT | SEP Package | SSD Bias Card | SEP DPU | LVPS | CIT | SEP Cen |
| 375 | 7.1.2.1.4 | Assess Solid State Detector Bias Supply EM & flight parts needs & availability |  | 25d | 2002-04-26 A | 2002-12-13 A | 374 | 100% |  | 2002-04-26 | 2002-12-13 | 25d |  |  |  | STEREO | IMPACT | SEP Package | SSD Bias Card | SEP DPU | LVPS | CIT | SEP Cen |
| 376 | 7.1.2.1.5 | Obtain Solid State Detector Bias Supply samples & footprint, provide to Printed Circuit Board designer |  | 2d | 2002-06-11 A | 2002-06-12 A | 398 | 100% |  | 2002-06-11 | 2002-06-12 | 2d |  |  |  | STEREO | IMPACT | SEP Package | SSD Bias Card | SEP DPU | LVPS | CIT | SEP Cen |
| 377 | 7.1.2.1.6 | Transfer Solid State Detector Bias Supply Printed Circuit Board outline from GSGC to SI |  | 1d | 2002-06-11 A | 2002-06-11 A | 365FS-1d | 100% |  | 2002-06-11 | 2002-06-11 | 1d |  |  |  | STEREO | IMPACT | SEP Package | SSD Bias Card | SEP DPU | LVPS | CIT | SEP Cen |
| 378 | 7.1.2.1.7 | Design Solid State Detector Bias Supply EM schematics |  | 15d | 2002-05-10 A | 2002-05-31 A | 377 | 100% |  | 2002-05-10 | 2002-05-31 | 15d |  |  |  | STEREO | IMPACT | SEP Package | SSD Bias Card | SEP DPU | LVPS | CIT | SEP Cen |
| 379 | 7.1.2.1.8 | Verify Solid State Detector Bias Supply design spec implementation - 1 |  | 3.5d | 2002-08-01 A | 2002-12-03 A | 378 | 100% |  | 2002-08-01 | 2002-12-03 | 3.5d |  |  | start no earlier than 2002-07-31 | STEREO | IMPACT | SEP Package | SSD Bias Card | SEP DPU | LVPS | CIT | SEP Cen |
| 380 | 7.1.2.1.9 | Solid State Detector Bias Supply FMA/design review/risk assessment |  | 20d | 2002-12-04 A | 2003-01-02 A | 379 | 100% |  | 2002-12-04 | 2003-01-02 | 20d |  |  | start no earlier than 2002-11-30 | STEREO | IMPACT | SEP Package | SSD Bias Card | SEP DPU | LVPS | CIT | SEP Cen |
| 381 | 7.1.2.1.10 | Provide feedback on Solid State Detector Bias Supply design review to SI designer |  | 1d | 2003-01-03 A | 2003-01-03 A | 380 | 100% |  | 2003-01-03 | 2003-01-03 | 1d |  |  | start no earlier than 2002-11-30 | STEREO | IMPACT | SEP Package | SSD Bias Card | SEP DPU | LVPS | CIT | SEP Cen |
| 382 | 7.1.2.1.11 | Design Solid State Detector Bias Supply EM Printed Circuit Board layout (final) |  | 15d | 2003-01-21 A | 2003-03-13 A | 381 | 100% |  | 2003-01-21 | 2003-03-13 | 15d |  |  | finish no earlier than 2003-03-13 | STEREO | IMPACT | SEP Package | SSD Bias Card | SEP DPU | LVPS | CIT | SEP Cen |
| 383 | 7.1.2.1.12 | Review & approve Solid State Detector Bias Supply EM Printed Circuit Board layout |  | 2d | 2003-03-14 A | 2003-03-17 A | 382 | 100% |  | 2003-03-14 | 2003-03-17 | 2d |  |  | start no earlier than 2002-11-30 | STEREO | IMPACT | SEP Package | SSD Bias Card | SEP DPU | LVPS | CIT | SEP Cen |
| 384 | 7.1.2.1.13 | Doc Solid State Detector Bias Supply EM board rework (traveler, ECR) |  | 2d | 2003-08-15 A | 2003-08-18 A | 410 | 100% |  | 2003-08-15 | 2003-08-18 | 2d |  |  |  | STEREO | IMPACT | SEP Package | SSD Bias Card | SEP DPU | LVPS | CIT | SEP Cen |

Notes:
- 366: Change logic so that we can take 55% credit. Really money related.
- 375: Assummed this completed on time for rebaselining purposes.

| ID | WBS | Task | Duration | Start | Finish | Predecessors | Complete | Remaining | Baseline start | Baseline finish | Baseline duration | Total slack | Free slack | Constraint | Text11 | Text12 | Text13 | Text15 | Text16 | Text17 | Text28 | Text14 | Text23 |
| --- | --- | --- | --- | --- | --- | --- | --- | --- | --- | --- | --- | --- | --- | --- | --- | --- | --- | --- | --- | --- | --- | --- | --- |
| 385 | 7.1.2.2 | **FM 1 & FM 2** | 100d | 2003-09-02 | 2004-01-27 |  |  |  | 2003-09-02 | 2004-01-27 | 100d | 32d |  |  | STEREO | IMPACT | SEP Package | SSD Bias Card | SEP DPU | LVPS | CIT |  |  |
| 386 | 7.1.2.2.1 | Design flight Solid State Detector Bias Supply schematics (final) | 4d | 2003-09-02 | 2003-09-05 |  |  |  | 2003-09-02 | 2003-09-05 | 4d | 32d | 0d | start no earlier than 2003-09-02 | STEREO | IMPACT | SEP Package | SSD Bias Card | SEP DPU | LVPS | CIT | SEP Cen |  |
| 387 | 7.1.2.2.2 | Final Solid State Detector Bias Supply design review | 2d | 2003-09-08 | 2003-09-09 | 386 |  |  | 2003-09-08 | 2003-09-09 | 2d | 32d | 0d |  | STEREO | IMPACT | SEP Package | SSD Bias Card | SEP DPU | LVPS | CIT | SEP Cen |  |
| 388 | 7.1.2.2.3 | Layout Solid State Detector Bias Supply Printed Circuit Board (final) | 5d | 2003-09-17 | 2003-09-23 | 387FS+5d |  |  | 2003-09-17 | 2003-09-23 | 5d | 32d | 0d |  | STEREO | IMPACT | SEP Package | SSD Bias Card | SEP DPU | LVPS | CIT | SEP Cen |  |
| 389 | 7.1.2.2.4 | Review & approve Solid State Detector Bias Supply flight Printed Circuit Board layout | 2d | 2003-09-24 | 2003-09-25 | 388 |  |  | 2003-09-24 | 2003-09-25 | 2d | 32d | 0d |  | STEREO | IMPACT | SEP Package | SSD Bias Card | SEP DPU | LVPS | CIT | SEP Cen |  |
| 390 | 7.1.2.2.5 | Provide Feedback on FM 1 Test Results to SI Designer | 1d | 2004-01-02 | 2004-01-02 | 433 |  |  | 2004-01-02 | 2004-01-02 | 1d | 118d | 0d |  | STEREO | IMPACT | SEP Package |  |  |  |  |  |  |
| 391 | 7.1.2.2.6 | Doc Solid State Detector Bias Supply flight board 1 rework (traveler, ECR) | 1d | 2004-01-07 | 2004-01-07 | 414 |  |  | 2004-01-07 | 2004-01-07 | 1d | 118d | 0d |  | STEREO | IMPACT | SEP Package | SSD Bias Card | SEP DPU | LVPS | CIT | SEP Cen |  |
| 392 | 7.1.2.2.7 | Final Solid State Detector Bias Supply FM 1 update of Printed Circuit Board schematics & layout | 4d | 2004-01-15 | 2004-01-20 | 391FS+4d |  |  | 2004-01-15 | 2004-01-20 | 4d | 118d |  |  | STEREO | IMPACT | SEP Package | SSD Bias Card | SEP DPU | LVPS | CIT | SEP Cen |  |
| 393 | 7.1.2.2.8 | Provide Feedback on FM 2 Test Results to SI Designer | 1d | 2004-01-09 | 2004-01-09 | 444 |  |  | 2004-01-09 | 2004-01-09 | 1d | 113d | 0d |  | STEREO | IMPACT | SEP Package |  |  |  |  |  |  |
| 394 | 7.1.2.2.9 | Doc Solid State Detector Bias Supply flight board 2 rework (traveler, ECR) | 1d | 2004-01-15 | 2004-01-15 | 418 |  |  | 2004-01-15 | 2004-01-15 | 1d | 113d | 0d |  | STEREO | IMPACT | SEP Package | SSD Bias Card | SEP DPU | LVPS | CIT | SEP Cen |  |
| 395 | 7.1.2.2.10 | Final Solid State Detector Bias Supply FM 2 update of Printed Circuit Board schematics & layout | 4d | 2004-01-22 | 2004-01-27 | 394FS+4d |  |  | 2004-01-22 | 2004-01-27 | 4d | 113d |  |  | STEREO | IMPACT | SEP Package | SSD Bias Card | SEP DPU | LVPS | CIT | SEP Cen |  |
| 396 | 7.1.3 | **Fabrication** | 149d | 2003-04-02 A | 2003-10-31 |  | 48% | 78.05d | 2003-04-02 | 2003-10-31 | 149d | 40d |  |  | STEREO | IMPACT | SEP Package | SSD Bias Card | SEP DPU | LVPS | CIT |  |  |
| 397 | 7.1.3.1 | **ETU** | 19d | 2003-04-02 A | 2003-04-28 A |  | 100% |  | 2003-04-02 | 2003-04-28 | 19d |  |  |  | STEREO | IMPACT | SEP Package | SSD Bias Card | SEP DPU | LVPS | CIT |  |  |
| 398 | 7.1.3.1.1 | Receive/inspect/database Solid State Detector Bias Supply EM parts | 4d | 2003-04-23 A | 2003-04-28 A | 365FS+2d | 100% |  | 2003-04-23 | 2003-04-28 | 4d |  |  | start no earlier than 2003-03-31 | STEREO | IMPACT | SEP Package | SSD Bias Card | SEP DPU | LVPS | CIT | SEP Cen |  |
| 399 | 7.1.3.1.2 | Inspect Solid State Detector Bias Supply EM Printed Circuit Board | 1d | 2003-04-02 A | 2003-04-02 A | 367FS+10d | 100% |  | 2003-04-02 | 2003-04-02 | 1d |  |  |  | STEREO | IMPACT | SEP Package | SSD Bias Card | SEP DPU | LVPS | CIT | SEP Cen | EM Solid State Detector Bias Supply Board Fabricated |
| 400 | 7.1.3.1.3 | Fabricate dummy load box for Solid State Detector Bias Supply EM board test | 5d | 2003-04-03 A | 2003-04-09 A | 421 | 100% |  | 2003-04-03 | 2003-04-09 | 5d |  |  | start no earlier than 2003-03-31 | STEREO | IMPACT | SEP Package | SSD Bias Card | SEP DPU | LVPS | CIT | SEP Cen |  |
| 401 | 7.1.3.2 | **FM 1 & FM 2** | 25d | 2003-09-26 | 2003-10-31 |  |  |  | 2003-09-26 | 2003-10-31 | 25d | 40d |  |  | STEREO | IMPACT | SEP Package | SSD Bias Card | SEP DPU | LVPS | CIT |  |  |
| 402 | 7.1.3.2.1 | Inspect Solid State Detector Bias Supply flight Printed Circuit Boards (coupon & elec. cont.) | 4d | 2003-10-28 | 2003-10-31 | 369FS+18d |  |  | 2003-10-28 | 2003-10-31 | 4d | 32d | 0d |  | STEREO | IMPACT | SEP Package | SSD Bias Card | SEP DPU | LVPS | CIT | SEP Cen | Flight Solid State Detector Bias Supply Boards Fabricated |
| 403 | 7.1.3.2.2 | Generate Flight Kit List in Database | 1d | 2003-09-26 | 2003-09-26 | 389 |  |  | 2003-09-26 | 2003-09-26 | 1d | 58d | 0d |  | STEREO | IMPACT | SEP Package |  |  |  |  |  |  |
| 404 | 7.1.3.2.3 | Bend Leads on Flight IC's | 2d | 2003-09-29 | 2003-09-30 | 403 |  |  | 2003-09-29 | 2003-09-30 | 2d | 58d | 0d |  | STEREO | IMPACT | SEP Package |  |  |  |  |  |  |
| 405 | 7.1.3.2.4 | Generate Flight Kit Book | 2d | 2003-10-01 | 2003-10-02 | 404 |  |  | 2003-10-01 | 2003-10-02 | 2d | 58d | 0d |  | STEREO | IMPACT | SEP Package |  |  |  |  |  |  |
| 406 | 7.1.3.2.5 | Kit Flight Parts (2 Boards) | 2d | 2003-10-03 | 2003-10-07 | 405 |  |  | 2003-10-03 | 2003-10-07 | 2d | 58d | 26d |  | STEREO | IMPACT | SEP Package |  |  |  |  |  |  |
| 407 | 7.1.4 | **Assembly** | 196d | 2003-04-03 A | 2004-01-14 |  | 35% | 127.14d | 2003-04-03 | 2004-01-14 | 196d | 113d |  |  | STEREO | IMPACT | SEP Package | SSD Bias Card | SEP DPU | LVPS | CIT |  |  |
| 408 | 7.1.4.1 | **ETU** | 94d | 2003-04-03 A | 2003-08-14 A |  | 100% |  | 2003-04-03 | 2003-08-14 | 94d |  |  |  | STEREO | IMPACT | SEP Package | SSD Bias Card | SEP DPU | LVPS | CIT |  |  |
| 409 | 7.1.4.1.1 | Assemble Solid State Detector Bias Supply EM Printed Circuit Board | 10d | 2003-04-03 A | 2003-06-04 A | 399 | 100% |  | 2003-04-03 | 2003-06-04 | 10d |  |  |  | STEREO | IMPACT | SEP Package | SSD Bias Card | SEP DPU | LVPS | CIT | SEP Cen |  |
| 410 | 7.1.4.1.2 | Rework/haywire/trim Solid State Detector Bias Supply EM board | 3d | 2003-08-12 A | 2003-08-14 A | 426 | 100% |  | 2003-08-12 | 2003-08-14 | 3d |  |  |  | STEREO | IMPACT | SEP Package | SSD Bias Card | SEP DPU | LVPS | CIT | SEP Cen |  |

| ID | WBS | Task | Duration | Start | Finish | Predecessors | Complete | Remaining | Baseline start | Baseline finish | Baseline duration | Total slack | Free slack | Constraint | Text11 | Text12 | Text13 | Text15 | Text16 | Text17 | Text28 | Text14 | Text23 |
| --- | --- | --- | --- | --- | --- | --- | --- | --- | --- | --- | --- | --- | --- | --- | --- | --- | --- | --- | --- | --- | --- | --- | --- |
| 411 | 7.1.4.2 | **FM 1** | 35d | 2003-11-14 | 2004-01-06 |  |  |  | 2003-11-14 | 2004-01-06 | 35d | 32d |  |  | STEREO | IMPACT | SEP Package | SSD Bias Card | SEP DPU | LVPS | CIT |  |  |
| 412 | 7.1.4.2.1 | Assemble flight Solid State Detector Bias Supply Printed Circuit Board 1 | 10d | 2003-11-14 | 2003-11-28 | 402FS+8d, 406 |  |  | 2003-11-14 | 2003-11-28 | 10d | 32d | 0d |  | STEREO | IMPACT | SEP Package | SSD Bias Card | SEP DPU | LVPS | CIT | SEP Cen | Flight Solid State Detector Bias Supply Boards Tested |
| 413 | 7.1.4.2.2 | Rework/haywire/trim Solid State Detector Bias Supply flight board 1 | 1d | 2004-01-05 | 2004-01-05 | 390 |  |  | 2004-01-05 | 2004-01-05 | 1d | 118d | 0d |  | STEREO | IMPACT | SEP Package | SSD Bias Card | SEP DPU | LVPS | CIT | SEP Cen |  |
| 414 | 7.1.4.2.3 | Post rework QA inspection of Solid State Detector Bias Supply board 1 | 1d | 2004-01-06 | 2004-01-06 | 413 |  |  | 2004-01-06 | 2004-01-06 | 1d | 118d | 0d |  | STEREO | IMPACT | SEP Package | SSD Bias Card | SEP DPU | LVPS | CIT | SEP Cen |  |
| 415 | 7.1.4.3 | **FM 2** | 30d | 2003-12-01 | 2004-01-14 |  |  |  | 2003-12-01 | 2004-01-14 | 30d | 113d |  |  | STEREO | IMPACT | SEP Package | SSD Bias Card | SEP DPU | LVPS | CIT |  |  |
| 416 | 7.1.4.3.1 | Assemble flight Solid State Detector Bias Supply Printed Circuit Board 2 | 10d | 2003-12-01 | 2003-12-12 | 412 |  |  | 2003-12-01 | 2003-12-12 | 10d | 113d | 0d |  | STEREO | IMPACT | SEP Package | SSD Bias Card | SEP DPU | LVPS | CIT | SEP Cen | Flight Solid State Detector Bias Supply Boards Tested |
| 417 | 7.1.4.3.2 | Rework/haywire/trim Solid State Detector Bias Supply flight board 2 | 1d | 2004-01-13 | 2004-01-13 | 393 |  |  | 2004-01-13 | 2004-01-13 | 1d | 113d | 0d |  | STEREO | IMPACT | SEP Package | SSD Bias Card | SEP DPU | LVPS | CIT | SEP Cen |  |
| 418 | 7.1.4.3.3 | Post rework QA inspection of Solid State Detector Bias Supply board 2 | 1d | 2004-01-14 | 2004-01-14 | 417 |  |  | 2004-01-14 | 2004-01-14 | 1d | 113d | 0d |  | STEREO | IMPACT | SEP Package | SSD Bias Card | SEP DPU | LVPS | CIT | SEP Cen |  |
| 419 | 7.1.5 | **Test** | 204d | 2003-04-01 A | 2004-01-22 |  | 40% | 122.4d | 2003-04-01 | 2004-01-22 | 204d | 116d |  |  | STEREO | IMPACT | SEP Package | SSD Bias Card | SEP DPU | LVPS | CIT |  |  |
| 420 | 7.1.5.1 | **ETU** | 93d | 2003-04-01 A | 2003-08-11 A |  | 100% |  | 2003-04-01 | 2003-08-11 | 93d |  |  |  | STEREO | IMPACT | SEP Package | SSD Bias Card | SEP DPU | LVPS | CIT |  |  |
| 421 | 7.1.5.1.1 | Prepare test spec for Solid State Detector Bias Supply EM board | 2d | 2003-04-01 A | 2003-04-02 A | 367 | 100% |  | 2003-04-01 | 2003-04-02 | 2d |  |  | start no earlier than 2003-03-31 | STEREO | IMPACT | SEP Package | SSD Bias Card | SEP DPU | LVPS | CIT | SEP Cen |  |
| 422 | 7.1.5.1.2 | Test Solid State Detector Bias Supply EM board | 27d | 2003-04-17 A | 2003-07-02 A | 400, 409 | 100% |  | 2003-04-17 | 2003-07-02 | 27d |  |  |  | STEREO | IMPACT | SEP Package | SSD Bias Card | SEP DPU | LVPS | CIT | SEP Cen |  |
| 423 | 7.1.5.1.3 | Receive/inspect/doc Solid State Detector Bias Supply EM board | 2d | 2003-07-02 A | 2003-07-07 A | 422 | 100% |  | 2003-07-02 | 2003-07-07 | 2d |  |  | start no earlier than 2003-06-30 | STEREO | IMPACT | SEP Package | SSD Bias Card | SEP DPU | LVPS | CIT | SEP Cen | EM Solid State Detector Bias Supply Board Tested |
| 424 | 7.1.5.1.4 | Integrate & test Solid State Detector Bias Supply EM board with SEP Bds Available | 2d | 2003-08-01 A | 2003-08-04 A | 423 | 100% |  | 2003-08-01 | 2003-08-04 | 2d |  |  | start no earlier than 2003-08-01 | STEREO | IMPACT | SEP Package | SSD Bias Card | SEP DPU | LVPS | CIT | SEP Cen |  |
| 425 | 7.1.5.1.5 | Doc Solid State Detector Bias Supply EM board test results | 3d | 2003-08-05 A | 2003-08-07 A | 424 | 100% |  | 2003-08-05 | 2003-08-07 | 3d |  |  |  | STEREO | IMPACT | SEP Package | SSD Bias Card | SEP DPU | LVPS | CIT | SEP Cen |  |
| 426 | 7.1.5.1.6 | Provide feedback on Solid State Detector Bias Supply test results to SI designer | 2d | 2003-08-08 A | 2003-08-11 A | 425 | 100% |  | 2003-08-08 | 2003-08-11 | 2d |  |  |  | STEREO | IMPACT | SEP Package | SSD Bias Card | SEP DPU | LVPS | CIT | SEP Cen |  |
| 427 | 7.1.5.2 | **FM 1 & FM 2** | 36d | 2003-12-01 | 2004-01-22 |  |  |  | 2003-12-01 | 2004-01-22 | 36d | 32d |  |  | STEREO | IMPACT | SEP Package | SSD Bias Card | SEP DPU | LVPS | CIT |  |  |
| 428 | 7.1.5.2.1 | Prepare test spec for Solid State Detector Bias Supply flight boards | 1d | 2003-12-01 | 2003-12-01 | 412 |  |  | 2003-12-01 | 2003-12-01 | 1d | 32d | 0d |  | STEREO | IMPACT | SEP Package | SSD Bias Card | SEP DPU | LVPS | CIT | SEP Cen |  |
| 429 | 7.1.5.2.2 | **FM 1** | 31d | 2003-12-02 | 2004-01-16 |  |  |  | 2003-12-02 | 2004-01-16 | 31d | 32d |  |  | STEREO | IMPACT | SEP Package |  |  |  |  |  |  |
| 430 | 7.1.5.2.2.1 | Test Flight Board 1 Pre-Delivery | 5d | 2003-12-02 | 2003-12-08 | 428 |  |  | 2003-12-02 | 2003-12-08 | 5d | 32d | 0d |  | STEREO | IMPACT | SEP Package | SSD Bias Card | SEP DPU | LVPS | CIT | SEP Cen |  |
| 431 | 7.1.5.2.2.2 | Receive/QA inspect/document Solid State Detector Bias Supply flight board 1 | 2d | 2003-12-09 | 2003-12-10 | 430 |  |  | 2003-12-09 | 2003-12-10 | 2d | 32d | 0d |  | STEREO | IMPACT | SEP Package | SSD Bias Card | SEP DPU | LVPS | CIT | SEP Cen |  |
| 432 | 7.1.5.2.2.3 | Test Flight Board 1 Post Delivery | 3d | 2003-12-11 | 2003-12-15 | 431 |  |  | 2003-12-11 | 2003-12-15 | 3d | 32d | 0d |  | STEREO | IMPACT | SEP Package | SSD Bias Card | SEP DPU | LVPS | CIT | SEP Cen |  |
| 433 | 7.1.5.2.2.4 | Doc Solid State Detector Bias Supply flight board 1 test results | 3d | 2003-12-29 | 2003-12-31 | 432 |  |  | 2003-12-29 | 2003-12-31 | 3d | 118d | 0d | start no earlier than 2003-12-29 | STEREO | IMPACT | SEP Package | SSD Bias Card | SEP DPU | LVPS | CIT | SEP Cen |  |
| 434 | 7.1.5.2.2.5 | Stake/conformal coat Solid State Detector Bias Supply flight board 1 | 1d | 2004-01-08 | 2004-01-08 | 391 |  |  | 2004-01-08 | 2004-01-08 | 1d | 120d | 0d |  | STEREO | IMPACT | SEP Package | SSD Bias Card | SEP DPU | LVPS | CIT | SEP Cen |  |
| 435 | 7.1.5.2.2.6 | Bakeout Solid State Detector Bias Supply flight board 1 | 1d | 2004-01-09 | 2004-01-09 | 434 |  |  | 2004-01-09 | 2004-01-09 | 1d | 120d | 0d |  | STEREO | IMPACT | SEP Package | SSD Bias Card | SEP DPU | LVPS | CIT | SEP Cen |  |
| 436 | 7.1.5.2.2.7 | Post-conf coat QA inspection of Solid State Detector Bias Supply board 1 | 1d | 2004-01-13 | 2004-01-13 | 435 |  |  | 2004-01-13 | 2004-01-13 | 1d | 120d | 0d |  | STEREO | IMPACT | SEP Package | SSD Bias Card | SEP DPU | LVPS | CIT | SEP Cen |  |
| 437 | 7.1.5.2.2.8 | Test Solid State Detector Bias Supply flight board 1 (final) | 2d | 2004-01-14 | 2004-01-15 | 436 |  |  | 2004-01-14 | 2004-01-15 | 2d | 120d | 0d |  | STEREO | IMPACT | SEP Package | SSD Bias Card | SEP DPU | LVPS | CIT | SEP Cen | Flight Solid State Detector Bias Supply Boards Tested |
| 438 | 7.1.5.2.2.9 | Solid State Detector Bias Supply FM 1 Mass properties/photo | 1d | 2004-01-16 | 2004-01-16 | 437 |  |  | 2004-01-16 | 2004-01-16 | 1d | 120d | 0d |  | STEREO | IMPACT | SEP Package | SSD Bias Card | SEP DPU | LVPS | CIT | SEP Cen |  |
| 439 | 7.1.5.2.2.10 | Maintain Solid State Detector Bias Supply FM 1 hard copy docs (sch, parts, material list) | 9d | 2004-01-05 | 2004-01-16 | 438FF |  |  | 2004-01-05 | 2004-01-16 | 9d | 120d |  |  | STEREO | IMPACT | SEP Package | SSD Bias Card | SEP DPU | LVPS | CIT | SEP Cen |  |

| ID | WBS | Task | Type | Duration | Start | Finish | Predecessors | Complete | Remaining | Baseline start | Baseline finish | Baseline duration | Total slack | Free slack | Constraint | Text11 | Text12 | Text13 | Text14 | Text15 | Text16 | Text17 | Text28 | Text23 |
| --- | --- | --- | --- | --- | --- | --- | --- | --- | --- | --- | --- | --- | --- | --- | --- | --- | --- | --- | --- | --- | --- | --- | --- | --- |
| 440 | 7.1.5.2.3 | **FM 2** |  | 26d | 2003-12-15 | 2004-01-22 |  |  |  | 2003-12-15 | 2004-01-22 | 26d | 113d |  |  | STEREO | IMPACT | SEP Package |  |  |  |  |  |  |
| 441 | 7.1.5.2.3.1 | Test Flight Board 2 Pre-Delivery |  | 5d | 2003-12-15 | 2003-12-19 | 416 |  |  | 2003-12-15 | 2003-12-19 | 5d | 113d | 0d |  | STEREO | IMPACT | SEP Package | SEP Cen | SSD Bias Card | SEP DPU | LVPS | CIT |  |
| 442 | 7.1.5.2.3.2 | Receive/QA inspect/document Solid State Detector Bias Supply flight board 2 |  | 3d | 2003-12-29 | 2003-12-31 | 441FS+4d |  |  | 2003-12-29 | 2003-12-31 | 3d | 113d | 0d |  | STEREO | IMPACT | SEP Package | SEP Cen | SSD Bias Card | SEP DPU | LVPS | CIT |  |
| 443 | 7.1.5.2.3.3 | Test Flight Board 2 Post Delivery |  | 2d | 2004-01-02 | 2004-01-05 | 442 |  |  | 2004-01-02 | 2004-01-05 | 2d | 113d | 0d |  | STEREO | IMPACT | SEP Package | SEP Cen | SSD Bias Card | SEP DPU | LVPS | CIT |  |
| 444 | 7.1.5.2.3.4 | Doc Solid State Detector Bias Supply flight board 2 test results |  | 3d | 2004-01-06 | 2004-01-08 | 443 |  |  | 2004-01-06 | 2004-01-08 | 3d | 113d | 0d |  | STEREO | IMPACT | SEP Package | SEP Cen | SSD Bias Card | SEP DPU | LVPS | CIT |  |
| 445 | 7.1.5.2.3.5 | Stake/conformal coat Solid State Detector Bias Supply flight board 2 |  | 1d | 2004-01-15 | 2004-01-15 | 418 |  |  | 2004-01-15 | 2004-01-15 | 1d | 116d | 0d |  | STEREO | IMPACT | SEP Package | SEP Cen | SSD Bias Card | SEP DPU | LVPS | CIT |  |
| 446 | 7.1.5.2.3.6 | Bakeout Solid State Detector Bias Supply flight board 2 |  | 1d | 2004-01-16 | 2004-01-16 | 445 |  |  | 2004-01-16 | 2004-01-16 | 1d | 116d | 0d |  | STEREO | IMPACT | SEP Package | SEP Cen | SSD Bias Card | SEP DPU | LVPS | CIT |  |
| 447 | 7.1.5.2.3.7 | Post-conf coat QA inspection of Solid State Detector Bias Supply board 2 |  | 1d | 2004-01-19 | 2004-01-19 | 446 |  |  | 2004-01-19 | 2004-01-19 | 1d | 116d | 0d |  | STEREO | IMPACT | SEP Package | SEP Cen | SSD Bias Card | SEP DPU | LVPS | CIT |  |
| 448 | 7.1.5.2.3.8 | Test Solid State Detector Bias Supply flight board 2 (final) |  | 2d | 2004-01-20 | 2004-01-21 | 447 |  |  | 2004-01-20 | 2004-01-21 | 2d | 116d | 0d |  | STEREO | IMPACT | SEP Package | SEP Cen | SSD Bias Card | SEP DPU | LVPS | CIT | Flight Solid State Detector Bias Supply Boards Tested |
| 449 | 7.1.5.2.3.9 | Solid State Detector Bias Supply FM 2 Mass properties/photo |  | 1d | 2004-01-22 | 2004-01-22 | 448 |  |  | 2004-01-22 | 2004-01-22 | 1d | 116d | 0d |  | STEREO | IMPACT | SEP Package | SEP Cen | SSD Bias Card | SEP DPU | LVPS | CIT |  |
| 450 | 7.1.5.2.3.10 | Maintain Solid State Detector Bias Supply FM 2 hard copy docs (sch, parts, material list) |  | 9d | 2004-01-09 | 2004-01-22 | 449FF |  |  | 2004-01-09 | 2004-01-22 | 9d | 116d |  |  | STEREO | IMPACT | SEP Package | SEP Cen | SSD Bias Card | SEP DPU | LVPS | CIT |  |
| 451 | 8 | **Harness** |  | 1d | 2003-12-01 | 2003-12-01 |  |  |  | 2003-12-01 | 2003-12-01 | 1d | 151d |  |  | STEREO | IMPACT | SEP Package |  |  |  |  | CIT |  |
| 452 | 8.1 | **Procurements** |  | 1d | 2003-12-01 | 2003-12-01 |  |  |  | 2003-12-01 | 2003-12-01 | 1d | 151d |  |  | STEREO | IMPACT | SEP Package |  |  |  |  | CIT |  |
| 453 | 8.1.1 | **FM 1 & FM 2** |  | 1d | 2003-12-01 | 2003-12-01 |  |  |  | 2003-12-01 | 2003-12-01 | 1d | 151d |  |  | STEREO | IMPACT | SEP Package |  |  |  |  | CIT |  |
| 454 | 8.1.1.1 | Procure Flight Harnesses |  | 1d | 2003-12-01 | 2003-12-01 |  |  |  | 2003-12-01 | 2003-12-01 | 1d | 151d |  | start no earlier than 2003-12-01 | STEREO | IMPACT | SEP Package | SEP Cen |  |  |  | CIT |  |
| 455 | 9 | **Flight Software** |  | 459d? | 2002-09-03 A | 2004-06-30 |  | 73% | 123.76d? | 2002-09-03 | 2004-06-30 | 459d? | 0d |  |  | STEREO | IMPACT | SEP Package |  | Flt S/W | SEP DPU |  | CIT |  |
| 456 | 9.1 | **Design, Manufacture, Assembly and Test** |  | 459d? | 2002-09-03 A | 2004-06-30 |  | 69% | 141.09d? | 2002-09-03 | 2004-06-30 | 459d? | 0d |  |  | STEREO | IMPACT | SEP Package |  | Flt S/W | SEP DPU |  | CIT |  |
| 457 | 9.1.1 | **Assembly** |  | 332d | 2002-09-03 A | 2003-12-30 |  | 69% | 102.05d | 2002-09-03 | 2003-12-30 | 332d | 61d |  |  | STEREO | IMPACT | SEP Package |  | Flt S/W | SEP DPU |  | CIT |  |
| 458 | 9.1.1.1 | SEP Central Build 1 |  | 112d | 2002-09-03 A | 2003-04-08 A | 82SS | 100% |  | 2002-09-03 | 2003-04-08 | 112d |  |  |  | STEREO | IMPACT | SEP Package | SEP Cen |  |  |  |  | B1 Flight Software Available |
| 459 | 9.1.1.2 | SEP Central Build 2 |  | 45d | 2003-05-01 A | 2003-07-03 A | 458 | 100% |  | 2003-05-01 | 2003-07-03 | 45d |  |  | start no earlier than 2003-04-30 | STEREO | IMPACT | SEP Package | SEP Cen | Flt S/W | SEP DPU |  | CIT | B2 Flight Software Available |
| 460 | 9.1.1.3 | SEP Central Build 3 |  | 79d | 2003-08-01 A | 2003-11-24 | 459 | 27% | 58d | 2003-08-01 | 2003-11-24 | 79d | 64d | 0d | start no earlier than 2003-08-01 | STEREO | IMPACT | SEP Package | SEP Cen | Flt S/W | SEP DPU |  | CIT |  |
| 461 | 9.1.1.4 | Final Flight S/W Build |  | 21d | 2003-12-01 | 2003-12-30 | 460, 80, 28 |  |  | 2003-12-01 | 2003-12-30 | 21d | 61d | 60d | start no earlier than 2003-12-01 | STEREO | IMPACT | SEP Package | SEP Cen | Flt S/W | SEP DPU |  | CIT | Final Flight Software Available |
| 462 | 2.3.14 | SEP system test FM 1 |  | 10d | 2004-03-29 | 2004-04-09 | 461 |  |  | 2004-03-29 | 2004-04-09 | 10d | 1d | 0d |  | STEREO | IMPACT | SEP Package |  |  |  |  |  |  |
| 463 | 9.1.2 | **Test** |  | 0d? | 2004-06-30 A | 2004-06-30 A |  | 100% |  | 2004-06-30 | 2004-06-30 | 0d? |  |  |  | STEREO | IMPACT | SEP Package |  | Flt S/W | SEP DPU |  | CIT |  |
| 464 | 9.1.2.1 | (OBSOLETE) SEP Central/HET & SIT I/F Test | milestone | 0d? | 2004-06-30 A | 2004-06-30 A | 13, 16 | 100% |  | 2004-06-30 | 2004-06-30 | 0d? |  |  | finish no later than 2003-07-31 | STEREO | IMPACT | SEP Package | SEP Cen | Flt S/W | SEP DPU |  | CIT |  |

Notes:
- 464: Ths activity occurs in conjunction with a SEP Meeting, But where is it. May need some deliver/receive points here. / 2/5/03-Sent e-mail to Alan Cummings, this may disappear may mod MISC test board to SEP Cen EM board so that this testing can occur anytime. For the time being moved date to 4/30. / 2/6/03-Got no response from Al but Kristin said she thought the test was moved to May so, I'll make that change for now / March 03 Status Upd: CIT to produce 2nd SepCen EM Logic Board for GSFC/UMD.

| ID | WBS | Task | Duration | Start | Finish | Complete | Baseline start | Baseline finish | Baseline duration | Constraint | Text11 | Text12 | Text13 |
| --- | --- | --- | --- | --- | --- | --- | --- | --- | --- | --- | --- | --- | --- |
| 465 | 9.2 | **GSE** | 92d | 2003-02-03 A | 2003-06-12 A | 100% | 2003-02-03 | 2003-06-12 | 92d |  | STEREO | IMPACT | SEP Package |
| 466 | 9.2.1 | **Simulator** | 92d | 2003-02-03 A | 2003-06-12 A | 100% | 2003-02-03 | 2003-06-12 | 92d |  | STEREO | IMPACT | SEP Package |
| 467 | 9.2.1.1 | Design & Fabricate SEP Instrument Simulator Unit | 36d | 2003-02-03 A | 2003-06-12 A | 100% | 2003-02-03 | 2003-06-12 | 36d | start no earlier than 2003-02-01 | STEREO | IMPACT | SEP Package |
