# SEP I & T

Schedule from MS Project, 2001-03-01 to 2005-01-25, status date 2003-08-31, A marks actual dates.
SEP Package I & T
NASA GSFC
Status Date: 08/31/2003 / Baseline Date: 01/31/2003 R1

## Calendars

- Standard w/ 10 Gov't Holidays: Mon-Fri 08:00-12:00, 13:00-17:00; Sat-Sun off. Exceptions (off unless hours are given): 2001-05-28, 2001-07-04, 2001-09-03, 2001-10-08, 2001-11-12, 2001-11-22, 2001-12-25, 2002-01-01, 2002-01-14, 2002-02-18, 2002-05-27, 2002-07-04, 2002-09-02, 2002-10-07, 2002-11-11, 2002-11-28, 2002-12-25, 2003-01-01, 2003-01-13, 2003-02-17, 2003-05-26, 2003-07-04, 2003-09-01, 2003-10-06, 2003-11-10, 2003-11-27, 2003-12-25, 2004-01-01, 2004-01-12, 2004-02-16, 2004-05-31, 2004-07-05, 2004-09-06, 2004-10-11, 2004-11-08, 2004-11-25, 2004-12-24, 2004-12-31, 2005-01-17.

## Schedule

| ID | WBS | Task | Type | Duration | Start | Finish | Predecessors | Complete | Remaining | Baseline start | Baseline finish | Baseline duration | Total slack | Free slack | Constraint | Text11 | Text12 | Text13 | Text14 | Text28 | Text20 | Text22 | Text23 |
| --- | --- | --- | --- | --- | --- | --- | --- | --- | --- | --- | --- | --- | --- | --- | --- | --- | --- | --- | --- | --- | --- | --- | --- |
| 1 | 1 | **Management** |  | 321d | 2003-04-08 A | 2004-07-16 |  | 9% | 291.82d | 2003-04-08 | 2004-07-16 | 321d | 130d |  |  | STEREO | IMPACT | SEP Package | SEP Package | CIT |  |  |  |
| 2 | 1.1 | **Contingency** |  | 20d | 2003-10-14 | 2003-11-11 |  |  |  | 2003-10-09 | 2003-11-05 | 20d | 33d |  |  | STEREO | IMPACT | SEP Package | SEP Package |  |  |  |  |
| 3 | 1.1.1 | SEP Package EM Contingency |  | 20d | 2003-10-14 | 2003-11-11 | 121, 123, 122, 125, 120 |  |  | 2003-10-09 | 2003-11-05 | 20d | 33d | 0d |  | STEREO | IMPACT | SEP Package | SEP Package |  |  |  |  |
| 4 | 1.2 | **Milestones** |  | 321d | 2003-04-08 A | 2004-07-16 |  | 99% | 0d | 2003-04-08 | 2004-07-16 | 321d | 130d |  |  | STEREO | IMPACT | SEP Package | SEP Package | CIT |  |  |  |
| 5 | 1.2.1 | SEP Package EM I & T Begins | milestone | 0d | 2003-05-08 A | 2003-05-08 A | 115SS | 100% |  | 2003-05-08 | 2003-05-08 | 0d |  |  |  | STEREO | IMPACT | SEP Package | SEP Package |  | Begin EM I & T |  |  |
| 6 | 1.2.2 | SEP Package EM I & T Complete | milestone | 0d | 2003-11-11 | 2003-11-11 | 3 |  |  | 2003-11-05 | 2003-11-05 | 0d | 33d | 7d |  | STEREO | IMPACT | SEP Package | SEP Package |  | Completed EM I & T | SEP Package - EM I & T Complete | EM I & T Complete |
| 7 | 5.1.3.1.2 | Assemble Flight PCB 1 |  | 7d | 2003-11-21 | 2003-12-02 | 6 |  |  |  |  |  | 26d | 0d |  | STEREO | IMPACT | SEP Package | SEP Package |  |  |  |  |
| 8 | 1.2.4 | SEP Package FM 1 I & T Complete | milestone | 0d | 2004-04-30 | 2004-04-30 | 154 |  |  | 2004-04-30 | 2004-04-30 | 0d | 11d | 0d | finish no later than 2004-05-17 | STEREO | IMPACT | SEP Package | SEP Package |  | FM 1 I & T | SEP Package - FM 1 I & T Complete | FM 1 I & T Complete |
| 9 | 1.2.5 | SEP Package FM 1 Enviornmental Testing Complete | milestone | 0d | 2004-06-28 | 2004-06-28 | 182 |  |  | 2004-06-28 | 2004-06-28 | 0d | 8d | 0d |  | STEREO | IMPACT | SEP Package | SEP Package |  | FM 1 Envt | SEP Package - FM 1 Enviornmental Testing Complete | FM 1 Environ. Testing Complete |
| 10 | 1.2.6 | SEP Package FM 2 I & T Complete | milestone | 0d | 2004-05-21 | 2004-05-21 | 169, 172 |  |  | 2004-05-21 | 2004-05-21 | 0d | 1d | 0d | finish no later than 2004-05-24 | STEREO | IMPACT | SEP Package | SEP Package |  | FM 2 I & T | SEP Package - FM 2 I & T Complete | FM 2 I & T Complete |
| 11 | 1.2.7 | **Receivables** |  | 298d | 2003-04-08 A | 2004-06-14 |  | 99% | 0d | 2003-04-08 | 2004-06-22 | 304d | 153d |  |  | STEREO | IMPACT | SEP Package | SEP Package | CIT |  |  |  |
| 12 | 1.1.66.5 | Deliver SEP Package FM 1 After EMC Testing | milestone | 0d | 2004-05-28 | 2004-05-28 |  |  |  | 2004-06-04 | 2004-06-04 | 0d | 158d | 0d |  | STEREO | IMPACT | SEP Package | SEP Package |  |  |  |  |
| 13 | 1.2.7.2 | Receive SEP Package FM 1 From IMPACT Suite EMC Testing | milestone | 0d | 2004-06-07 | 2004-06-07 | 12FS+5d |  |  | 2004-06-11 | 2004-06-11 | 0d | 158d |  |  | STEREO | IMPACT | SEP Package | SEP Package |  |  |  |  |
| 14 | 1.1.66.7 | Deliver SEP Package FM 2 After EMC Testing | milestone | 0d | 2004-06-07 | 2004-06-07 |  |  |  | 2004-06-15 | 2004-06-15 | 0d | 153d | 0d |  | STEREO | IMPACT | SEP Package | SEP Package |  |  |  |  |
| 15 | 1.2.7.4 | Receive SEP Package FM 2 From IMPACT Suite EMC Testing | milestone | 0d | 2004-06-14 | 2004-06-14 | 14FS+5d |  |  | 2004-06-22 | 2004-06-22 | 0d | 153d |  |  | STEREO | IMPACT | SEP Package | SEP Package |  |  |  |  |
| 16 | 1.2.7.5 | **SEP Central** |  | 243d | 2003-04-08 A | 2004-03-26 |  | 99% | 0d | 2003-04-08 | 2004-03-25 | 242d | 208d |  |  | STEREO | IMPACT | SEP Package | SEP Package |  |  |  |  |
| 17 | 1.2.7.5.1 | **EM** |  | 159d | 2003-04-08 A | 2003-11-24 |  | 99% | 0d | 2003-04-08 | 2003-11-24 | 159d | 292d |  |  | STEREO | IMPACT | SEP Package | SEP Package |  |  |  |  |
| 18 | 1.1.8.10 | Deliver SEP Central EM Logic Board (intial) for SEP EM/IDPU ETU I & T | milestone | 0d | 2003-05-31 A | 2003-05-31 A |  | 100% |  | 2003-05-31 | 2003-05-31 | 0d |  |  | start no earlier than 2003-05-31 | STEREO | IMPACT | SEP Package | SEP Package |  |  |  |  |
| 19 | 1.2.7.5.1.2 | Receive SEP Central EM Logic Board for SEP EM /IDPU I & T |  | 1d | 2003-05-08 A | 2003-05-08 A | 18 | 100% |  | 2003-05-08 | 2003-05-08 | 1d |  |  |  | STEREO | IMPACT | SEP Package | SEP Package |  |  |  |  |
| 20 | 1.1.8.11 | Deliver SEP Central EM Logic Board (final) for SEP EM I & T | milestone | 0d | 2003-06-05 A | 2003-06-05 A |  | 100% |  | 2003-06-05 | 2003-06-05 | 0d |  |  | start no earlier than 2003-05-31 | STEREO | IMPACT | SEP Package | SEP Package |  |  |  |  |
| 21 | 1.2.7.5.1.4 | Receive SEP Central EM Logic Board for SEP EM I & T |  | 1d | 2003-06-05 A | 2003-06-06 A | 20 | 100% |  | 2003-06-05 | 2003-06-06 | 1d |  |  | start no earlier than 2003-05-31 | STEREO | IMPACT | SEP Package | SEP Package |  |  |  |  |
| 22 | 1.1.8.24 | Deliver Bench Tested SEP Cental EM Analog/Post-Reg Board for SEP EM I & T | milestone | 0d | 2003-05-29 A | 2003-05-29 A |  | 100% |  | 2003-05-29 | 2003-05-29 | 0d |  |  |  | STEREO | IMPACT | SEP Package | SEP Package |  |  |  |  |
| 23 | 1.2.7.5.1.6 | Receive SEP Central EM Analog/Post-Reg Board for SEP EM I & T | milestone | 0d | 2003-05-29 A | 2003-05-29 A | 22 | 100% |  | 2003-05-29 | 2003-05-29 | 0d |  |  |  | STEREO | IMPACT | SEP Package | SEP Package |  |  |  |  |
| 24 | 1.1.8.30 | Deliver Bench Tested SEP Cental EM SSD Bias Supply for SEP EM I & T | milestone | 0d | 2003-06-25 A | 2003-07-07 A |  | 100% |  | 2003-06-25 | 2003-07-07 | 0d |  |  |  | STEREO | IMPACT | SEP Package | SEP Package |  |  |  |  |
| 25 | 1.2.7.5.1.8 | Receive SEP Central EM SSD Bias Supply for SEP EM I & T | milestone | 0d | 2003-06-25 A | 2003-07-07 | 24 | 50% | 0d | 2003-06-25 | 2003-07-07 | 0d | 96.65d | 53.65d |  | STEREO | IMPACT | SEP Package | SEP Package |  |  |  |  |
| 26 | 1.1.8.18 | Deliver Bench Tested SEP Cental ETU LVPS for SEP EM I & T | milestone | 0d | 2003-09-19 | 2003-09-19 |  |  |  | 2003-09-16 | 2003-09-16 | 0d | 43d | 0d |  | STEREO | IMPACT | SEP Package | SEP Package |  |  |  |  |
| 27 | 1.2.7.5.1.10 | Receive SEP Central EM Bench Tested LVPS for SEP EM I & T | milestone | 0d | 2003-09-19 | 2003-09-19 | 26 |  |  | 2003-09-16 | 2003-09-16 | 0d | 43d | 0d |  | STEREO | IMPACT | SEP Package | SEP Package |  |  |  |  |
| 28 | 1.1.8.35 | Deliver SEP Central Build 1 For SEP I & T | milestone | 0d | 2003-04-08 A | 2003-04-08 A |  | 100% |  | 2003-04-08 | 2003-04-08 | 0d |  |  |  | STEREO | IMPACT | SEP Package | SEP Package |  |  |  |  |
| 29 | 1.2.7.5.1.12 | Receive SEP Central S/W Build 1 for SEP I & T | milestone | 0d | 2003-04-08 A | 2003-04-08 A | 28 | 100% |  | 2003-04-08 | 2003-04-08 | 0d |  |  |  | STEREO | IMPACT | SEP Package | SEP Package |  |  |  |  |
| 30 | 1.1.8.37 | Deliver SEP Central Build 2 For SEP I & T | milestone | 0d | 2003-07-29 A | 2003-07-29 A |  | 100% |  | 2003-07-29 | 2003-07-29 | 0d |  |  |  | STEREO | IMPACT | SEP Package | SEP Package |  |  |  |  |
| 31 | 1.2.7.5.1.14 | Receive SEP Central S/W Build 2 for SEP I & T | milestone | 0d | 2003-07-29 A | 2003-07-29 A | 30 | 100% |  | 2003-07-29 | 2003-07-29 | 0d |  |  |  | STEREO | IMPACT | SEP Package | SEP Package |  |  |  |  |
| 32 | 1.1.8.39 | Deliver SEP Central Build 3 For SEP I & T | milestone | 0d | 2003-11-24 | 2003-11-24 |  |  |  | 2003-11-24 | 2003-11-24 | 0d | 155d | 0d |  | STEREO | IMPACT | SEP Package | SEP Package |  |  |  |  |
| 33 | 1.2.7.5.1.16 | Receive SEP Central S/W Build 3 for SEP I & T | milestone | 0d | 2003-11-24 | 2003-11-24 | 32 |  |  | 2003-11-24 | 2003-11-24 | 0d | 292d |  |  | STEREO | IMPACT | SEP Package | SEP Package |  |  |  |  |

| ID | WBS | Task | Type | Duration | Start | Finish | Predecessors | Complete | Remaining | Baseline start | Baseline finish | Baseline duration | Total slack | Free slack | Constraint | Text11 | Text12 | Text13 | Text14 | Text16 | Text28 |
| --- | --- | --- | --- | --- | --- | --- | --- | --- | --- | --- | --- | --- | --- | --- | --- | --- | --- | --- | --- | --- | --- |
| 34 | 1.2.7.5.2 | **FM 1** |  | 61.5d | 2003-10-30 | 2004-01-30 |  |  |  | 2003-10-30 | 2004-01-29 | 60.5d | 1d |  |  | STEREO | IMPACT | SEP Package | SEP Package |  |  |
| 35 | 1.1.8.14 | Deliver SEP Central FM 1 Logic Board to SEP FM 1 I & T | milestone | 0d | 2003-11-07 | 2003-11-07 |  |  |  | 2003-11-07 | 2003-11-07 | 0d | 56d | 0d |  | STEREO | IMPACT | SEP Package | SEP Package |  |  |
| 36 | 1.2.7.5.2.2 | Receive SEP Central FM 1 Logic Board for SEP FM 1 I & T | milestone | 0d | 2003-11-07 | 2003-11-07 | 35 |  |  | 2003-11-07 | 2003-11-07 | 0d | 56d |  |  | STEREO | IMPACT | SEP Package | SEP Package |  |  |
| 37 | 1.1.8.26 | Deliver Bench Tested SEP Cental FM 1 Analog/Post-Reg Board for SEP FM 1 I & T | milestone | 0d | 2003-11-20 | 2003-11-20 |  |  |  | 2003-11-20 | 2003-11-20 | 0d | 48d | 1d | finish no earlier than 2003-11-20 | STEREO | IMPACT | SEP Package | SEP Package |  |  |
| 38 | 1.2.7.5.2.4 | Receive SEP Central FM 1Analog/Post-Reg Board for SEP FM 1 I & T | milestone | 0d | 2003-11-21 | 2003-11-21 | 37 |  |  | 2003-11-21 | 2003-11-21 | 0d | 47d |  | finish no earlier than 2003-11-21 | STEREO | IMPACT | SEP Package | SEP Package |  |  |
| 39 | 1.1.8.32 | Deliver Bench Tested SEP Cental FM 1 SSD Bias Supply for SEP FM 1 I & T | milestone | 0d | 2003-12-15 | 2003-12-15 |  |  |  | 2003-12-15 | 2003-12-15 | 0d | 32d | 0d | finish no earlier than 2003-11-27 | STEREO | IMPACT | SEP Package | SEP Package |  |  |
| 40 | 1.2.7.5.2.6 | Receive SEP Central FM 1 SSD Bias Supply Board for SEP FM 1 I & T | milestone | 0d | 2003-12-15 | 2003-12-15 | 39 |  |  | 2003-12-15 | 2003-12-15 | 0d | 32d |  | finish no earlier than 2003-11-28 | STEREO | IMPACT | SEP Package | SEP Package |  |  |
| 41 | 1.1.8.20 | Deliver Bench Tested SEP Central FM 1 LVPS to SEP FM 1 I & T | milestone | 0d | 2004-01-30 | 2004-01-30 |  |  |  | 2004-01-29 | 2004-01-29 | 0d | 0d |  |  | STEREO | IMPACT | SEP Package | SEP Package |  |  |
| 42 | 1.2.7.5.2.8 | Receive SEP Central FM 1 Bench Tested LVPS for SEP FM 1 I & T | milestone | 0d | 2004-01-30 | 2004-01-30 | 41 |  |  | 2004-01-29 | 2004-01-29 | 0d | 1d |  |  | STEREO | IMPACT | SEP Package | SEP Package |  |  |
| 43 | 1.1.8.1 | Deliver SEP FM 1 Common Electronics Enclosure to CIT | milestone | 0d | 2003-10-30 | 2003-10-30 |  |  |  | 2003-10-30 | 2003-10-30 | 0d | 62.5d | 0d |  | STEREO | IMPACT | SEP Package | SEP Package |  |  |
| 44 | 1.2.7.5.2.10 | Receive SEP FM 1 Common Electronics Enclosure from GSFC | milestone | 0d | 2003-10-30 | 2003-10-30 | 43 |  |  | 2003-10-30 | 2003-10-30 | 0d | 62.5d |  |  | STEREO | IMPACT | SEP Package | SEP Cen | SEP DPU | CIT |
| 45 | 1.2.7.5.3 | **FM 2** |  | 100.5d | 2003-10-30 | 2004-03-26 |  |  |  | 2003-10-30 | 2004-03-25 | 99.5d | 14d |  |  | STEREO | IMPACT | SEP Package | SEP Package |  |  |
| 46 | 1.1.8.16 | Deliver SEP Central FM 2 Logic Board to SEP FM 2 I & T | milestone | 0d | 2003-11-07 | 2003-11-07 |  |  |  | 2003-11-07 | 2003-11-07 | 0d | 56d | 0d |  | STEREO | IMPACT | SEP Package | SEP Package |  |  |
| 47 | 1.2.7.5.3.2 | Receive SEP Central FM 2 Logic Board for SEP FM 2 I & T | milestone | 0d | 2003-11-07 | 2003-11-07 | 46 |  |  | 2003-11-07 | 2003-11-07 | 0d | 56d | 24d |  | STEREO | IMPACT | SEP Package | SEP Package |  |  |
| 48 | 1.1.8.28 | Deliver Bench Tested SEP Cental FM 2 Analog/Post-Reg Board for SEP FM 2 I & T | milestone | 0d | 2003-11-20 | 2003-11-20 |  |  |  | 2003-11-20 | 2003-11-20 | 0d | 48d | 1d | finish no earlier than 2003-11-20 | STEREO | IMPACT | SEP Package | SEP Package |  |  |
| 49 | 1.2.7.5.3.4 | Receive SEP Central FM 2Analog/Post-Reg Board for SEP FM 2 I & T | milestone | 0d | 2003-11-21 | 2003-11-21 | 48 |  |  | 2003-11-21 | 2003-11-21 | 0d | 47d | 15d | finish no earlier than 2003-11-21 | STEREO | IMPACT | SEP Package | SEP Package |  |  |
| 50 | 1.1.8.34 | Deliver Bench Tested SEP Cental FM 2 SSD Bias Supply for SEP FM 2 I & T | milestone | 0d | 2003-12-15 | 2003-12-15 |  |  |  | 2003-12-15 | 2003-12-15 | 0d | 32d | 0d | finish no earlier than 2003-11-27 | STEREO | IMPACT | SEP Package | SEP Package |  |  |
| 51 | 1.2.7.5.3.6 | Receive SEP Central FM 2 SSD Bias Supply Board for SEP FM 2 I & T | milestone | 0d | 2003-12-15 | 2003-12-15 | 50 |  |  | 2003-12-15 | 2003-12-15 | 0d | 32d | 0d | finish no earlier than 2003-11-28 | STEREO | IMPACT | SEP Package | SEP Package |  |  |
| 52 | 1.1.8.22 | Deliver Bench Tested SEP Central FM 2 LVPS to SEP FM 2 I & T | milestone | 0d | 2004-03-26 | 2004-03-26 |  |  |  | 2004-03-25 | 2004-03-25 | 0d | 14d | 0d |  | STEREO | IMPACT | SEP Package | SEP Package |  |  |
| 53 | 1.2.7.5.3.8 | Receive SEP Central FM 2 Bench Tested LVPS for SEP FM 2 I & T | milestone | 0d | 2004-03-26 | 2004-03-26 | 52 |  |  | 2004-03-25 | 2004-03-25 | 0d | 14d | 6d |  | STEREO | IMPACT | SEP Package | SEP Package |  |  |
| 54 | 1.1.8.3 | Deliver SEP FM 2 Common Electronics Enclosure to CIT | milestone | 0d | 2003-10-30 | 2003-10-30 |  |  |  | 2003-10-30 | 2003-10-30 | 0d | 62.5d | 0d |  | STEREO | IMPACT | SEP Package | SEP Package |  |  |
| 55 | 1.2.7.5.3.10 | Receive SEP FM 2 Common Electronics Enclosure from GSFC | milestone | 0d | 2003-10-30 | 2003-10-30 | 54 |  |  | 2003-10-30 | 2003-10-30 | 0d | 62.5d | 30.5d |  | STEREO | IMPACT | SEP Package | SEP Cen | SEP DPU | CIT |
| 56 | 1.2.7.6 | **HET** |  | 176d | 2003-07-08 A | 2004-03-19 |  |  | 176d | 2003-07-08 | 2004-03-19 | 176d | 8d |  |  | STEREO | IMPACT | SEP Package | SEP Package |  |  |
| 57 | 1.1.6.4 | Deliver HET EM to CIT | milestone | 0d | 2003-06-17 A | 2003-06-17 A |  | 100% |  | 2003-06-17 | 2003-06-17 | 0d |  |  | finish no later than 2003-05-30 | STEREO | IMPACT | SEP Package | SEP Package |  |  |
| 58 | 1.2.7.6.2 | Receive HET EM for SEP EM I & T | milestone | 0d | 2003-07-08 A | 2003-07-08 A | 57FS+5d | 100% |  | 2003-07-08 | 2003-07-08 | 0d |  |  | start no earlier than 2003-07-08 | STEREO | IMPACT | SEP Package | SEP Package |  |  |
| 59 | 1.1.6.8 | Deliver HET FM 1 for SEP I & T | milestone | 0d | 2004-02-27 | 2004-02-27 |  |  |  | 2004-02-18 | 2004-02-18 | 0d | 6d | 0d | start no earlier than 2004-02-27 | STEREO | IMPACT | SEP Package | SEP Package |  |  |
| 60 | 1.2.7.6.4 | Receive HET FM 1 From GSFC For SEP FM 1 I & T | milestone | 0d | 2004-03-04 | 2004-03-04 | 59FS+5d |  |  | 2004-02-25 | 2004-02-25 | 0d | 6d | 0d |  | STEREO | IMPACT | SEP Package | SEP Package | HET | CIT |
| 61 | 1.1.6.10 | Deliver HET FM 2 for SEP I & T | milestone | 0d | 2004-03-15 | 2004-03-15 |  |  |  | 2004-03-12 | 2004-03-12 | 0d | 0d |  | start no earlier than 2004-03-15 | STEREO | IMPACT | SEP Package | SEP Package |  |  |
| 62 | 1.2.7.6.6 | Receive HET FM 2 From GSFC For SEP FM 2 I & T | milestone | 0d | 2004-03-19 | 2004-03-19 | 61FS+5d |  |  | 2004-03-19 | 2004-03-19 | 0d | 8d | 0d |  | STEREO | IMPACT | SEP Package | SEP Package | HET | CIT |

| ID | WBS | Task | Type | Duration | Start | Finish | Predecessors | Complete | Remaining | Baseline start | Baseline finish | Baseline duration | Total slack | Free slack | Constraint | Text11 | Text12 | Text13 | Text14 | Text16 | Text28 | Text20 |
| --- | --- | --- | --- | --- | --- | --- | --- | --- | --- | --- | --- | --- | --- | --- | --- | --- | --- | --- | --- | --- | --- | --- |
| 63 | 1.2.7.7 | **LET** |  | 168d | 2003-07-02 A | 2004-03-05 |  |  | 168d | 2003-07-02 | 2004-03-05 | 168d | 223d |  |  | STEREO | IMPACT | SEP Package | SEP Package |  |  |  |
| 64 | 1.2.4.9 | Deliver LET S/W Build 2 | milestone | 0d | 2003-07-31 A | 2003-07-31 A |  | 100% |  | 2003-07-31 | 2003-07-31 | 0d |  |  |  | STEREO | IMPACT | SEP Package | SEP Package |  |  |  |
| 65 | 1.2.7.7.2 | Receive LET S/W Build 2 | milestone | 0d | 2003-07-02 A | 2003-07-02 A | 64 | 100% |  | 2003-07-02 | 2003-07-02 | 0d |  |  |  | STEREO | IMPACT | SEP Package | SEP Package | LET | CIT |  |
| 66 | 1.2.4.12 | Deliver LET S/W Build 3 | milestone | 0d | 2003-11-03 | 2003-11-03 |  |  |  | 2003-11-03 | 2003-11-03 | 0d | 78d | 0d |  | STEREO | IMPACT | SEP Package | SEP Package |  |  |  |
| 67 | 1.2.7.7.4 | Receive LET S/W Build 3 | milestone | 0d | 2003-11-03 | 2003-11-03 | 66 |  |  | 2003-11-03 | 2003-11-03 | 0d | 84d | 83d |  | STEREO | IMPACT | SEP Package | SEP Package | LET | CIT |  |
| 68 | 1.2.4.3 | Deliver LET EM to I & T | milestone | 0d | 2003-10-15 | 2003-10-15 |  |  |  | 2003-10-15 | 2003-10-15 | 0d | 284d | 0d |  | STEREO | IMPACT | SEP Package | SEP Package |  |  |  |
| 69 | 1.2.7.7.6 | Receive LET EM for SEP EM I & T | milestone | 0d | 2003-10-22 | 2003-10-22 | 68FS+5d |  |  | 2003-10-22 | 2003-10-22 | 0d | 314d |  | start no earlier than 2003-07-15 | STEREO | IMPACT | SEP Package | SEP Package |  |  |  |
| 70 | 1.2.4.5 | Deliver LET FM 1 to CIT For SEP I & T | milestone | 0d | 2004-02-27 | 2004-02-27 |  |  |  | 2004-02-27 | 2004-02-27 | 0d | 1d | 0d |  | STEREO | IMPACT | SEP Package | SEP Package |  |  |  |
| 71 | 1.2.7.7.8 | Receive LET FM 1 For SEP FM 1 I & T | milestone | 0d | 2004-03-05 | 2004-03-05 | 70FS+5d |  |  | 2004-03-05 | 2004-03-05 | 0d | 1d | 0d |  | STEREO | IMPACT | SEP Package | SEP Package | LET | CIT | LET |
| 72 | 1.2.4.7 | Deliver LET FM 2 to CIT For SEP I & T | milestone | 0d | 2004-02-27 | 2004-02-27 |  |  |  | 2004-02-27 | 2004-02-27 | 0d | 14d | 0d |  | STEREO | IMPACT | SEP Package | SEP Package |  |  |  |
| 73 | 1.2.7.7.10 | Receive LET FM 2 For SEP FM 2 I & T | milestone | 0d | 2004-03-05 | 2004-03-05 | 72FS+5d |  |  | 2004-03-05 | 2004-03-05 | 0d | 14d | 0d |  | STEREO | IMPACT | SEP Package | SEP Package | LET | CIT | LET |
| 74 | 1.2.7.8 | **SIT** |  | 165d | 2003-07-23 A | 2004-03-19 |  |  | 165d | 2003-07-23 | 2004-03-19 | 165d | 13d |  |  | STEREO | IMPACT | SEP Package | SEP Package |  |  |  |
| 75 | 1.1.3.21 | Deliver SIT EM to CIT | milestone | 0d | 2003-07-21 A | 2003-07-21 A |  | 100% |  | 2003-07-21 | 2003-07-21 | 0d |  |  | must start on 2003-06-13 | STEREO | IMPACT | SEP Package | SEP Package |  |  |  |
| 76 | 1.2.7.8.2 | Receive SIT EM From UMD For SEP EM I & T | milestone | 0d | 2003-07-23 A | 2003-07-23 A | 75FS+5d | 100% |  | 2003-07-23 | 2003-07-23 | 0d |  |  | start no earlier than 2003-06-30 | STEREO | IMPACT | SEP Package | SEP Package |  |  |  |
| 77 | 1.1.3.23 | Deliver SIT FM 1 to CIT For SEP I & T | milestone | 0d | 2004-03-02 | 2004-03-02 |  |  |  | 2004-03-02 | 2004-03-02 | 0d | 8d | 0d |  | STEREO | IMPACT | SEP Package | SEP Package |  |  |  |
| 78 | 1.2.7.8.4 | Receive SIT FM 1 From UMD For SEP FM 1 I & T | milestone | 0d | 2004-03-09 | 2004-03-09 | 77FS+5d |  |  | 2004-03-09 | 2004-03-09 | 0d | 8d | 0d |  | STEREO | IMPACT | SEP Package | SEP Package | SIT | CIT |  |
| 79 | 1.1.3.25 | Deliver SIT FM 2 to CIT For SEP I & T | milestone | 0d | 2004-03-12 | 2004-03-12 |  |  |  | 2004-03-12 | 2004-03-12 | 0d | 0d |  |  | STEREO | IMPACT | SEP Package | SEP Package |  |  |  |
| 80 | 1.2.7.8.6 | Receive SIT FM 2 From UMD For SEP FM 2 I & T | milestone | 0d | 2004-03-19 | 2004-03-19 | 79FS+5d |  |  | 2004-03-19 | 2004-03-19 | 0d | 13d | 0d |  | STEREO | IMPACT | SEP Package | SEP Package | SIT | CIT |  |
| 81 | 1.2.7.9 | **SEPT** |  | 130d | 2003-07-11 A | 2004-01-19 |  |  | 130d | 2003-07-11 | 2004-01-19 | 130d | 41d |  |  | STEREO | IMPACT | SEP Package | SEP Package |  |  |  |
| 82 | 1.3.5.2 | Deliver SEPT ETUElectronics to CIT | milestone | 0d | 2003-06-11 A | 2003-06-11 A |  | 100% |  | 2003-06-11 | 2003-06-11 | 0d |  |  | finish no earlier than 2003-06-11 | STEREO | IMPACT | SEP Package | SEP Package |  |  |  |
| 83 | 1.2.7.9.2 | Receive SEPT EM From Kiel For SEP EM I & T | milestone | 0d | 2003-07-11 A | 2003-07-11 A | 82 | 100% |  | 2003-07-11 | 2003-07-11 | 0d |  |  |  | STEREO | IMPACT | SEP Package | SEP Package |  |  |  |
| 84 | 1.3.5.12 | Deliver SEPT-NS FM 1 w/Brackets to CIT for SEP I & T | milestone | 0d | 2003-12-19 | 2003-12-19 |  |  |  | 2003-12-19 | 2003-12-19 | 0d | 13d | 0d |  | STEREO | IMPACT | SEP Package | SEP Package |  |  |  |
| 85 | 1.2.7.9.4 | Receive SEPT-NS w/Brackets FM 1 From Kiel For SEP FM 1 I & T | milestone | 0d | 2003-12-29 | 2003-12-29 | 84FS+5d |  |  | 2003-12-29 | 2003-12-29 | 0d | 41d | 0d |  | STEREO | IMPACT | SEP Package | SEP Package | SEPT | CIT |  |
| 86 | 1.3.5.14 | Deliver SEPT-E FM 1 to CIT for SEP I & T | milestone | 0d | 2003-12-19 | 2003-12-19 |  |  |  | 2003-12-19 | 2003-12-19 | 0d | 13d | 0d |  | STEREO | IMPACT | SEP Package | SEP Package |  |  |  |
| 87 | 1.2.7.9.6 | Receive SEPT-E FM 1 From Kiel For SEP FM 1 I & T | milestone | 0d | 2003-12-29 | 2003-12-29 | 86FS+5d |  |  | 2003-12-29 | 2003-12-29 | 0d | 41d | 0d |  | STEREO | IMPACT | SEP Package | SEP Package | SEPT | CIT |  |
| 88 | 1.3.5.16 | Deliver SEPT-NS FM 2 w/Brackets to CIT for SEP I & T | milestone | 0d | 2004-01-09 | 2004-01-09 |  |  |  | 2004-01-09 | 2004-01-09 | 0d | 0d |  |  | STEREO | IMPACT | SEP Package | SEP Package |  |  |  |
| 89 | 1.2.7.9.8 | Receive SEPT-NS w/Brackets FM 2 From Kiel For SEP FM 2 I & T | milestone | 0d | 2004-01-19 | 2004-01-19 | 88FS+5d |  |  | 2004-01-19 | 2004-01-19 | 0d | 41d | 0d |  | STEREO | IMPACT | SEP Package | SEP Package | SEPT | CIT |  |
| 90 | 1.3.5.18 | Deliver SEPT-E FM 2 to CIT for SEP I & T | milestone | 0d | 2004-01-09 | 2004-01-09 |  |  |  | 2004-01-09 | 2004-01-09 | 0d | 0d |  |  | STEREO | IMPACT | SEP Package | SEP Package |  |  |  |
| 91 | 1.2.7.9.10 | Receive SEPT-E FM 2 From Kiel For SEP FM 2 I & T | milestone | 0d | 2004-01-19 | 2004-01-19 | 90FS+5d |  |  | 2004-01-19 | 2004-01-19 | 0d | 41d | 0d |  | STEREO | IMPACT | SEP Package | SEP Package | SEPT | CIT |  |

| ID | WBS | Task | Type | Duration | Start | Finish | Predecessors | Complete | Remaining | Baseline start | Baseline finish | Baseline duration | Total slack | Free slack | Constraint | Text11 | Text12 | Text13 | Text14 | Text16 | Text28 | Text21 |
| --- | --- | --- | --- | --- | --- | --- | --- | --- | --- | --- | --- | --- | --- | --- | --- | --- | --- | --- | --- | --- | --- | --- |
| 92 | 1.2.7.10 | **IDPU** |  | 5d | 2003-04-30 A | 2003-05-08 |  |  | 5d | 2003-04-30 | 2003-05-08 | 5d | 430d |  |  | STEREO | IMPACT | SEP Package | SEP Package |  |  |  |
| 93 | 1.1.5.20 | Deliver ETU IDPU to CIT For SEP/IDPU I/F Test | milestone | 0d | 2003-05-08 A | 2003-05-08 A |  | 100% |  | 2003-05-08 | 2003-05-08 | 0d |  |  | finish no earlier than 2003-05-01 | STEREO | IMPACT | SEP Package | SEP Package |  |  |  |
| 94 | 1.2.7.10.2 | Receive ETU IDPU From UC-B For SEP ETU/IDPU ETU I/F Test | milestone | 0d | 2003-05-08 A | 2003-05-08 A | 93 | 100% |  | 2003-05-08 | 2003-05-08 | 0d |  |  | start no earlier than 2003-05-23 | STEREO | IMPACT | SEP Package | SEP Package | IDPU | CIT |  |
| 95 | 1.2.7.10.3 | Receive Flight IDPU From UC-B | milestone | 0d | 2003-04-30 | 2003-04-30 |  |  |  | 2003-04-30 | 2003-04-30 | 0d | 435d |  | start no earlier than 2003-04-30 | STEREO | IMPACT | SEP Package | SEP Package |  |  |  |
| 96 | 1.2.8 | **Deliverables** |  | 299d | 2003-05-09 A | 2004-07-16 |  |  | 299d | 2003-05-09 | 2004-07-16 | 299d | 120d |  |  | STEREO | IMPACT | SEP Package | SEP Package |  | CIT |  |
| 97 | 1.2.8.1 | Deliver SIT EM Back to UMD | milestone | 0d | 2003-08-01 A | 2003-08-01 A | 121 | 100% |  | 2003-08-01 | 2003-08-01 | 0d |  |  | start no earlier than 2003-06-30 | STEREO | IMPACT | SEP Package | SEP Package |  |  |  |
| 98 | 1.1.2.25 | Receive SIT EM Back from CIT | milestone | 0d | 2003-08-04 A | 2003-08-04 A | 97FS+5d | 100% |  | 2003-08-04 | 2003-08-04 | 0d |  |  |  | STEREO | IMPACT | SEP Package | SEP Package |  |  |  |
| 99 | 1.2.8.3 | Deliver SEPT EM Back to Kiel | milestone | 0d | 2003-09-11 A | 2003-09-11 A | 122 | 100% |  | 2003-09-11 | 2003-09-11 | 0d |  |  |  | STEREO | IMPACT | SEP Package | SEP Package |  |  |  |
| 100 | 1.3.4.11 | Receive SEPT ETU Back From CIT | milestone | 0d | 2003-07-02 A | 2003-07-02 A | 99FS+5d | 100% |  | 2003-07-02 | 2003-07-02 | 0d |  |  |  | STEREO | IMPACT | SEP Package | SEP Package |  |  |  |
| 101 | 1.2.8.5 | Deliver SEP FM 1 to UC-B for EMC Testing | milestone | 0d | 2004-04-30 | 2004-04-30 | 176, 8 |  |  | 2004-04-30 | 2004-04-30 | 0d | 19d | 0d |  | STEREO | IMPACT | SEP Package | SEP Package |  | CIT | Ready for EMC Test |
| 102 | 1.1.65.6 | Receive SEP Package FM 1 For EMC Testing | milestone | 0d | 2004-05-03 | 2004-05-03 | 101FS+1d |  |  | 2004-05-24 | 2004-05-24 | 0d | 19d | 9d |  | STEREO | IMPACT | SEP Package | SEP Package |  |  |  |
| 103 | 1.2.8.7 | Deliver SEP FM 2 to UC-B for EMC Testing | milestone | 0d | 2004-05-21 | 2004-05-21 | 10, 176 |  |  | 2004-05-21 | 2004-05-21 | 0d | 158d | 0d |  | STEREO | IMPACT | SEP Package | SEP Package |  |  |  |
| 104 | 1.1.65.8 | Receive SEP Package FM 2 For EMC Testing | milestone | 0d | 2004-05-21 | 2004-05-21 | 103 |  |  | 2004-05-21 | 2004-05-21 | 0d | 158d | 5d |  | STEREO | IMPACT | SEP Package | SEP Package |  |  |  |
| 105 | 1.2.8.9 | Deliver IDPU ETU to UC-B W/ SEP ETU/IDPU ETU I/F Test Results | milestone | 0d | 2003-05-09 A | 2003-05-09 A | 115 | 100% |  | 2003-05-09 | 2003-05-09 | 0d |  |  |  | STEREO | IMPACT | SEP Package | SEP Package | IDPU | CIT |  |
| 106 | 1.1.4.14 | Receive ETU IDPU Back From CIT SEP/IDPU I/F Test | milestone | 0d | 2003-05-09 A | 2003-05-09 A | 105 | 100% |  | 2003-05-09 | 2003-05-09 | 0d |  |  |  | STEREO | IMPACT | SEP Package | SEP Package |  |  |  |
| 107 | 1.2.8.11 | Deliver IDPU FM 1 to UC-B From SEP FM 1/ IDPU FM 1 Testing | milestone | 0d | 2004-04-30 | 2004-04-30 | 154 |  |  | 2004-04-30 | 2004-04-30 | 0d | 20d | 0d |  | STEREO | IMPACT | SEP Package | SEP Package | IDPU | CIT |  |
| 108 | 1.1.4.32 | Receive IDPU FM 2 From SEP Package/IDPU I & T | milestone | 0d | 2004-04-30 | 2004-04-30 | 107 |  |  | 2004-05-13 | 2004-05-13 | 0d | 20d | 0d |  | STEREO | IMPACT | SEP Package | SEP Package |  |  |  |
| 109 | 1.2.8.13 | SEP Package FM 1 Complete | milestone | 0d | 2004-07-01 | 2004-07-01 | 185 |  |  | 2004-07-01 | 2004-07-01 | 0d | 8d | 0d |  | STEREO | IMPACT | SEP Package | SEP Package |  |  |  |
| 110 | 1.1.3.2 | SEP Package FM 1 Ready For Delivery to APL | milestone | 0d | 2004-07-01 | 2004-07-01 | 109 |  |  | 2004-07-01 | 2004-07-01 | 0d | 8d | 0d |  | STEREO | IMPACT | SEP Package | SEP Package |  |  |  |
| 111 | 1.2.8.15 | SEP Package FM 2 Complete | milestone | 0d | 2004-07-16 | 2004-07-16 | 193 |  |  | 2004-07-16 | 2004-07-16 | 0d | 7d | 6d |  | STEREO | IMPACT | SEP Package | SEP Package |  |  |  |
| 112 | 1.1.3.4 | SEP Package FM 2 Ready For Delivery to APL | milestone | 0d | 2004-07-27 | 2004-07-27 | 111 |  |  | 2004-07-27 | 2004-07-27 | 0d | 1d | 0d | start no earlier than 2004-07-27 | STEREO | IMPACT | SEP Package | SEP Package |  |  |  |
| 113 | 2 | **Integration & Test** |  | 430d | 2003-05-08 A | 2005-01-25 |  | 3% | 418.7d | 2003-05-08 | 2005-01-21 | 428d | 0d |  |  | STEREO | IMPACT | SEP Package | SEP Package |  | CIT |  |
| 114 | 2.1 | **ETU** |  | 141d | 2003-05-08 A | 2003-11-28 |  | 48% | 72.77d | 2003-05-08 | 2003-11-28 | 141d | 52d |  |  | STEREO | IMPACT | SEP Package | SEP Package |  | CIT |  |
| 115 | 2.1.1 | Integrate/Test SEP Central Logic Board EM With IDPU |  | 2.5d | 2003-05-08 A | 2003-05-12 A | 214, 19, 23, 203, 213, 94 | 100% |  | 2003-05-08 | 2003-05-12 | 2.5d |  |  |  | STEREO | IMPACT | SEP Package | SEP Package |  |  |  |
| 116 | 6.1.5.1.2 | Test EM LET Detector Board (Final) |  | 19d | 2003-08-18 A | 2003-09-12 |  | 53% | 9d | 2003-08-18 | 2003-09-12 | 19d | 14d | 0d |  | STEREO | IMPACT | SEP Package | SEP Package |  |  |  |
| 117 | 2.1.3 | LET tel EM integration/documentation |  | 9d | 2003-11-17 | 2003-11-28 | 116 |  |  | 2003-11-17 | 2003-11-28 | 9d | 52d | 38d | start no earlier than 2003-11-17 | STEREO | IMPACT | SEP Package | SEP Package |  |  |  |
| 118 | 5.1.4.1.8 | Rework/Haywire/Trim EM Board |  | 2d | 2003-09-25 | 2003-09-26 |  |  |  | 2003-09-22 | 2003-09-23 | 2d | 26d | 0d |  | STEREO | IMPACT | SEP Package | SEP Package |  |  |  |
| 119 | 2.1.5 | Integrate/Test SEP Central EM Boards |  | 5d | 2003-09-29 | 2003-10-03 | 115, 23, 21, 118 |  |  | 2003-09-24 | 2003-09-30 | 5d | 33d | 0d |  | STEREO | IMPACT | SEP Package | SEP Package |  |  |  |
| 120 | 2.1.6 | Integrate/Test SEP Central EM with Sensors |  | 5d | 2003-10-07 | 2003-10-13 | 116, 119 |  |  | 2003-10-01 | 2003-10-08 | 5d | 33d | 0d |  | STEREO | IMPACT | SEP Package | SEP Package |  |  |  |
| 121 | 2.1.7 | Integrate/Test SIT EM |  | 5d | 2003-07-23 A | 2003-07-29 A | 76, 119 | 100% |  | 2003-07-23 | 2003-07-29 | 5d |  |  | start no earlier than 2003-06-30 | STEREO | IMPACT | SEP Package | SEP Package |  |  |  |
| 122 | 2.1.8 | Integrate/Test SEPT EM |  | 10d | 2003-08-27 A | 2003-09-11 A | 83, 119 | 100% |  | 2003-08-27 | 2003-09-11 | 10d |  |  |  | STEREO | IMPACT | SEP Package | SEP Package |  |  |  |
| 123 | 2.1.9 | Integrate/Test HET EM |  | 5d | 2003-07-08 A | 2003-07-14 A | 58, 119 | 100% |  | 2003-07-08 | 2003-07-14 | 5d |  |  |  | STEREO | IMPACT | SEP Package | SEP Package |  |  |  |
| 124 | 1.1.3.3.3 | Deliver SEP ETU LVPS to CIT | milestone | 0d | 2003-09-19 A | 2003-09-19 A |  | 100% |  | 2003-09-15 | 2003-09-15 | 0d |  |  | start no earlier than 2003-09-19 | STEREO | IMPACT | SEP Package | SEP Package |  |  |  |
| 125 | 2.1.11 | LVPS Compatibility Test |  | 5d | 2003-09-22 | 2003-09-26 | 27, 25, 124 |  |  | 2003-09-17 | 2003-09-23 | 5d | 43d | 10d |  | STEREO | IMPACT | SEP Package | SEP Package |  |  |  |

Notes:
- 101: FNL 5/17/04

| ID | WBS | Task | Type | Duration | Start | Finish | Predecessors | Baseline start | Baseline finish | Baseline duration | Total slack | Free slack | Constraint | Text11 | Text12 | Text13 | Text14 | Text28 |
| --- | --- | --- | --- | --- | --- | --- | --- | --- | --- | --- | --- | --- | --- | --- | --- | --- | --- | --- |
| 126 | 2.2 | **FM 1 & FM 2** |  | 176d | 2003-11-03 | 2004-07-15 |  | 2003-11-03 | 2004-07-13 | 174d | 75d |  |  | STEREO | IMPACT | SEP Package | SEP Package |  |
| 127 | 2.2.1 | Software Support For SEP Integration |  | 115d | 2004-02-03 | 2004-07-15 | 142SS | 2004-01-30 | 2004-07-13 | 115d | 131d |  |  | STEREO | IMPACT | SEP Package | SEP Package | CIT |
| 128 | 2.2.2 | Generate SEPT integration & test procedure |  | 5d | 2003-11-03 | 2003-11-07 |  | 2003-11-03 | 2003-11-07 | 5d | 75d | 47d | start no earlier than 2003-11-03 | STEREO | IMPACT | SEP Package | SEP Package | CIT |
| 129 | 2.2.3 | Generate LET integration & test procedure |  | 5d | 2004-02-10 | 2004-02-17 | 144FS-5d | 2004-02-06 | 2004-02-12 | 5d | 14d | 13d |  | STEREO | IMPACT | SEP Package | SEP Package | CIT |
| 130 | 2.2.4 | Generate HET integration & test procedure |  | 5d | 2004-03-08 | 2004-03-12 | 145FS-5d | 2004-03-08 | 2004-03-12 | 5d | 1d | 0d |  | STEREO | IMPACT | SEP Package | SEP Package | CIT |
| 131 | 2.2.5 | Generate SIT integration & test procedure |  | 5d | 2004-03-15 | 2004-03-19 | 147FS-5d | 2004-03-15 | 2004-03-19 | 5d | 1d | 0d |  | STEREO | IMPACT | SEP Package | SEP Package | CIT |
| 132 | 2.2.6 | Generate SEP system test procedure |  | 5d | 2004-03-22 | 2004-03-26 | 149FS-5d | 2004-03-22 | 2004-03-26 | 5d | 1d | 0d |  | STEREO | IMPACT | SEP Package | SEP Package | CIT |
| 133 | 2.2.7 | Software Support For Acceptance Testing of SEP Instruments |  | 25d | 2004-03-29 | 2004-04-30 | 151SS | 2004-03-29 | 2004-04-30 | 25d | 183d |  |  | STEREO | IMPACT | SEP Package | SEP Package | CIT |
| 134 | 2.2.8 | Generate SEP-IDPU integration procedure |  | 5d | 2004-03-29 | 2004-04-02 | 132 | 2004-03-29 | 2004-04-02 | 5d | 6d | 0d |  | STEREO | IMPACT | SEP Package | SEP Package | CIT |
| 135 | 2.2.9 | Generate SEP-IDPU test procedure |  | 5d | 2004-04-05 | 2004-04-09 | 134 | 2004-04-05 | 2004-04-09 | 5d | 6d | 5d |  | STEREO | IMPACT | SEP Package | SEP Package | CIT |
| 136 | 2.2.10 | Software Support of SEP Accelerator Tests |  | 20d | 2003-12-01 | 2003-12-29 | 174SS-10d | 2003-12-01 | 2003-12-29 | 20d | 269d |  |  | STEREO | IMPACT | SEP Package | SEP Package | CIT |
| 137 | 2.3 | **FM 1** |  | 269d | 2003-12-30 | 2005-01-25 |  | 2003-12-30 | 2005-01-21 | 267d | 0d |  |  | STEREO | IMPACT | SEP Package | SEP Package |  |
| 138 | 6.1.5.2.7 | LET FM 1 Detector Board Mass properties/photo |  | 1d | 2004-01-26 | 2004-01-26 |  | 2004-01-21 | 2004-01-21 | 1d | 14d | 0d |  | STEREO | IMPACT | SEP Package | SEP Package |  |
| 139 | 4.2.4.3.5 | Analyze Detector Testing Data |  | 75d | 2003-09-15 | 2004-01-02 |  | 2003-09-15 | 2004-01-02 | 75d | 1d | 0d |  | STEREO | IMPACT | SEP Package | SEP Package |  |
| 140 | 2.3.3 | LET tel flight 1 integration/documentation |  | 15d | 2004-01-27 | 2004-02-17 | 117, 174, 138, 139FS-20d | 2004-01-22 | 2004-02-11 | 15d | 14d | 0d |  | STEREO | IMPACT | SEP Package | SEP Package |  |
| 141 | 1.1.3 | SEP Central FM 1 Ready for I & T | milestone | 0d | 2004-02-02 | 2004-02-02 |  |  |  |  | 0d |  |  | STEREO | IMPACT | SEP Package | SEP Package |  |
| 142 | 2.3.5 | Integrate/test SEP Central FM 1 |  | 5d | 2004-02-03 | 2004-02-09 | 36, 38, 40, 203, 44, 42, 141 | 2004-01-30 | 2004-02-05 | 5d | 0d |  |  | STEREO | IMPACT | SEP Package | SEP Package |  |
| 143 | 2.3.6 | Receive & inspect SEPT FM 1 |  | 1d | 2003-12-30 | 2003-12-30 | 85, 87, 174 | 2003-12-30 | 2003-12-30 | 1d | 41d | 27d |  | STEREO | IMPACT | SEP Package | SEP Package |  |
| 144 | 2.3.7 | Integrate & test SEPT FM 1 |  | 5d | 2004-02-10 | 2004-02-17 | 128, 143, 142 | 2004-02-06 | 2004-02-12 | 5d | 14d | 0d |  | STEREO | IMPACT | SEP Package | SEP Package |  |
| 145 | 2.3.8 | Integrate & test LET FM 1 |  | 5d | 2004-03-08 | 2004-03-12 | 129, 71, 144, 67, 140 | 2004-03-08 | 2004-03-12 | 5d | 1d | 0d |  | STEREO | IMPACT | SEP Package | SEP Package |  |
| 146 | 2.3.9 | Receive & inspect HET FM 1 |  | 1d | 2004-03-05 | 2004-03-05 | 60 | 2004-02-26 | 2004-02-26 | 1d | 6d | 5d |  | STEREO | IMPACT | SEP Package | SEP Package |  |
| 147 | 2.3.10 | Integrate & test HET FM 1 |  | 5d | 2004-03-15 | 2004-03-19 | 130, 145, 146 | 2004-03-15 | 2004-03-19 | 5d | 1d | 0d |  | STEREO | IMPACT | SEP Package | SEP Package |  |
| 148 | 2.3.11 | Receive & inspect SIT FM 1 |  | 1d | 2004-03-10 | 2004-03-10 | 78 | 2004-03-10 | 2004-03-10 | 1d | 8d | 7d |  | STEREO | IMPACT | SEP Package | SEP Package |  |
| 149 | 2.3.12 | Integrate & test SIT FM 1 |  | 5d | 2004-03-22 | 2004-03-26 | 148, 147, 131 | 2004-03-22 | 2004-03-26 | 5d | 1d | 0d |  | STEREO | IMPACT | SEP Package | SEP Package |  |
| 150 | 9.1.1.4 | Final Flight S/W Build |  | 21d | 2003-12-01 | 2003-12-30 |  | 2003-12-01 | 2003-12-30 | 21d | 61d | 60d | start no earlier than 2003-12-01 | STEREO | IMPACT | SEP Package | SEP Package |  |
| 151 | 2.3.14 | SEP system test FM 1 |  | 10d | 2004-03-29 | 2004-04-09 | 132, 149, 150 | 2004-03-29 | 2004-04-09 | 10d | 1d | 0d |  | STEREO | IMPACT | SEP Package | SEP Package |  |
| 152 | 2.3.15 | Integrate SEP FM 1 - IDPU FM 1 |  | 5d | 2004-04-12 | 2004-04-16 | 134, 151 | 2004-04-12 | 2004-04-16 | 5d | 1d | 0d |  | STEREO | IMPACT | SEP Package | SEP Package |  |
| 153 | 2.3.16 | Test SEP FM 1 -IDPU |  | 5d | 2004-04-19 | 2004-04-23 | 152, 135 | 2004-04-19 | 2004-04-23 | 5d | 1d | 0d |  | STEREO | IMPACT | SEP Package | SEP Package |  |
| 154 | 2.3.17 | Rework SEP FM 1-IDPU issues and retest |  | 5d | 2004-04-26 | 2004-04-30 | 153 | 2004-04-26 | 2004-04-30 | 5d | 1d | 0d |  | STEREO | IMPACT | SEP Package | SEP Package |  |
| 155 | 2.3.18 | Maintain hard copy docs |  | 241d | 2004-02-10 | 2005-01-25 | 142 | 2004-02-06 | 2005-01-21 | 241d | 0d |  |  | STEREO | IMPACT | SEP Package | SEP Package |  |

| ID | WBS | Task | Type | Duration | Start | Finish | Predecessors | Baseline start | Baseline finish | Baseline duration | Total slack | Free slack | Constraint | Text11 | Text12 | Text13 | Text14 | Text28 | Text21 |
| --- | --- | --- | --- | --- | --- | --- | --- | --- | --- | --- | --- | --- | --- | --- | --- | --- | --- | --- | --- |
| 156 | 2.4 | **FM 2** |  | 246d | 2003-12-16 | 2004-12-07 |  | 2003-12-16 | 2004-12-07 | 246d | 32d |  |  | STEREO | IMPACT | SEP Package | SEP Package | CIT |  |
| 157 | 6.1.5.3.7 | LET FM 2 Detector Board Mass properties/photo |  | 1d | 2004-01-30 | 2004-01-30 |  | 2004-01-30 | 2004-01-30 | 1d | 28d | 0d |  | STEREO | IMPACT | SEP Package | SEP Package |  |  |
| 158 | 2.4.2 | LET tel flight 2 integration/documentation |  | 10d | 2004-02-18 | 2004-03-02 | 140, 157 | 2004-02-12 | 2004-02-26 | 10d | 17d | 3d |  | STEREO | IMPACT | SEP Package | SEP Package |  |  |
| 159 | 2.4.3 | Integrate/testSEP Central FM 2 |  | 5d | 2003-12-16 | 2003-12-22 | 203, 55, 47, 49, 51 | 2003-12-16 | 2003-12-22 | 5d | 32d | 0d |  | STEREO | IMPACT | SEP Package | SEP Package | CIT |  |
| 160 | 2.4.4 | Receive & inspect SEPT FM 2 |  | 1d | 2004-01-20 | 2004-01-20 | 89, 91, 174 | 2004-01-20 | 2004-01-20 | 1d | 41d | 0d |  | STEREO | IMPACT | SEP Package | SEP Package | CIT |  |
| 161 | 2.4.5 | Integrate & test SEPT FM 2 |  | 5d | 2004-01-21 | 2004-01-27 | 159, 160, 128 | 2004-01-21 | 2004-01-27 | 5d | 41d | 27d |  | STEREO | IMPACT | SEP Package | SEP Package | CIT | Begin I & T |
| 162 | 2.4.6 | Integrate & test LET FM 2 |  | 5d | 2004-03-08 | 2004-03-12 | 73, 129, 67, 161, 158 | 2004-03-08 | 2004-03-12 | 5d | 14d | 6d |  | STEREO | IMPACT | SEP Package | SEP Package | CIT |  |
| 163 | 2.4.7 | Receive & inspect HET FM 2 |  | 1d | 2004-03-22 | 2004-03-22 | 62 | 2004-03-22 | 2004-03-22 | 1d | 8d | 0d |  | STEREO | IMPACT | SEP Package | SEP Package | CIT |  |
| 164 | 2.4.8 | Integrate & test HET FM 2 |  | 5d | 2004-03-23 | 2004-03-29 | 130, 162, 163 | 2004-03-23 | 2004-03-29 | 5d | 8d | 0d |  | STEREO | IMPACT | SEP Package | SEP Package | CIT |  |
| 165 | 2.4.9 | Receive & inspect SIT FM 2 |  | 1d | 2004-03-22 | 2004-03-22 | 80 | 2004-03-22 | 2004-03-22 | 1d | 13d | 5d |  | STEREO | IMPACT | SEP Package | SEP Package | CIT |  |
| 166 | 2.4.10 | Integrate & test SIT FM 2 |  | 5d | 2004-03-30 | 2004-04-05 | 131, 165, 164, 149 | 2004-03-30 | 2004-04-05 | 5d | 8d | 0d |  | STEREO | IMPACT | SEP Package | SEP Package | CIT |  |
| 167 | 1.1.5 | SEP Central FM 2 Ready for I & T | milestone | 0d | 2004-03-26 | 2004-03-26 |  |  |  |  | 14d | 6d |  | STEREO | IMPACT | SEP Package | SEP Package |  |  |
| 168 | 2.4.12 | Integrate FM 2 LVPS into SEP Central (if necessary) |  | 2d | 2004-04-06 | 2004-04-07 | 53, 166, 167 | 2004-04-06 | 2004-04-07 | 2d | 8d | 0d |  | STEREO | IMPACT | SEP Package | SEP Package |  |  |
| 169 | 2.4.13 | SEP FM 2 system test |  | 10d | 2004-04-08 | 2004-04-21 | 168, 166 | 2004-04-08 | 2004-04-21 | 10d | 8d | 7d |  | STEREO | IMPACT | SEP Package | SEP Package | CIT | SEP System Test |
| 170 | 2.4.14 | Integrate SEP FM 2 -IDPU |  | 5d | 2004-05-03 | 2004-05-07 | 169, 134, 154 | 2004-05-03 | 2004-05-07 | 5d | 1d | 0d |  | STEREO | IMPACT | SEP Package | SEP Package | CIT |  |
| 171 | 2.4.15 | Test SEP FM 2 -IDPU |  | 5d | 2004-05-10 | 2004-05-14 | 170, 135 | 2004-05-10 | 2004-05-14 | 5d | 1d | 0d |  | STEREO | IMPACT | SEP Package | SEP Package | CIT |  |
| 172 | 2.4.16 | Rework SEP FM 2 -IDPU issues and retest |  | 5d | 2004-05-17 | 2004-05-21 | 171 | 2004-05-17 | 2004-05-21 | 5d | 1d | 0d |  | STEREO | IMPACT | SEP Package | SEP Package | CIT |  |
| 173 | 2.4.17 | Maintain hard copy docs |  | 241d | 2003-12-23 | 2004-12-07 | 159 | 2003-12-23 | 2004-12-07 | 241d | 32d |  |  | STEREO | IMPACT | SEP Package | SEP Package | CIT |  |
| 174 | 3 | LET/SEP Cen end-to-end test at Accelerator |  | 9d | 2003-12-15 | 2003-12-26 | 207 | 2003-12-15 | 2003-12-26 | 9d | 33d | 0d | start no earlier than 2003-12-15 | STEREO | IMPACT | SEP Package | SEP Package |  |  |
| 175 | 4 | **Environmental Test** |  | 249d | 2003-08-01 | 2004-07-28 |  | 2003-08-01 | 2004-07-28 | 249d | 34d |  |  | STEREO | IMPACT | SEP Package | SEP Package | CIT |  |
| 176 | 4.1 | Generate Environmental Test Procedures |  | 15d | 2003-08-01 | 2003-08-21 |  | 2003-08-01 | 2003-08-21 | 15d | 190d | 173d | start no earlier than 2003-08-01 | STEREO | IMPACT | SEP Package | SEP Package | CIT |  |
| 177 | 4.2 | Manufacture test cables (JPL) |  | 9d | 2004-02-09 | 2004-02-20 |  | 2004-02-09 | 2004-02-20 | 9d | 67d | 60d | start no earlier than 2004-02-09 | STEREO | IMPACT | SEP Package | SEP Package | CIT |  |
| 178 | 4.3 | **FM 1** |  | 51d | 2004-05-03 | 2004-07-14 |  | 2004-05-03 | 2004-07-14 | 51d | 7d |  |  | STEREO | IMPACT | SEP Package | SEP Package |  |  |
| 179 | 4.3.1 | FM 1 EMI/EMC Test at UCB |  | 10d | 2004-05-03 | 2004-05-14 | 154 | 2004-05-03 | 2004-05-14 | 10d | 7d | 0d |  | STEREO | IMPACT | SEP Package | SEP Package |  |  |
| 180 | 4.3.2 | FM 1 LET/HET/SEP Central Vibration/Acoustics Test |  | 10d | 2004-05-17 | 2004-05-28 | 176, 177, 174, 179 | 2004-05-17 | 2004-05-28 | 10d | 7d | 0d |  | STEREO | IMPACT | SEP Package | SEP Package |  |  |
| 181 | 4.3.3 | FM 1 LET/HET/SIT/SEPT/SEP Central Thermal Balance Test |  | 5d | 2004-06-01 | 2004-06-07 | 180 | 2004-06-01 | 2004-06-07 | 5d | 8d | 0d |  | STEREO | IMPACT | SEP Package | SEP Package |  |  |
| 182 | 4.3.4 | FM 1 LET/HET/SIT/SEP Central T/V Test |  | 15d | 2004-06-08 | 2004-06-28 | 181 | 2004-06-08 | 2004-06-28 | 15d | 8d | 0d |  | STEREO | IMPACT | SEP Package | SEP Package |  |  |
| 183 | 4.3.5 | Evaluate SEP performance |  | 10d | 2004-06-29 | 2004-07-13 | 182 | 2004-06-29 | 2004-07-13 | 10d | 35d | 0d |  | STEREO | IMPACT | SEP Package | SEP Package |  |  |
| 184 | 4.3.6 | Generate test reports |  | 11d | 2004-06-29 | 2004-07-14 | 183FS-10d | 2004-06-29 | 2004-07-14 | 11d | 35d |  | finish no later than 2004-09-01 | STEREO | IMPACT | SEP Package | SEP Package |  |  |
| 185 | 4.3.7 | Bakeout Clean SEP exterior & prepare for delivery |  | 3d | 2004-06-29 | 2004-07-01 | 182, 9 | 2004-06-29 | 2004-07-01 | 3d | 8d | 0d |  | STEREO | IMPACT | SEP Package | SEP Package |  |  |

Notes:
- 159: March 03 Status - Removed Predecessor of LVPS FM 2 to verify it is the driver of the suite.
- 176: 2003 May Status - Change the logic to have these procedures written in parallel with the I & T procedures of each instrument/component. The entire I & T areas of both the Boom Suite and SEP Package should be revisited.

| ID | WBS | Task | Type | Duration | Start | Finish | Predecessors | Complete | Remaining | Baseline start | Baseline finish | Baseline duration | Total slack | Free slack | Constraint | Text11 | Text12 | Text13 | Text14 | Text28 | Text20 |
| --- | --- | --- | --- | --- | --- | --- | --- | --- | --- | --- | --- | --- | --- | --- | --- | --- | --- | --- | --- | --- | --- |
| 186 | 4.4 | **FM 2** |  | 46d | 2004-05-24 | 2004-07-28 |  |  |  | 2004-05-24 | 2004-07-28 | 46d | 7d |  |  | STEREO | IMPACT | SEP Package | SEP Package |  |  |
| 187 | 4.4.1 | FM 2 EMI/EMC Test at CalTech |  | 5d | 2004-05-24 | 2004-05-28 | 172 |  |  | 2004-05-24 | 2004-05-28 | 5d | 7d | 0d |  | STEREO | IMPACT | SEP Package | SEP Package |  |  |
| 188 | 4.4.2 | FM 2 LET/HET/SEP Central Vibration/Acoustics Test |  | 10d | 2004-06-01 | 2004-06-14 | 180, 187 |  |  | 2004-06-01 | 2004-06-14 | 10d | 7d | 0d |  | STEREO | IMPACT | SEP Package | SEP Package |  |  |
| 189 | 4.4.3 | FM 2 LET/HET/SIT/SEPT/SEP Central Thermal Balance Test |  | 5d | 2004-06-15 | 2004-06-21 | 188 |  |  | 2004-06-15 | 2004-06-21 | 5d | 7d | 0d |  | STEREO | IMPACT | SEP Package | SEP Package |  |  |
| 190 | 4.4.4 | FM 2 LET/HET/SIT/SEP Central T/V Test |  | 15d | 2004-06-22 | 2004-07-13 | 189 |  |  | 2004-06-22 | 2004-07-13 | 15d | 7d | 0d |  | STEREO | IMPACT | SEP Package | SEP Package |  |  |
| 191 | 4.4.5 | Evaluate SEP performance |  | 10d | 2004-07-14 | 2004-07-27 | 190 |  |  | 2004-07-14 | 2004-07-27 | 10d | 34d | 0d |  | STEREO | IMPACT | SEP Package | SEP Package | CIT |  |
| 192 | 4.4.6 | Generate test reports |  | 11d | 2004-07-14 | 2004-07-28 | 191FS-10d |  |  | 2004-07-14 | 2004-07-28 | 11d | 34d |  | finish no later than 2004-09-15 | STEREO | IMPACT | SEP Package | SEP Package | CIT |  |
| 193 | 4.4.7 | Bakeout Clean SEP exterior & prepare for delivery |  | 3d | 2004-07-14 | 2004-07-16 | 190 |  |  | 2004-07-14 | 2004-07-16 | 3d | 7d | 0d |  | STEREO | IMPACT | SEP Package | SEP Package | CIT | Begin SEP Final I & T |
| 194 | 5 | **Emulators/Simulators/GSE** |  | 914d | 2001-03-01 A | 2004-10-18 |  | 58% | 380.07d | 2001-03-01 | 2004-10-18 | 914d | 66d |  |  | STEREO | IMPACT | SEP Package | SEP Package | CIT |  |
| 195 | 5.1 | **GSE** |  | 914d | 2001-03-01 A | 2004-10-18 |  | 58% | 380.07d | 2001-03-01 | 2004-10-18 | 914d | 66d |  |  | STEREO | IMPACT | SEP Package | SEP Package | CIT |  |
| 196 | 5.1.1 | GSE Release 1 Ready | milestone | 0d | 2003-05-30 A | 2003-07-10 | 214, 203 | 90% | 0d | 2003-05-30 | 2003-07-10 | 0d | 386.2d |  |  | STEREO | IMPACT | SEP Package | GSE | CIT |  |
| 197 | 5.1.2 | **Design hardware** |  | 655d | 2001-08-01 A | 2004-03-12 |  | 5% | 620.07d | 2001-08-01 | 2004-03-12 | 655d | 218d |  |  | STEREO | IMPACT | SEP Package | GSE | CIT |  |
| 198 | 5.1.2.1 | Initial GSE H/W Design |  | 3d | 2001-08-01 A | 2001-08-03 A |  | 100% |  | 2001-08-01 | 2001-08-03 | 3d |  |  | start no earlier than 2001-08-01 | STEREO | IMPACT | SEP Package | GSE | CIT |  |
| 199 | 5.1.2.2 | Final GSE H/W Design |  | 1d | 2002-12-02 A | 2002-12-02 A | 198FS+123d | 100% |  | 2002-12-02 | 2002-12-02 | 1d |  |  | start no earlier than 2002-11-30 | STEREO | IMPACT | SEP Package | GSE | CIT |  |
| 200 | 5.1.2.3 | GSE H/W Calibration equipment |  | 71d | 2003-12-01 | 2004-03-12 |  |  |  | 2003-12-01 | 2004-03-12 | 71d | 218d |  | start no earlier than 2003-12-01 | STEREO | IMPACT | SEP Package | GSE | CIT |  |
| 201 | 5.1.3 | **Assemble & test** |  | 1d | 2002-12-02 A | 2002-12-02 A |  | 100% |  | 2002-12-02 | 2002-12-02 | 1d |  |  |  | STEREO | IMPACT | SEP Package | SEP Package | CIT |  |
| 202 | 5.1.3.1 | Initial GSE H/W Assembly |  | 1d | 2002-12-02 A | 2002-12-02 A | 199FS+19d | 100% |  | 2002-12-02 | 2002-12-02 | 1d |  |  |  | STEREO | IMPACT | SEP Package | GSE | CIT |  |
| 203 | 5.1.3.2 | GSE H/W Test |  | 1d | 2002-12-02 A | 2002-12-02 A | 202FS+24d | 100% |  | 2002-12-02 | 2002-12-02 | 1d |  |  |  | STEREO | IMPACT | SEP Package | GSE | CIT |  |
| 204 | 5.1.4 | **End-to-End Test Equipment** |  | 81d | 2003-08-11 A | 2003-12-05 |  | 19% | 66d | 2003-08-11 | 2003-12-05 | 81d | 38d |  |  | STEREO | IMPACT | SEP Package | SEP Package |  |  |
| 205 | 5.1.4.1 | Design |  | 72d | 2003-08-11 A | 2003-11-21 |  | 21% | 57d | 2003-08-11 | 2003-11-21 | 72d | 38d | 0d | start no earlier than 2003-08-11 | STEREO | IMPACT | SEP Package | SEP Package |  |  |
| 206 | 5.1.4.2 | Assemble |  | 4d | 2003-11-24 | 2003-11-28 | 205 |  |  | 2003-11-24 | 2003-11-28 | 4d | 38d | 0d |  | STEREO | IMPACT | SEP Package | SEP Package |  |  |
| 207 | 5.1.4.3 | Test |  | 5d | 2003-12-01 | 2003-12-05 | 206 |  |  | 2003-12-01 | 2003-12-05 | 5d | 38d | 5d |  | STEREO | IMPACT | SEP Package | SEP Package |  |  |
| 208 | 5.1.5 | **GSE software** |  | 914d | 2001-03-01 A | 2004-10-18 |  | 68% | 291.89d | 2001-03-01 | 2004-10-18 | 914d | 66d |  |  | STEREO | IMPACT | SEP Package | SEP Package | CIT |  |
| 209 | 5.1.5.1 | Preliminary design activities |  | 189d | 2001-03-01 A | 2001-11-28 A |  | 100% |  | 2001-03-01 | 2001-11-28 | 189d |  |  | start no earlier than 2001-03-01 | STEREO | IMPACT | SEP Package | GSE | CIT |  |
| 210 | 5.1.5.2 | Write software development plan |  | 61d | 2001-09-04 A | 2001-11-30 A | 209SS+130d | 100% |  | 2001-09-04 | 2001-11-30 | 61d |  |  |  | STEREO | IMPACT | SEP Package | GSE | CIT |  |
| 211 | 5.1.5.3 | Initial s/w des & implementation of generic pieces |  | 98d | 2002-10-01 A | 2003-02-24 A | 210SS+10d | 100% |  | 2002-10-01 | 2003-02-24 | 98d |  |  | finish no earlier than 2003-02-24 | STEREO | IMPACT | SEP Package | GSE | CIT |  |
| 212 | 5.1.5.4 | Preparation for informal s/w reqs & des rev |  | 5d | 2002-05-13 A | 2002-05-17 A |  | 100% |  | 2002-05-13 | 2002-05-17 | 5d |  |  |  | STEREO | IMPACT | SEP Package | GSE | CIT |  |
| 213 | 5.1.5.5 | Write & Test Instrument Simulator S/W |  | 61d | 2002-12-03 A | 2003-05-14 A | 203 | 100% |  | 2002-12-03 | 2003-05-14 | 61d |  |  |  | STEREO | IMPACT | SEP Package | SEP Package |  |  |
| 214 | 5.1.5.6 | Finalize des & complete GSE release 1 |  | 68d | 2003-02-25 A | 2003-07-10 A | 211, 212 | 100% |  | 2003-02-25 | 2003-07-10 | 68d |  |  |  | STEREO | IMPACT | SEP Package | GSE | CIT |  |
| 215 | 5.1.5.7 | Write user's guide |  | 4d | 2003-10-01 | 2003-10-07 | 214 |  |  | 2003-10-01 | 2003-10-07 | 4d | 315d | 57d | start no earlier than 2003-10-01 | STEREO | IMPACT | SEP Package | GSE | CIT |  |
| 216 | 5.1.5.8 | Build GSE software release 2 |  | 113d | 2003-08-01 A | 2004-01-15 |  | 19% | 92d | 2003-08-01 | 2004-01-15 | 113d | 258d | 0d | start no earlier than 2003-08-01 | STEREO | IMPACT | SEP Package | GSE | CIT |  |
| 217 | 5.1.5.9 | Write user's guide supplement |  | 10d | 2003-12-31 | 2004-01-15 | 215, 216FS-10d |  |  | 2003-12-31 | 2004-01-15 | 10d | 258d |  |  | STEREO | IMPACT | SEP Package | GSE | CIT |  |
| 218 | 5.1.5.10 | Build GSE software release 3 |  | 130d | 2004-04-14 | 2004-10-18 | 109FS-56d |  |  | 2004-04-14 | 2004-10-18 | 130d | 66d |  |  | STEREO | IMPACT | SEP Package | GSE | CIT |  |

Notes:
- 193: EMC is a pred to this activity right now.
- 199: Reduced lag by 23 days on successor
- 211: In July we broke up build1 into initial and then final. so that we got back on track. finish this off. / Receive an e-mail from Alan on 11/25 breaking out the GSE, this should activity should finish 12/02 so I modified this for worst case ending on 12/31/02. Will modify it's successor to end on 5/30/03 based on the 11/25 e-mail.
- 214: Receive an e-mail from Alan on 11/25 breaking out the GSE, this activity should finish 5/30/03. Will modify it's predessor to end on 12/31/02 based on the 11/25 e-mail.
